# پروژه تقاطع غیرهمسطح میدان امام حسن (ع)

Schedule from MS Project, 2025-09-21 to 2026-12-20, status date 2026-01-08, costs in ه.ریال, A marks actual dates.

## Calendars

- Standard: Mon-Fri 08:00-12:00, 13:00-17:00; Sat-Sun 08:00-13:00, 14:00-17:00. Exceptions (off unless hours are given): 2025-11-24 (شهادت حضرت فاطمه زهرا (س)), 2026-01-03 (ولادت امام علی (ع)), 2026-01-17 (مبعث حضرت رسول اکرم (ص)), 2026-02-04 (ولادت حضرت قائم عج الله تعالی فرجه), 2026-02-11 (پیروزی انقلاب اسلامی), 2026-03-11 (شهادت امام علی (ع)), 2026-03-20 (روز ملی شدن صنعت نفت), 2026-03-21 to 2026-03-24 (تعطیلات نوروز), 2026-04-01 (روز جمهوری اسلامی ایران), 2026-04-02 (روز طبیعت), 2026-06-04 (رحلت امام خمینی), 2026-06-05 (قیام 15 خرداد).

## Resources

| Resource | Unit | Rate |
| --- | --- | --- |
| تجهیز اولیه | مقطوع | 115500000 |
| حفر چاه دستی | مترطول | 15000 |
| حفر چاه ماشینی | مترطول | 25000 |
| آرماتوربندی شمع | کیلوگرم | 292.5 |
| آرماتوربندی | کیلوگرم | 450 |
| آرماتوربندی دیواره | کیلوگرم | 450 |
| بتن ریزی | مترمکعب | 22000 |
| خاکبرداری | مترمکعب | 1500 |
| بغل تراشی خاک | مترمکعب | 3500 |
| روتبال و قطاعی | اصله | 16500 |
| قالب بندی | مترمربع | 6000 |
| زهکش | مترمربع | 6750 |
| ساخت قطعات پیش ساخته نما | مترمربع | 16400 |
| نصب قطعات پیش ساخته نما | مترمربع | 3600 |
| سرشمع و قرنیز | مترطول | 62850 |
| رگلاژ و بسترسازی | مترمربع | 500 |
| زیراساس | مترمربع | 600 |
| اساس | مترمربع | 900 |
| آسفالت | مترمربع | 3000 |
| پیاده رو | مترمربع | 5500 |
| نصب گاردریل | مترطول مسیر | 4500 |
| رنگ آمیزی مسیر | مترطول مسیر | 3000 |
| نصب پمپ | دستگاه | 2500000 |
| داربست بندی | مترمکعب | 500 |
| جدول و کانال بتنی | مترطول | 12500 |
| غلاف تاسیساتی | مترطول | 3855.6 |
| تاسیسات برقی سپتیک | مقطوع | 37817699 |
| تاسیسات مکانیکی سپتیک | مقطوع | 3940034 |
| لوله گذاری خروجی سپتیک | مترطول | 33437 |
| رنگ آمیزی مسیر دوچرخه | مترمربع | 4000 |
| خاکریزی | مترمکعب | 1500 |
| ساخت گاردریل | مترطول مسیر | 10500 |
| تخریب | مترطول مسیر | 6000 |
| ساخت قرنیز | مترطول | 900 |
| نصب آرماتوربندی شمع | کیلوگرم | 157.5 |
| اجرای فونداسیون | مترمکعب | 3500 |
| برچیدن | مقطوع | 77000000 |
| تجهیز مستمر | مقطوع | 2369230 |
| Ø10 | کیلوگرم |  |
| Ø12 | کیلوگرم |  |
| Ø14 | کیلوگرم |  |
| Ø16 | کیلوگرم |  |
| Ø18 | کیلوگرم |  |
| Ø25 | کیلوگرم |  |
| Ø32 | کیلوگرم |  |
| Ø20 | کیلوگرم |  |

## Schedule

| ID | WBS | Task | Type | Duration | Start | Finish | Predecessors | Complete | Remaining | Total slack | Free slack | Constraint | Resources | Cost | Actual cost | Text7 | Text8 | 1404.07.07 | 1404.07.14 | 1404.07.21 | 1404.07.28 | 1404.08.05 | 1404.08.12 | 1404.08.19 | 1404.08.26 | معارض | Activity Category | Task Category | Task Sub Category | Activity Type | نام پیمانکار |
| --- | --- | --- | --- | --- | --- | --- | --- | --- | --- | --- | --- | --- | --- | --- | --- | --- | --- | --- | --- | --- | --- | --- | --- | --- | --- | --- | --- | --- | --- | --- | --- |
| 1 | 1 | شروع پروژه | milestone | 0d | 2025-09-21 A | 2025-09-21 A |  | 100% |  |  |  |  |  |  |  | 0.00 | 0.00 | 100% | 100% | 100% | 100% | 100% | 100% | 100% | 100% | No |  |  |  |  |  |
| 2 | 2 | ابلاغ قرارداد | milestone | 0d | 2025-09-21 A | 2025-09-21 A |  | 100% |  |  |  |  |  |  |  | 0.00 | 0.00 | 100% | 100% | 100% | 100% | 100% | 100% | 100% | 100% | No |  |  |  |  |  |
| 3 | 3 | تحویل زمین | milestone | 0d | 2025-09-21 A | 2025-09-21 A |  | 100% |  |  |  |  |  |  |  |  |  | 100% | 100% | 100% | 100% | 100% | 100% | 100% | 100% | No |  |  |  |  |  |
| 4 | 4 | ابلاغ نقشه ها | milestone | 0d | 2025-09-21 A | 2025-09-21 A |  | 100% |  |  |  |  |  |  |  | 0.00 | 0.00 | 100% | 100% | 100% | 100% | 100% | 100% | 100% | 100% | No |  |  |  |  |  |
| 5 | 5 | **تجهیز کارگاه** |  | 405d | 2025-09-21 A | 2026-11-14 |  | 27% | 297d | 36d |  |  |  | 146,299,990 | 122,844,613 |  |  | 0% | 0% | 0% | 0% | 0% | 0% | 0% | 0% | No |  |  |  |  |  |
| 6 | 5.1 | تجهیز اولیه |  | 15d | 2025-09-21 A | 2025-10-05 A | 2, 4 | 100% |  |  |  |  | تجهیز اولیه [1 مقطوع] | 115,500,000 | 115,500,000 | 2.18 | 0.33 | 100% | 100% | 100% | 100% | 100% | 100% | 100% | 100% | No | تجهیز و برچیدن | تجهیز و برچیدن کارگاه | تجهیز اولیه |  |  |
| 7 | 5.2 | **تجهیز مستمر** |  | 390d | 2025-10-06 A | 2026-11-14 |  | 24% | 297d | 36d |  |  |  | 30,799,990 | 7,344,613 |  |  | 0% | 0% | 0% | 0% | 0% | 0% | 0% | 0% | No |  |  |  |  |  |
| 8 | 5.2.1 | تجهیز مستمر 1 |  | 30d | 2025-10-06 A | 2025-11-04 A | 6 | 100% |  |  |  | start no earlier than 2025-07-21 | تجهیز مستمر [1 مقطوع] | 2,369,230 | 2,369,230 | 0.04 | 0.68 | 0% | 7% | 27% | 50% | 73% | 97% | 100% | 100% | No | تجهیز و برچیدن | تجهیز و برچیدن کارگاه | تجهیز مستمر |  |  |
| 9 | 5.2.2 | تجهیز مستمر 2 |  | 30d | 2025-11-05 A | 2025-12-05 A | 8 | 100% |  |  |  | start no earlier than 2025-08-21 | تجهیز مستمر [1 مقطوع] | 2,369,230 | 2,369,230 | 0.04 | 0.68 | 0% | 0% | 0% | 0% | 0% | 0% | 20% | 30% | No | تجهیز و برچیدن | تجهیز و برچیدن کارگاه | تجهیز مستمر |  |  |
| 10 | 5.2.3 | تجهیز مستمر 3 |  | 30d | 2025-12-06 A | 2026-01-05 A | 9 | 100% |  |  |  | start no earlier than 2025-09-21 | تجهیز مستمر [1 مقطوع] | 2,369,230 | 2,369,230 | 0.04 | 0.68 | 0% | 0% | 0% | 0% | 0% | 0% | 0% | 0% | No | تجهیز و برچیدن | تجهیز و برچیدن کارگاه | تجهیز مستمر |  |  |
| 11 | 5.2.4 | تجهیز مستمر 4 |  | 30d | 2026-01-06 A | 2026-02-06 | 10 | 10% | 27d | 36d | 0d | start no earlier than 2025-10-22 | تجهیز مستمر [1 مقطوع] | 2,369,230 | 236,923 | 0.04 | 0.68 | 0% | 0% | 0% | 0% | 0% | 0% | 0% | 0% | No | تجهیز و برچیدن | تجهیز و برچیدن کارگاه | تجهیز مستمر |  |  |
| 12 | 5.2.5 | تجهیز مستمر 5 |  | 30d | 2026-02-07 | 2026-03-09 | 11 |  |  | 36d | 0d | start no earlier than 2025-11-21 | تجهیز مستمر [1 مقطوع] | 2,369,230 |  | 0.04 | 0.68 | 0% | 0% | 0% | 0% | 0% | 0% | 0% | 0% | No | تجهیز و برچیدن | تجهیز و برچیدن کارگاه | تجهیز مستمر |  |  |
| 13 | 5.2.6 | تجهیز مستمر 6 |  | 30d | 2026-03-10 | 2026-04-16 | 12 |  |  | 36d | 0d | start no earlier than 2025-12-21 | تجهیز مستمر [1 مقطوع] | 2,369,230 |  | 0.04 | 0.68 | 0% | 0% | 0% | 0% | 0% | 0% | 0% | 0% | No | تجهیز و برچیدن | تجهیز و برچیدن کارگاه | تجهیز مستمر |  |  |
| 14 | 5.2.7 | تجهیز مستمر 7 |  | 30d | 2026-04-17 | 2026-05-16 | 13 |  |  | 36d | 0d | start no earlier than 2026-01-20 | تجهیز مستمر [1 مقطوع] | 2,369,230 |  | 0.04 | 0.68 | 0% | 0% | 0% | 0% | 0% | 0% | 0% | 0% | No | تجهیز و برچیدن | تجهیز و برچیدن کارگاه | تجهیز مستمر |  |  |
| 15 | 5.2.8 | تجهیز مستمر 8 |  | 30d | 2026-05-17 | 2026-06-17 | 14 |  |  | 36d | 0d | start no earlier than 2026-02-19 | تجهیز مستمر [1 مقطوع] | 2,369,230 |  | 0.04 | 0.68 | 0% | 0% | 0% | 0% | 0% | 0% | 0% | 0% | No | تجهیز و برچیدن | تجهیز و برچیدن کارگاه | تجهیز مستمر |  |  |
| 16 | 5.2.9 | تجهیز مستمر 9 |  | 30d | 2026-06-18 | 2026-07-17 | 15 |  |  | 36d | 0d | start no earlier than 2026-03-20 | تجهیز مستمر [1 مقطوع] | 2,369,230 |  | 0.04 | 0.68 | 0% | 0% | 0% | 0% | 0% | 0% | 0% | 0% | No | تجهیز و برچیدن | تجهیز و برچیدن کارگاه | تجهیز مستمر |  |  |
| 17 | 5.2.10 | تجهیز مستمر 10 |  | 30d | 2026-07-18 | 2026-08-16 | 16 |  |  | 36d | 0d | start no earlier than 2026-04-19 | تجهیز مستمر [1 مقطوع] | 2,369,230 |  | 0.04 | 0.68 | 0% | 0% | 0% | 0% | 0% | 0% | 0% | 0% | No | تجهیز و برچیدن | تجهیز و برچیدن کارگاه | تجهیز مستمر |  |  |
| 18 | 5.2.11 | تجهیز مستمر 11 |  | 30d | 2026-08-17 | 2026-09-15 | 17 |  |  | 36d | 0d | start no earlier than 2026-05-20 | تجهیز مستمر [1 مقطوع] | 2,369,230 |  | 0.04 | 0.68 | 0% | 0% | 0% | 0% | 0% | 0% | 0% | 0% | No | تجهیز و برچیدن | تجهیز و برچیدن کارگاه | تجهیز مستمر |  |  |
| 19 | 5.2.12 | تجهیز مستمر 12 |  | 30d | 2026-09-16 | 2026-10-15 | 18 |  |  | 36d | 0d | start no earlier than 2026-06-20 | تجهیز مستمر [1 مقطوع] | 2,369,230 |  | 0.04 | 0.68 | 0% | 0% | 0% | 0% | 0% | 0% | 0% | 0% | No | تجهیز و برچیدن | تجهیز و برچیدن کارگاه | تجهیز مستمر |  |  |
| 20 | 5.2.13 | تجهیز مستمر 13 |  | 30d | 2026-10-16 | 2026-11-14 | 19 |  |  | 36d |  | start no earlier than 2026-07-21 | تجهیز مستمر [1 مقطوع] | 2,369,230 |  | 0.04 | 0.68 | 0% | 0% | 0% | 0% | 0% | 0% | 0% | 0% | No | تجهیز و برچیدن | تجهیز و برچیدن کارگاه | تجهیز مستمر |  |  |
| 21 | 6 | **کنارگذرها** |  | 438d | 2025-09-23 A | 2026-12-19 |  | 71% | 126.96d | 1d |  |  |  | 498,049,404.8 | 369,419,280.8 |  |  | 0% | 0% | 0% | 0% | 0% | 0% | 0% | 0% | No |  |  |  |  |  |
| 22 | 6.1 | **کنارگذر جنوب شرقی** |  | 438d | 2025-09-23 A | 2026-12-19 |  | 71% | 128.2d | 1d |  |  |  | 112,393,072 | 82,934,714.4 |  |  | 0% | 0% | 0% | 0% | 0% | 0% | 0% | 0% | No |  |  |  |  |  |
| 23 | 6.1.1 | عملیات روتبال و قطاعی (کنارگذر جنوب شرقی) |  | 4d | 2025-09-23 A | 2025-09-26 A | 2, 4, 6FS-13d | 100% |  |  |  |  | روتبال و قطاعی [266 اصله] | 4,389,000 | 4,389,000 | 0.08 | 0.09 | 100% | 92% | 100% | 100% | 100% | 100% | 100% | 100% | No | روتبال و قطاعی | کنارگذر | جنوب شرقی | اجرا | پیمانکار روتبال 1 |
| 24 | 6.1.2 | **احداث مسیر کنارگذر جنوب شرقی** |  | 39d | 2025-09-27 A | 2025-11-04 A |  | 100% |  |  |  |  |  | 78,545,714.4 | 78,545,714.4 |  |  | 0% | 0% | 0% | 0% | 0% | 0% | 0% | 0% | No |  |  |  |  |  |
| 25 | 6.1.2.1 | اجرای خاک برداری (کنارگذر جنوب شرقی) |  | 7d | 2025-09-27 A | 2025-10-03 A | 23 | 100% |  |  |  |  | خاکبرداری [13268 مترمکعب] | 19,902,000 | 19,902,000 | 0.38 | 0.16 | 95% | 95% | 95% | 95% | 95% | 95% | 95% | 100% | No | خاکبرداری | کنارگذر | جنوب شرقی | اجرا | پیمانکار خاکبرداری و خاکریزی 1 |
| 26 | 6.1.2.2 | اجرای خاک ریزی و بستر سازی (کنارگذر جنوب شرقی) |  | 8d | 2025-10-02 A | 2025-10-09 A | 25FS-2d | 100% |  |  |  |  | رگلاژ و بسترسازی [9653 مترمربع] | 4,826,500 | 4,826,500 | 0.09 | 0.18 | 87% | 87% | 87% | 87% | 87% | 87% | 87% | 90% | No | رگلاژ و بسترسازی | کنارگذر | جنوب شرقی | اجرا | پیمانکار خاکبرداری و خاکریزی 1 |
| 27 | 6.1.2.3 | اجرای غلاف تاسیساتی (کنارگذر جنوب شرقی) |  | 3d | 2025-10-08 A | 2025-10-10 A | 26FS-2d | 100% |  |  |  |  | غلاف تاسیساتی [74 مترطول] | 285,314.4 | 285,314.4 | 0.01 | 0.07 | 80% | 80% | 80% | 80% | 80% | 80% | 80% | 90% | No | غلاف تاسیساتی | کنارگذر | جنوب شرقی | اجرا | پیمانکار اجرای غلاف تاسیساتی 1 |
| 28 | 6.1.2.4 | اجرای زیر اساس (کنارگذر جنوب شرقی) |  | 10d | 2025-10-09 A | 2025-10-18 A | 26FS-1d | 100% |  |  |  |  | زیراساس [10242 مترمربع] | 6,145,200 | 6,145,200 | 0.12 | 0.22 | 80% | 80% | 80% | 80% | 80% | 80% | 80% | 80% | No | زیراساس | کنارگذر | جنوب شرقی | اجرا | پیمانکار آسفالت 1 |
| 29 | 6.1.2.5 | اجرای جدول گذاری و احداث کانال بتنی (کنارگذر جنوب شرقی) |  | 11d | 2025-10-16 A | 2025-10-26 A | 28FS-3d | 100% |  |  |  |  | جدول و کانال بتنی [637 مترطول] | 7,962,500 | 7,962,500 | 0.15 | 0.27 | 28% | 28% | 28% | 28% | 28% | 32% | 32% | 32% | No | جدول گذاری و کانال بتنی | کنارگذر | جنوب شرقی | اجرا | پیمانکار اجرای جدول و کانال بتنی 1 |
| 30 | 6.1.2.6 | اجرای اساس (کنارگذر جنوب شرقی) |  | 10d | 2025-10-23 A | 2025-11-01 A | 29FS-4d | 100% |  |  |  |  | اساس [10178 مترمربع] | 9,160,200 | 9,160,200 | 0.18 | 0.22 | 80% | 80% | 80% | 80% | 80% | 80% | 80% | 80% | No | اساس | کنارگذر | جنوب شرقی | اجرا | پیمانکار آسفالت 1 |
| 31 | 6.1.2.7 | اجرای آسفالت (کنارگذر جنوب شرقی) |  | 5d | 2025-10-31 A | 2025-11-04 A | 30FS-2d | 100% |  |  |  |  | آسفالت [10088 مترمربع] | 30,264,000 | 30,264,000 | 0.58 | 0.11 | 0% | 0% | 0% | 0% | 0% | 0% | 0% | 0% | No | آسفالت | کنارگذر | جنوب شرقی | اجرا | پیمانکار آسفالت 1 |

| ID | WBS | Task | Duration | Start | Finish | Predecessors | Complete | Remaining | Total slack | Free slack | Resources | Cost | Actual cost | 1404.07.07 | 1404.07.14 | 1404.07.21 | 1404.07.28 | 1404.08.05 | 1404.08.12 | 1404.08.19 | 1404.08.26 | معارض | Activity Category | Activity Type | Task Category | Task Sub Category | نام پیمانکار | Text7 | Text8 |
| --- | --- | --- | --- | --- | --- | --- | --- | --- | --- | --- | --- | --- | --- | --- | --- | --- | --- | --- | --- | --- | --- | --- | --- | --- | --- | --- | --- | --- | --- |
| 32 | 6.1.3 | **تکمیل مسیر کنارگذر جنوب شرقی** | 19d | 2026-12-01 | 2026-12-19 |  |  |  | 0d |  |  | 29,458,357.6 |  | 0% | 0% | 0% | 0% | 0% | 0% | 0% | 0% | No |  |  |  |  |  |  |  |
| 33 | 6.1.3.1 | جمع آوری مسیر انحراف موقت (کنارگذر جنوب شرقی) | 3d | 2026-12-01 | 2026-12-03 | 419, 469 |  |  | 0d |  | تخریب [1275 مترطول مسیر] | 7,650,000 |  | 0% | 0% | 0% | 0% | 0% | 0% | 0% | 0% | No | تخریب | اجرا | کنارگذر | جنوب شرقی | پیمانکار تخزیب و جمع آوری 1 | 0.15 | 0.07 |
| 34 | 6.1.3.2 | اجرای جداول جدا کننده پیاده رو و دوچرخه (کنارگذر جنوب شرقی) | 11d | 2026-12-03 | 2026-12-13 | 33FS-1d |  |  | 0d |  | جدول و کانال بتنی [1140 مترطول] | 14,250,000 |  | 0% | 0% | 0% | 0% | 0% | 0% | 0% | 0% | No | جدول گذاری و کانال بتنی | اجرا | کنارگذر | جنوب شرقی | پیمانکار اجرای جدول و کانال بتنی 1 | 0.27 | 0.31 |
| 35 | 6.1.3.3 | اجرای غلاف تاسیساتی (کنارگذر جنوب شرقی) | 2d | 2026-12-13 | 2026-12-14 | 34FS-1d |  |  | 0d |  | غلاف تاسیساتی [46 مترطول] | 177,357.6 |  | 0% | 0% | 0% | 0% | 0% | 0% | 0% | 0% | No | غلاف تاسیساتی | اجرا | کنارگذر | جنوب شرقی | پیمانکار اجرای غلاف تاسیساتی 1 | 0.00 | 0.04 |
| 36 | 6.1.3.4 | تکمیل روسازی (کنارگذر جنوب شرقی) | 2d | 2026-12-15 | 2026-12-16 | 35 |  |  | 0d |  | پیاده رو [272 مترمربع] | 1,496,000 |  | 0% | 0% | 0% | 0% | 0% | 0% | 0% | 0% | No | پیاده رو | اجرا | کنارگذر | جنوب شرقی | پیمانکار پیاده روسازی 1 | 0.03 | 0.07 |
| 37 | 6.1.3.5 | رنگ آمیزی مسیر دوچرخه (کنارگذر جنوب شرقی) | 2d | 2026-12-17 | 2026-12-18 | 36 |  |  | 2d |  | رنگ آمیزی مسیر دوچرخه [971 مترمربع] | 3,884,000 |  | 0% | 0% | 0% | 0% | 0% | 0% | 0% | 0% | No | رنگ آمیزی مسیر | اجرا | کنارگذر | جنوب شرقی | پیمانکار نصب علائم و رنگ آمیزی 1 | 0.07 | 0.04 |
| 38 | 6.1.3.6 | اجرای خط کشی مسیر و نصب علایم (کنارگذر جنوب شرقی) | 4d | 2026-12-16 | 2026-12-19 | 31, 36FS-1d |  |  | 0d |  | رنگ آمیزی مسیر [667 مترطول مسیر] | 2,001,000 |  | 0% | 0% | 0% | 0% | 0% | 0% | 0% | 0% | No | رنگ آمیزی مسیر | اجرا | کنارگذر | جنوب شرقی | پیمانکار نصب علائم و رنگ آمیزی 1 | 0.04 | 0.09 |
| 39 | 6.2 | **کنارگذر شمال شرقی** | 430d | 2025-09-27 A | 2026-12-15 |  | 70% | 128.44d | 5d |  |  | 105,964,528.8 | 79,836,214.4 | 0% | 0% | 0% | 0% | 0% | 0% | 0% | 0% | No |  |  |  |  |  |  |  |
| 40 | 6.2.1 | عملیات روتبال و قطاعی (کنارگذر شمال شرقی) | 4d | 2025-09-27 A | 2025-09-30 A | 23 | 100% |  |  |  | روتبال و قطاعی [240 اصله] | 3,960,000 | 3,960,000 | 30% | 60% | 90% | 95% | 100% | 99% | 100% | 100% | No | روتبال و قطاعی | اجرا | کنارگذر | شمال شرقی | پیمانکار روتبال 2 | 0.08 | 0.09 |
| 41 | 6.2.2 | **احداث مسیر کنارگذر شمال شرقی** | 35d | 2025-10-01 A | 2025-11-04 A |  | 100% |  |  |  |  | 75,876,214.4 | 75,876,214.4 | 0% | 0% | 0% | 0% | 0% | 0% | 0% | 0% | No |  |  |  |  |  |  |  |
| 42 | 6.2.2.1 | اجرای خاک برداری (کنارگذر شمال شرقی) | 6d | 2025-10-01 A | 2025-10-06 A | 40 | 100% |  |  |  | خاکبرداری [10987 مترمکعب] | 16,480,500 | 16,480,500 | 0% | 0% | 0% | 0% | 60% | 75% | 95% | 95% | Yes | خاکبرداری | اجرا | کنارگذر | شمال شرقی | پیمانکار خاکبرداری و خاکریزی 2 | 0.32 | 0.13 |
| 43 | 6.2.2.2 | اجرای خاک ریزی و بستر سازی (کنارگذر شمال شرقی) | 7d | 2025-10-05 A | 2025-10-11 A | 42FS-2d | 100% |  |  |  | رگلاژ و بسترسازی [9322 مترمربع] | 4,661,000 | 4,661,000 | 0% | 0% | 0% | 0% | 0% | 0% | 0% | 0% | No | رگلاژ و بسترسازی | اجرا | کنارگذر | شمال شرقی | پیمانکار خاکبرداری و خاکریزی 2 | 0.09 | 0.16 |
| 44 | 6.2.2.3 | اجرای غلاف تاسیساتی (کنارگذر شمال شرقی) | 3d | 2025-10-10 A | 2025-10-12 A | 43FS-2d | 100% |  |  |  | غلاف تاسیساتی [74 مترطول] | 285,314.4 | 285,314.4 | 0% | 0% | 0% | 0% | 0% | 0% | 0% | 50% | No | غلاف تاسیساتی | اجرا | کنارگذر | شمال شرقی | پیمانکار اجرای غلاف تاسیساتی 1 | 0.01 | 0.07 |
| 45 | 6.2.2.4 | اجرای زیر اساس (کنارگذر شمال شرقی) | 9d | 2025-10-11 A | 2025-10-19 A | 43FS-1d | 100% |  |  |  | زیراساس [10507 مترمربع] | 6,304,200 | 6,304,200 | 0% | 0% | 0% | 0% | 0% | 0% | 0% | 0% | No | زیراساس | اجرا | کنارگذر | شمال شرقی | پیمانکار آسفالت 2 | 0.12 | 0.20 |
| 46 | 6.2.2.5 | اجرای جدول گذاری و احداث کانال بتنی (کنارگذر شمال شرقی) | 11d | 2025-10-17 A | 2025-10-27 A | 45FS-3d | 100% |  |  |  | جدول و کانال بتنی [615 مترطول] | 7,687,500 | 7,687,500 | 0% | 0% | 0% | 0% | 0% | 0% | 0% | 0% | No | جدول گذاری و کانال بتنی | اجرا | کنارگذر | شمال شرقی | پیمانکار اجرای جدول و کانال بتنی 2 | 0.15 | 0.24 |
| 47 | 6.2.2.6 | اجرای اساس (کنارگذر شمال شرقی) | 9d | 2025-10-24 A | 2025-11-01 A | 46FS-4d | 100% |  |  |  | اساس [10443 مترمربع] | 9,398,700 | 9,398,700 | 0% | 0% | 0% | 0% | 0% | 0% | 0% | 0% | No | اساس | اجرا | کنارگذر | شمال شرقی | پیمانکار آسفالت 2 | 0.18 | 0.20 |
| 48 | 6.2.2.7 | اجرای آسفالت (کنارگذر شمال شرقی) | 5d | 2025-10-31 A | 2025-11-04 A | 47FS-2d | 100% |  |  |  | آسفالت [10353 مترمربع] | 31,059,000 | 31,059,000 | 0% | 0% | 0% | 0% | 0% | 0% | 0% | 0% | No | آسفالت | اجرا | کنارگذر | شمال شرقی | پیمانکار آسفالت 2 | 0.60 | 0.11 |
| 49 | 6.2.3 | **تکمیل مسیر کنارگذر شمال شرقی** | 15d | 2026-12-01 | 2026-12-15 |  |  |  | 4d |  |  | 26,128,314.4 |  | 0% | 0% | 0% | 0% | 0% | 0% | 0% | 0% | No |  |  |  |  |  |  |  |
| 50 | 6.2.3.1 | جمع آوری مسیر انحراف موقت (کنارگذر شمال شرقی) | 5d | 2026-12-01 | 2026-12-05 | 419, 469 |  |  | 4d | 0d | تخریب [1837 مترطول مسیر] | 11,022,000 |  | 0% | 0% | 0% | 0% | 0% | 0% | 0% | 0% | No | تخریب | اجرا | کنارگذر | شمال شرقی | پیمانکار تخزیب و جمع آوری 1 | 0.21 | 0.11 |
| 51 | 6.2.3.2 | اجرای جداول جدا کننده پیاده رو و دوچرخه (کنارگذر شمال شرقی) | 6d | 2026-12-05 | 2026-12-10 | 50FS-1d |  |  | 4d | 0d | جدول و کانال بتنی [615 مترطول] | 7,687,500 |  | 0% | 0% | 0% | 0% | 0% | 0% | 0% | 0% | No | جدول گذاری و کانال بتنی | اجرا | کنارگذر | شمال شرقی | پیمانکار اجرای جدول و کانال بتنی 2 | 0.15 | 0.20 |
| 52 | 6.2.3.3 | اجرای غلاف تاسیساتی (کنارگذر شمال شرقی) | 3d | 2026-12-09 | 2026-12-11 | 51FS-2d |  |  | 4d | 0d | غلاف تاسیساتی [74 مترطول] | 285,314.4 |  | 0% | 0% | 0% | 0% | 0% | 0% | 0% | 0% | No | غلاف تاسیساتی | اجرا | کنارگذر | شمال شرقی | پیمانکار اجرای غلاف تاسیساتی 1 | 0.01 | 0.07 |
| 53 | 6.2.3.4 | تکمیل روسازی (کنارگذر شمال شرقی) | 2d | 2026-12-09 | 2026-12-10 | 52FS-3d |  |  | 4d | 0d | پیاده رو [263 مترمربع] | 1,446,500 |  | 0% | 0% | 0% | 0% | 0% | 0% | 0% | 0% | No | پیاده رو | اجرا | کنارگذر | شمال شرقی | پیمانکار آرماتوربندی 2 | 0.03 | 0.11 |
| 54 | 6.2.3.5 | رنگ آمیزی مسیر دوچرخه (کنارگذر شمال شرقی) | 2d | 2026-12-11 | 2026-12-12 | 53 |  |  | 8d |  | رنگ آمیزی مسیر دوچرخه [938 مترمربع] | 3,752,000 |  | 0% | 0% | 0% | 0% | 0% | 0% | 0% | 0% | No | رنگ آمیزی مسیر | اجرا | کنارگذر | شمال شرقی | پیمانکار نصب علائم و رنگ آمیزی 1 | 0.07 | 0.04 |
| 55 | 6.2.3.6 | اجرای خط کشی مسیر و نصب علایم (کنارگذر شمال شرقی) | 5d | 2026-12-11 | 2026-12-15 | 48, 53 |  |  | 4d |  | رنگ آمیزی مسیر [645 مترطول مسیر] | 1,935,000 |  | 0% | 0% | 0% | 0% | 0% | 0% | 0% | 0% | No | رنگ آمیزی مسیر | اجرا | کنارگذر | شمال شرقی | پیمانکار نصب علائم و رنگ آمیزی 1 | 0.04 | 0.11 |

| ID | WBS | Task | Duration | Start | Finish | Predecessors | Complete | Remaining | Total slack | Free slack | Resources | Cost | Actual cost | 1404.07.07 | 1404.07.14 | 1404.07.21 | 1404.07.28 | 1404.08.05 | 1404.08.12 | 1404.08.19 | 1404.08.26 | معارض | Activity Category | Activity Type | Task Category | Task Sub Category | نام پیمانکار | Text7 | Text8 |
| --- | --- | --- | --- | --- | --- | --- | --- | --- | --- | --- | --- | --- | --- | --- | --- | --- | --- | --- | --- | --- | --- | --- | --- | --- | --- | --- | --- | --- | --- |
| 56 | 6.3 | **کنارگذر جنوب غربی** | 437d | 2025-09-23 A | 2026-12-18 |  | 71% | 128.8d | 2d |  |  | 141,922,452 | 105,170,726 | 0% | 0% | 0% | 0% | 0% | 0% | 0% | 0% | No |  |  |  |  |  |  |  |
| 57 | 6.3.1 | عملیات روتبال و قطاعی (کنارگذر جنوب غربی) | 4d | 2025-09-23 A | 2025-09-26 A | 2, 4, 6FS-13d | 100% |  |  |  | روتبال و قطاعی [230 اصله] | 3,795,000 | 3,795,000 | 100% | 100% | 100% | 100% | 100% | 100% | 100% | 100% | No | روتبال و قطاعی | اجرا | کنارگذر | جنوب غربی | پیمانکار روتبال 1 | 0.07 | 0.09 |
| 58 | 6.3.2 | **احداث مسیر کنارگذر جنوب غربی** | 44d | 2025-09-27 A | 2025-11-09 A |  | 100% |  |  |  |  | 101,375,726 | 101,375,726 | 0% | 0% | 0% | 0% | 0% | 0% | 0% | 0% | No |  |  |  |  |  |  |  |
| 59 | 6.3.2.1 | اجرای خاک برداری (کنارگذر جنوب غربی) | 6d | 2025-09-27 A | 2025-10-02 A | 57 | 100% |  |  |  | خاکبرداری [11681 مترمکعب] | 17,521,500 | 17,521,500 | 45% | 45% | 45% | 45% | 45% | 45% | 45% | 45% | Yes | خاکبرداری | اجرا | کنارگذر | جنوب غربی | پیمانکار خاکبرداری و خاکریزی 1 | 0.34 | 0.13 |
| 60 | 6.3.2.2 | اجرای خاک ریزی و بستر سازی (کنارگذر جنوب غربی) | 10d | 2025-09-30 A | 2025-10-09 A | 59FS-3d | 100% |  |  |  | رگلاژ و بسترسازی [13124 مترمربع] | 6,562,000 | 6,562,000 | 0% | 0% | 0% | 0% | 0% | 0% | 0% | 0% | No | رگلاژ و بسترسازی | اجرا | کنارگذر | جنوب غربی | پیمانکار خاکبرداری و خاکریزی 1 | 0.13 | 0.22 |
| 61 | 6.3.2.3 | اجرای غلاف تاسیساتی (کنارگذر جنوب غربی) | 4d | 2025-10-06 A | 2025-10-09 A | 60FS-4d | 100% |  |  |  | غلاف تاسیساتی [85 مترطول] | 327,726 | 327,726 | 0% | 0% | 0% | 0% | 0% | 0% | 0% | 0% | No | غلاف تاسیساتی | اجرا | کنارگذر | جنوب غربی | پیمانکار اجرای غلاف تاسیساتی 1 | 0.01 | 0.09 |
| 62 | 6.3.2.4 | اجرای زیر اساس (کنارگذر جنوب غربی) | 12d | 2025-10-08 A | 2025-10-19 A | 61FS-2d | 100% |  |  |  | زیراساس [14805 مترمربع] | 8,883,000 | 8,883,000 | 0% | 0% | 0% | 0% | 0% | 0% | 0% | 0% | No | زیراساس | اجرا | کنارگذر | جنوب غربی | پیمانکار آسفالت 1 | 0.17 | 0.27 |
| 63 | 6.3.2.5 | اجرای جدول گذاری و احداث کانال بتنی (کنارگذر جنوب غربی) | 13d | 2025-10-17 A | 2025-10-29 A | 62FS-3d | 100% |  |  |  | جدول و کانال بتنی [869 مترطول] | 10,862,500 | 10,862,500 | 0% | 0% | 0% | 0% | 0% | 0% | 0% | 0% | No | جدول گذاری و کانال بتنی | اجرا | کنارگذر | جنوب غربی | پیمانکار اجرای جدول و کانال بتنی 1 | 0.21 | 0.36 |
| 64 | 6.3.2.6 | اجرای اساس (کنارگذر جنوب غربی) | 12d | 2025-10-26 A | 2025-11-06 A | 63FS-4d | 100% |  |  |  | اساس [14740 مترمربع] | 13,266,000 | 13,266,000 | 0% | 0% | 0% | 0% | 0% | 0% | 0% | 0% | No | اساس | اجرا | کنارگذر | جنوب غربی | پیمانکار آسفالت 1 | 0.26 | 0.27 |
| 65 | 6.3.2.7 | اجرای آسفالت (کنارگذر جنوب غربی) | 6d | 2025-11-04 A | 2025-11-09 A | 64FS-3d | 100% |  |  |  | آسفالت [14651 مترمربع] | 43,953,000 | 43,953,000 | 0% | 0% | 0% | 0% | 0% | 0% | 0% | 0% | No | آسفالت | اجرا |  | جنوب غربی | پیمانکار آسفالت 1 | 0.85 | 0.13 |
| 66 | 6.3.3 | **تکمیل مسیر کنارگذر جنوب غربی** | 18d | 2026-12-01 | 2026-12-18 |  |  |  | 1d |  |  | 36,751,726 |  | 0% | 0% | 0% | 0% | 0% | 0% | 0% | 0% | No |  |  |  |  |  |  |  |
| 67 | 6.3.3.1 | جمع آوری مسیر انحراف موقت (کنارگذر جنوب غربی) | 5d | 2026-12-01 | 2026-12-05 | 419, 469 |  |  | 1d | 0d | تخریب [2598 مترطول مسیر] | 15,588,000 |  | 0% | 0% | 0% | 0% | 0% | 0% | 0% | 0% | No | تخریب | اجرا | کنارگذر | جنوب غربی | پیمانکار تخزیب و جمع آوری 1 | 0.30 | 0.11 |
| 68 | 6.3.3.2 | اجرای جداول جدا کننده پیاده رو و دوچرخه (کنارگذر جنوب غربی) | 8d | 2026-12-05 | 2026-12-12 | 67FS-1d |  |  | 1d | 0d | جدول و کانال بتنی [869 مترطول] | 10,862,500 |  | 0% | 0% | 0% | 0% | 0% | 0% | 0% | 0% | No | جدول گذاری و کانال بتنی | اجرا | کنارگذر | جنوب غربی | پیمانکار اجرای جدول و کانال بتنی 1 | 0.21 | 0.24 |
| 69 | 6.3.3.3 | اجرای غلاف تاسیساتی (کنارگذر جنوب غربی) | 4d | 2026-12-11 | 2026-12-14 | 68FS-2d |  |  | 1d | 0d | غلاف تاسیساتی [85 مترطول] | 327,726 |  | 0% | 0% | 0% | 0% | 0% | 0% | 0% | 0% | No | غلاف تاسیساتی | اجرا | کنارگذر | جنوب غربی | پیمانکار اجرای غلاف تاسیساتی 1 | 0.01 | 0.09 |
| 70 | 6.3.3.4 | تکمیل روسازی (کنارگذر جنوب غربی) | 3d | 2026-12-12 | 2026-12-14 | 69FS-3d |  |  | 1d | 0d | پیاده رو [365 مترمربع] | 2,007,500 |  | 0% | 0% | 0% | 0% | 0% | 0% | 0% | 0% | No | پیاده رو | اجرا | کنارگذر | جنوب غربی | پیمانکار پیاده روسازی 1 | 0.04 | 0.11 |
| 71 | 6.3.3.5 | رنگ آمیزی مسیر دوچرخه (کنارگذر جنوب غربی) | 3d | 2026-12-15 | 2026-12-17 | 70 |  |  | 3d |  | رنگ آمیزی مسیر دوچرخه [1318 مترمربع] | 5,272,000 |  | 0% | 0% | 0% | 0% | 0% | 0% | 0% | 0% | No | رنگ آمیزی مسیر | اجرا | کنارگذر | جنوب غربی | پیمانکار نصب علائم و رنگ آمیزی 1 | 0.10 | 0.07 |
| 72 | 6.3.3.6 | اجرای خط کشی مسیر و نصب علایم (کنارگذر جنوب غربی) | 5d | 2026-12-14 | 2026-12-18 | 65, 70FS-1d |  |  | 1d |  | رنگ آمیزی مسیر [898 مترطول مسیر] | 2,694,000 |  | 0% | 0% | 0% | 0% | 0% | 0% | 0% | 0% | No | رنگ آمیزی مسیر | اجرا | کنارگذر | جنوب غربی | پیمانکار نصب علائم و رنگ آمیزی 1 | 0.05 | 0.11 |
| 73 | 6.4 | **کنارگذر شمال غربی** | 432d | 2025-09-27 A | 2026-12-17 |  | 73% | 118.68d | 3d |  |  | 137,769,352 | 101,477,626 | 0% | 0% | 0% | 0% | 0% | 0% | 0% | 0% | No |  |  |  |  |  |  |  |
| 74 | 6.4.1 | عملیات روتبال و قطاعی (کنارگذر شمال غربی) | 3d | 2025-09-27 A | 2025-09-29 A | 57 | 100% |  |  |  | روتبال و قطاعی [200 اصله] | 3,300,000 | 3,300,000 | 0% | 0% | 0% | 0% | 0% | 0% | 0% | 45% | No | روتبال و قطاعی | اجرا | کنارگذر | شمال غربی | پیمانکار روتبال 2 | 0.06 | 0.07 |
| 75 | 6.4.2 | **احداث مسیر کنارگذر شمال غربی** | 45d | 2025-09-30 A | 2025-11-13 A |  | 100% |  |  |  |  | 98,177,626 | 98,177,626 | 0% | 0% | 0% | 0% | 0% | 0% | 0% | 0% | No |  |  |  |  |  |  |  |
| 76 | 6.4.2.1 | اجرای خاک برداری (کنارگذر شمال غربی) | 6d | 2025-09-30 A | 2025-10-05 A | 74 | 100% |  |  |  | خاکبرداری [10259 مترمکعب] | 15,388,500 | 15,388,500 | 0% | 0% | 0% | 0% | 0% | 0% | 0% | 0% | No | خاکبرداری | اجرا | کنارگذر | شمال غربی | پیمانکار خاکبرداری و خاکریزی 2 | 0.30 | 0.13 |
| 77 | 6.4.2.2 | اجرای خاک ریزی و بستر سازی (کنارگذر شمال غربی) | 10d | 2025-10-04 A | 2025-10-13 A | 76FS-2d | 100% |  |  |  | رگلاژ و بسترسازی [12959 مترمربع] | 6,479,500 | 6,479,500 | 0% | 0% | 0% | 0% | 0% | 0% | 0% | 0% | No | رگلاژ و بسترسازی | اجرا | کنارگذر | شمال غربی | پیمانکار خاکبرداری و خاکریزی 2 | 0.12 | 0.22 |
| 78 | 6.4.2.3 | اجرای غلاف تاسیساتی (کنارگذر شمال غربی) | 4d | 2025-10-10 A | 2025-10-13 A | 77FS-4d | 100% |  |  |  | غلاف تاسیساتی [85 مترطول] | 327,726 | 327,726 | 0% | 0% | 0% | 0% | 0% | 0% | 0% | 0% | No | غلاف تاسیساتی | اجرا | کنارگذر | شمال غربی | پیمانکار اجرای غلاف تاسیساتی 1 | 0.01 | 0.09 |
| 79 | 6.4.2.4 | اجرای زیر اساس (کنارگذر شمال غربی) | 12d | 2025-10-11 A | 2025-10-22 A | 77FS-3d | 100% |  |  |  | زیراساس [14617 مترمربع] | 8,770,200 | 8,770,200 | 0% | 0% | 0% | 0% | 0% | 0% | 0% | 0% | No | زیراساس | اجرا | کنارگذر | شمال غربی | پیمانکار آسفالت 2 | 0.17 | 0.27 |
| 80 | 6.4.2.5 | اجرای جدول گذاری و احداث کانال بتنی (کنارگذر شمال غربی) | 13d | 2025-10-20 A | 2025-11-01 A | 79FS-3d | 100% |  |  |  | جدول و کانال بتنی [858 مترطول] | 10,725,000 | 10,725,000 | 0% | 0% | 0% | 0% | 0% | 0% | 0% | 0% | No | جدول گذاری و کانال بتنی | اجرا | کنارگذر | شمال غربی | پیمانکار اجرای جدول و کانال بتنی 2 | 0.21 | 0.36 |
| 81 | 6.4.2.6 | اجرای اساس (کنارگذر شمال غربی) | 12d | 2025-10-29 A | 2025-11-09 A | 80FS-4d | 100% |  |  |  | اساس [14553 مترمربع] | 13,097,700 | 13,097,700 | 0% | 0% | 0% | 0% | 0% | 0% | 0% | 0% | No | اساس | اجرا | کنارگذر | شمال غربی | پیمانکار آسفالت 2 | 0.25 | 0.27 |
| 82 | 6.4.2.7 | اجرای آسفالت (کنارگذر شمال غربی) | 6d | 2025-11-08 A | 2025-11-13 A | 81FS-2d | 100% |  |  |  | آسفالت [14463 مترمربع] | 43,389,000 | 43,389,000 | 0% | 0% | 0% | 0% | 0% | 0% | 0% | 0% | No | آسفالت | اجرا | کنارگذر | شمال غربی | پیمانکار آسفالت 2 | 0.83 | 0.13 |

| ID | WBS | Task | Duration | Start | Finish | Predecessors | Complete | Remaining | Total slack | Free slack | Resources | Cost | Actual cost | 1404.07.07 | 1404.07.14 | 1404.07.21 | 1404.07.28 | 1404.08.05 | 1404.08.12 | 1404.08.19 | 1404.08.26 | معارض | Activity Category | Activity Type | Task Category | Task Sub Category | نام پیمانکار | Text7 | Text8 |
| --- | --- | --- | --- | --- | --- | --- | --- | --- | --- | --- | --- | --- | --- | --- | --- | --- | --- | --- | --- | --- | --- | --- | --- | --- | --- | --- | --- | --- | --- |
| 83 | 6.4.3 | **تکمیل مسیر کنارگذر شمال غربی** | 17d | 2026-12-01 | 2026-12-17 |  |  |  | 2d |  |  | 36,291,726 |  | 0% | 0% | 0% | 0% | 0% | 0% | 0% | 0% | No |  |  |  |  |  |  |  |
| 84 | 6.4.3.1 | جمع آوری مسیر انحراف موقت (کنارگذر شمال غربی) | 4d | 2026-12-01 | 2026-12-04 | 419, 469 |  |  | 2d | 0d | تخریب [2565 مترطول مسیر] | 15,390,000 |  | 0% | 0% | 0% | 0% | 0% | 0% | 0% | 0% | No | تخریب | اجرا | کنارگذر | شمال غربی | پیمانکار تخزیب و جمع آوری 1 | 0.30 | 0.09 |
| 85 | 6.4.3.2 | اجرای جداول جدا کننده پیاده رو و دوچرخه (کنارگذر شمال غربی) | 8d | 2026-12-04 | 2026-12-11 | 84FS-1d |  |  | 2d | 0d | جدول و کانال بتنی [858 مترطول] | 10,725,000 |  | 0% | 0% | 0% | 0% | 0% | 0% | 0% | 0% | No | جدول گذاری و کانال بتنی | اجرا | کنارگذر | شمال غربی | پیمانکار اجرای جدول و کانال بتنی 2 | 0.21 | 0.24 |
| 86 | 6.4.3.3 | اجرای غلاف تاسیساتی (کنارگذر شمال غربی) | 4d | 2026-12-10 | 2026-12-13 | 85FS-2d |  |  | 2d | 0d | غلاف تاسیساتی [85 مترطول] | 327,726 |  | 0% | 0% | 0% | 0% | 0% | 0% | 0% | 0% | No | غلاف تاسیساتی | اجرا | کنارگذر | شمال غربی | پیمانکار اجرای غلاف تاسیساتی 1 | 0.01 | 0.09 |
| 87 | 6.4.3.4 | تکمیل روسازی (کنارگذر شمال غربی) | 3d | 2026-12-11 | 2026-12-13 | 86FS-3d |  |  | 2d | 0d | پیاده رو [360 مترمربع] | 1,980,000 |  | 0% | 0% | 0% | 0% | 0% | 0% | 0% | 0% | No | پیاده رو | اجرا | کنارگذر | شمال غربی | پیمانکار آرماتوربندی 2 | 0.04 | 0.11 |
| 88 | 6.4.3.5 | رنگ آمیزی مسیر دوچرخه (کنارگذر شمال غربی) | 2d | 2026-12-14 | 2026-12-15 | 87 |  |  | 5d |  | رنگ آمیزی مسیر دوچرخه [1302 مترمربع] | 5,208,000 |  | 0% | 0% | 0% | 0% | 0% | 0% | 0% | 0% | No | رنگ آمیزی مسیر | اجرا | کنارگذر | شمال غربی | پیمانکار نصب علائم و رنگ آمیزی 1 | 0.10 | 0.04 |
| 89 | 6.4.3.6 | اجرای خط کشی مسیر و نصب علایم (کنارگذر شمال غربی) | 4d | 2026-12-14 | 2026-12-17 | 82, 87 |  |  | 2d |  | رنگ آمیزی مسیر [887 مترطول مسیر] | 2,661,000 |  | 0% | 0% | 0% | 0% | 0% | 0% | 0% | 0% | No | رنگ آمیزی مسیر | اجرا | کنارگذر | شمال غربی | پیمانکار نصب علائم و رنگ آمیزی 1 | 0.05 | 0.09 |
| 90 | 7 | **احداث پل های شرقی و غربی** | 319d | 2025-09-26 A | 2026-08-25 |  | 39% | 193.04d | 117d |  |  | 2,498,556,215 | 863,972,248.74 | 0% | 0% | 0% | 0% | 0% | 0% | 0% | 0% | No |  |  |  |  |  |  |  |
| 91 | 7.1 | **احداث پل های شرقی** | 185d | 2025-09-26 A | 2026-04-11 |  | 68% | 59.38d | 251d |  |  | 974,991,285 | 638,881,320 | 0% | 0% | 0% | 0% | 0% | 0% | 0% | 0% | No |  |  |  |  |  |  |  |
| 92 | 7.1.1 | **اجرای شمع های بتنی (پل های شرقی)** | 136d | 2025-09-26 A | 2026-02-13 |  | 90% | 12.97d | 300d |  |  | 695,852,385 | 638,881,320 | 0% | 0% | 0% | 0% | 0% | 0% | 0% | 0% | No |  |  |  |  |  |  |  |
| 93 | 7.1.1.1 | **اجرای شمع های بتنی (ضلع شمالی پل های شرقی)** | 136d | 2025-09-26 A | 2026-02-13 |  | 84% | 22.12d | 300d |  |  | 347,861,410 | 305,039,545 | 0% | 0% | 0% | 0% | 0% | 0% | 0% | 0% | No |  |  |  |  |  |  |  |
| 94 | 7.1.1.1.1 | **اجرای شمع های بتنی W7-P1~58 (ضلع شمالی پل های شرقی)** | 68d | 2025-09-26 A | 2025-12-03 A |  | 100% |  |  |  |  | 44,249,547.5 | 44,249,547.5 | 0% | 0% | 0% | 0% | 0% | 0% | 0% | 0% | No |  |  |  |  |  |  |  |
| 95 | 7.1.1.1.1.1 | حفاری شمع های بتنی W7-P1~58 (ضلع شمالی پل های شرقی) | 27d | 2025-11-05 A | 2025-12-02 A | 48 | 100% |  |  |  | حفر چاه دستی [657 مترطول] | 9,855,000 | 9,855,000 | 0% | 0% | 0% | 0% | 0% | 0% | 0% | 0% | No | حفر چاه دستی | اجرا | روگذر | ضلع جنوب پل های شرقی | پیمانکار حفاری دستی 1 | 0.19 | 0.62 |
| 96 | 7.1.1.1.1.2 | پیش ساخت آرماتور شمع های بتنی W7-P1~58 (ضلع شمالی پل های شرقی) | 11d | 2025-09-26 A | 2025-10-06 A | 6FS-10d | 100% |  |  |  | آرماتوربندی شمع [57326 کیلوگرم]; Ø12 [8420.36 کیلوگرم]; Ø20 [16598.9 کیلوگرم]; Ø25 [24670.8 کیلوگرم] | 16,767,855 | 16,767,855 | 17% | 24% | 24% | 27% | 32% | 36% | 39% | 39% | No | آرماتوربندی | پیش ساخت | روگذر | ضلع جنوب پل های شرقی | پیمانکار آرماتوربندی 1 | 0.32 | 0.24 |
| 97 | 7.1.1.1.1.3 | نصب آرماتور شمع های بتنی W7-P1~58 (ضلع شمالی پل های شرقی) | 5d | 2025-11-27 A | 2025-12-01 A | 96, 95FS-6d | 100% |  |  |  | نصب آرماتوربندی شمع [57579 کیلوگرم] | 9,068,692.5 | 9,068,692.5 | 0% | 0% | 0% | 0% | 0% | 0% | 0% | 0% | No | آرماتوربندی | نصب | روگذر | ضلع جنوب پل های شرقی | پیمانکار آرماتوربندی 1 | 0.17 | 0.11 |
| 98 | 7.1.1.1.1.4 | بتن ریزی شمع های بتنی W7-P1~58 (ضلع شمالی پل های شرقی) | 3d | 2025-12-01 A | 2025-12-03 A | 97FS-1d | 100% |  |  |  | بتن ریزی [389 مترمکعب] | 8,558,000 | 8,558,000 | 0% | 0% | 0% | 0% | 0% | 0% | 0% | 0% | No | بتن ریزی | اجرا | روگذر | ضلع جنوب پل های شرقی | پیمانکار بتن ریزی 1 | 0.16 | 0.07 |
| 99 | 7.1.1.1.2 | **اجرای شمع های بتنی محور A2-P43~67 (ضلع شمالی پل های شرقی)** | 94d | 2025-10-07 A | 2026-01-10 |  | 98% | 2.09d | 300d |  |  | 92,015,345 | 85,397,745 | 0% | 0% | 0% | 0% | 0% | 0% | 0% | 0% | No |  |  |  |  |  |  |  |
| 100 | 7.1.1.1.2.1 | حفاری شمع های بتنی A2-P43~67 (ضلع شمالی پل های شرقی) | 20d | 2025-11-26 A | 2025-12-15 A | 139 | 100% |  |  |  | حفر چاه ماشینی [666 مترطول] | 16,650,000 | 16,650,000 | 0% | 0% | 0% | 0% | 0% | 0% | 0% | 0% | No | حفر چاه ماشینی | اجرا | روگذر | ضلع جنوب پل های شرقی | پیمانکار حفر ماشینی 2 | 0.32 | 0.45 |
| 101 | 7.1.1.1.2.2 | پیش ساخت آرماتور شمع های بتنی A2-P43~67 (ضلع شمالی پل های شرقی) | 40d | 2025-10-07 A | 2025-11-15 A | 96 | 100% |  |  |  | آرماتوربندی شمع [130663 کیلوگرم]; Ø12 [33316 کیلوگرم]; Ø20 [10919.3 کیلوگرم]; Ø25 [60928.6 کیلوگرم] | 38,218,927.5 | 38,218,927.5 | 0% | 0% | 0% | 0% | 0% | 0% | 0% | 0% | No | آرماتوربندی | پیش ساخت | روگذر | ضلع جنوب پل های شرقی | پیمانکار آرماتوربندی 1 | 0.73 | 0.89 |
| 102 | 7.1.1.1.2.3 | نصب آرماتور شمع های بتنی A2-P43~67 (ضلع شمالی پل های شرقی) | 25d | 2025-12-14 A | 2026-01-08 A | 100FS-2d, 101FS-7d | 100% |  |  |  | نصب آرماتوربندی شمع [130809 کیلوگرم] | 20,602,417.5 | 20,602,417.5 | 0% | 0% | 0% | 0% | 0% | 0% | 0% | 0% | No | آرماتوربندی | نصب | روگذر | ضلع جنوب پل های شرقی | پیمانکار آرماتوربندی 1 | 0.40 | 0.56 |
| 103 | 7.1.1.1.2.4 | بتن ریزی شمع های بتنی A2-P43~67 (ضلع شمالی پل های شرقی) | 5d | 2026-01-06 A | 2026-01-10 | 102FS-3d | 60% | 2d | 300d | 0d | بتن ریزی [752 مترمکعب] | 16,544,000 | 9,926,400 | 0% | 0% | 0% | 0% | 0% | 0% | 0% | 0% | No | بتن ریزی | اجرا | روگذر | ضلع جنوب پل های شرقی | پیمانکار بتن ریزی 1 | 0.32 | 0.11 |
| 104 | 7.1.1.1.3 | **اجرای شمع های بتنی W5-P1~10 خارج از میدان (ضلع شمالی پل های شرقی)** | 21d | 2025-11-16 A | 2025-12-07 A |  | 100% |  |  |  |  | 3,820,340 | 3,820,340 | 0% | 0% | 0% | 0% | 0% | 0% | 0% | 0% | No |  |  |  |  |  |  |  |
| 105 | 7.1.1.1.3.1 | حفاری شمع های بتنی W5-P1~10 خارج از میدان (ضلع شمالی پل های شرقی) | 3d | 2025-12-03 A | 2025-12-05 A | 95 | 100% |  |  |  | حفر چاه دستی [74 مترطول] | 1,110,000 | 1,110,000 | 0% | 0% | 0% | 0% | 0% | 0% | 0% | 20% | No | حفر چاه دستی | اجرا | روگذر | ضلع جنوب پل های شرقی | پیمانکار حفاری دستی 1 | 0.02 | 0.07 |
| 106 | 7.1.1.1.3.2 | پیش ساخت آرماتور شمع های بتنی W5-P1~10 خارج از میدان (ضلع شمالی پل های شرقی) | 2d | 2025-11-16 A | 2025-11-17 A | 101 | 100% |  |  |  | آرماتوربندی شمع [4049 کیلوگرم]; Ø12 [610.21 کیلوگرم]; Ø20 [2563.86 کیلوگرم] | 1,184,332.5 | 1,184,332.5 | 0% | 100% | 100% | 100% | 100% | 100% | 100% | 0% | No | آرماتوربندی | پیش ساخت | روگذر | ضلع جنوب پل های شرقی | پیمانکار آرماتوربندی 1 | 0.02 | 0.04 |
| 107 | 7.1.1.1.3.3 | نصب آرماتور شمع های بتنی W5-P1~10 خارج از میدان (ضلع شمالی پل های شرقی) | 1d | 2025-12-06 A | 2025-12-06 A | 105, 106 | 100% |  |  |  | نصب آرماتوربندی شمع [4381 کیلوگرم] | 690,007.5 | 690,007.5 | 0% | 0% | 0% | 0% | 0% | 0% | 0% | 0% | No | آرماتوربندی | نصب | روگذر | ضلع جنوب پل های شرقی | پیمانکار آرماتوربندی 1 | 0.01 | 0.02 |
| 108 | 7.1.1.1.3.4 | بتن ریزی شمع های بتنی W5-P1~10 خارج از میدان (ضلع شمالی پل های شرقی) | 1d | 2025-12-07 A | 2025-12-07 A | 107 | 100% |  |  |  | بتن ریزی [38 مترمکعب] | 836,000 | 836,000 | 0% | 0% | 0% | 0% | 0% | 0% | 0% | 0% | No | بتن ریزی | اجرا | روگذر | ضلع جنوب پل های شرقی | پیمانکار بتن ریزی 1 | 0.02 | 0.02 |

| ID | WBS | Task | Duration | Start | Finish | Predecessors | Complete | Remaining | Total slack | Free slack | Resources | Cost | Actual cost | 1404.07.07 | 1404.07.14 | 1404.07.21 | 1404.07.28 | 1404.08.05 | 1404.08.12 | 1404.08.19 | 1404.08.26 | معارض | Activity Category | Activity Type | Task Category | Task Sub Category | نام پیمانکار | Text7 | Text8 |
| --- | --- | --- | --- | --- | --- | --- | --- | --- | --- | --- | --- | --- | --- | --- | --- | --- | --- | --- | --- | --- | --- | --- | --- | --- | --- | --- | --- | --- | --- |
| 109 | 7.1.1.1.4 | **اجرای شمع های بتنی W5-P11~26 داخل میدان موجود (ضلع شمالی پل های شرقی)** | 81d | 2025-09-30 A | 2025-12-20 A |  | 100% |  |  |  |  | 143,933,547.5 | 143,933,547.5 | 0% | 0% | 0% | 0% | 0% | 0% | 0% | 0% | No |  |  |  |  |  |  |  |
| 110 | 7.1.1.1.4.1 | روتبال و قطاعی داخل میدان موجود (ضلع شمالی پل های شرقی) | 4d | 2025-09-30 A | 2025-10-03 A | 74 | 100% |  |  |  | روتبال و قطاعی [500 اصله] | 8,250,000 | 8,250,000 | 100% | 100% | 100% | 100% | 100% | 100% | 100% | 100% | No | روتبال و قطاعی | اجرا | روگذر | ضلع جنوب پل های شرقی | پیمانکار روتبال 1 | 0.16 | 0.09 |
| 111 | 7.1.1.1.4.2 | اجرای خاک برداری تا تراز روی شمع های بتنی W5-P11~26 داخل میدان موجود (ضلع شمالی پل های شرقی) | 39d | 2025-10-04 A | 2025-11-11 A | 110 | 100% |  |  |  | خاکبرداری [75556 مترمکعب] | 113,334,000 | 113,334,000 | 100% | 100% | 100% | 100% | 100% | 100% | 100% | 100% | No | خاکبرداری | اجرا | روگذر | ضلع جنوب پل های شرقی | پیمانکار خاکبرداری و خاکریزی 1 | 2.18 | 0.87 |
| 112 | 7.1.1.1.4.3 | حفاری شمع های بتنی W5-P11~26 داخل میدان موجود (ضلع شمالی پل های شرقی) | 11d | 2025-12-06 A | 2025-12-16 A | 105, 111 | 100% |  |  |  | حفر چاه دستی [257 مترطول] | 3,855,000 | 3,855,000 | 57% | 50% | 50% | 50% | 50% | 70% | 100% | 100% | No | حفر چاه دستی | اجرا | روگذر | ضلع جنوب پل های شرقی | پیمانکار حفاری دستی 1 | 0.07 | 0.24 |
| 113 | 7.1.1.1.4.4 | پیش ساخت آرماتور شمع های بتنی W5-P11~26 داخل میدان موجود (ضلع شمالی پل های شرقی) | 10d | 2025-11-18 A | 2025-11-28 A | 106 | 100% |  |  |  | آرماتوربندی شمع [30632 کیلوگرم]; Ø12 [4496.56 کیلوگرم]; Ø20 [5773.91 کیلوگرم]; Ø25 [16262.4 کیلوگرم] | 8,959,860 | 8,959,860 | 28% | 27% | 30% | 33% | 38% | 70% | 100% | 100% | No | آرماتوربندی | پیش ساخت | روگذر | ضلع جنوب پل های شرقی | پیمانکار آرماتوربندی 1 | 0.17 | 0.22 |
| 114 | 7.1.1.1.4.5 | نصب آرماتور شمع های بتنی W5-P11~26 داخل میدان موجود (ضلع شمالی پل های شرقی) | 4d | 2025-12-15 A | 2025-12-18 A | 113FS-4d, 112FS-2d | 100% |  |  |  | نصب آرماتوربندی شمع [30925 کیلوگرم] | 4,870,687.5 | 4,870,687.5 | 28% | 24% | 24% | 24% | 24% | 70% | 70% | 70% | No | آرماتوربندی | نصب | روگذر | ضلع جنوب پل های شرقی | پیمانکار آرماتوربندی 1 | 0.09 | 0.09 |
| 115 | 7.1.1.1.4.6 | بتن ریزی شمع های بتنی W5-P11~26 داخل میدان موجود (ضلع شمالی پل های شرقی) | 2d | 2025-12-19 A | 2025-12-20 A | 114 | 100% |  |  |  | بتن ریزی [212 مترمکعب] | 4,664,000 | 4,664,000 | 28% | 20% | 20% | 20% | 20% | 70% | 70% | 70% | No | بتن ریزی | اجرا | روگذر | ضلع جنوب پل های شرقی | پیمانکار بتن ریزی 1 | 0.09 | 0.04 |
| 116 | 7.1.1.1.5 | **اجرای دیوارهای نمایی شمال شرقی محور A2 (پل های شرقی)** | 31d | 2026-01-11 | 2026-02-13 |  |  |  | 300d |  |  | 21,276,750 |  | 0% | 0% | 0% | 0% | 0% | 0% | 0% | 0% | No |  |  |  |  |  |  |  |
| 117 | 7.1.1.1.5.1 | بغل تراشی خاک (دیوارهای نمایی شمال شرقی محور A2) | 4d | 2026-01-11 | 2026-01-14 | 103, 156 |  |  | 300d | 0d | بغل تراشی خاک [535 مترمکعب] | 1,872,500 |  | 0% | 0% | 0% | 0% | 0% | 0% | 0% | 0% | No | بغل تراشی خاک | اجرا | روگذر | ضلع جنوب پل های شرقی | پیمانکار بغل تراشی 1 | 0.04 | 0.09 |
| 118 | 7.1.1.1.5.2 | اجرای لایه زهكش (دیوارهای نمایی شمال شرقی محور A2) | 3d | 2026-01-15 | 2026-01-18 | 117 |  |  | 300d | 0d | زهکش [520 مترمربع] | 3,510,000 |  | 0% | 0% | 0% | 0% | 0% | 0% | 0% | 0% | No | زهکش | اجرا | روگذر | ضلع جنوب پل های شرقی | پیمانکار اجرای زهکش 1 | 0.07 | 0.07 |
| 119 | 7.1.1.1.5.3 | آرماتوربندی دیوار (دیوارهای نمایی شمال شرقی محور A2) | 14d | 2026-01-19 | 2026-02-01 | 118 |  |  | 300d | 0d | آرماتوربندی دیواره [12005 کیلوگرم] | 5,402,250 |  | 0% | 0% | 0% | 0% | 0% | 0% | 0% | 0% | No | آرماتوربندی | اجرا | روگذر | ضلع جنوب پل های شرقی | پیمانکار آرماتوربندی 1 | 0.10 | 0.31 |
| 120 | 7.1.1.1.5.4 | قالب بندی دیوار نمایی (دیوارهای نمایی شمال شرقی محور A2) | 6d | 2026-02-02 | 2026-02-08 | 119 |  |  | 300d | 0d | قالب بندی [522 مترمربع] | 3,132,000 |  | 0% | 0% | 0% | 0% | 0% | 0% | 0% | 0% | No | قالب بندی | اجرا | روگذر | ضلع جنوب پل های شرقی | پیمانکار قالب بندی 1 | 0.06 | 0.13 |
| 121 | 7.1.1.1.5.5 | بتن ریزی دیوار (دیوارهای نمایی شمال شرقی محور A2) | 1d | 2026-02-09 | 2026-02-09 | 120 |  |  | 300d | 0d | بتن ریزی [106 مترمکعب] | 2,332,000 |  | 0% | 0% | 0% | 0% | 0% | 0% | 0% | 0% | No | بتن ریزی | اجرا | روگذر | ضلع جنوب پل های شرقی | پیمانکار بتن ریزی 1 | 0.04 | 0.02 |
| 122 | 7.1.1.1.5.6 | اجرای سرشمع ها و قرنیز (دیوارهای نمایی شمال شرقی محور A2) | 3d | 2026-02-10 | 2026-02-13 | 121 |  |  | 300d |  | سرشمع و قرنیز [80 مترطول] | 5,028,000 |  | 0% | 0% | 0% | 0% | 0% | 0% | 0% | 0% | No | سرشمع و قرنیز | اجرا | روگذر | ضلع جنوب پل های شرقی | پیمانکار ساخت و نصب و اجرای سرشمع و قرنیز 1 | 0.10 | 0.07 |
| 123 | 7.1.1.1.6 | **اجرای ستون های میانی محور P1-P34~42 (ضلع شمالی پل های شرقی)** | 70d | 2025-11-11 A | 2026-01-22 |  | 69% | 21.78d | 0d |  |  | 42,565,880 | 27,638,365 | 0% | 0% | 0% | 0% | 0% | 0% | 0% | 0% | No |  |  |  |  |  |  |  |
| 124 | 7.1.1.1.6.1 | حفاری تا تراز زیر گذر ستون های میانی محور P1-P34~42 (ضلع شمالی پل های شرقی) | 1d | 2025-11-11 A | 2025-11-11 A | 150 | 100% |  |  |  | خاکبرداری [315 مترمکعب] | 472,500 | 472,500 | 0% | 0% | 0% | 0% | 0% | 0% | 0% | 0% | No | خاکبرداری | اجرا | روگذر | ضلع جنوب پل های شرقی | پیمانکار خاکبرداری و خاکریزی 1 | 0.01 | 0.02 |
| 125 | 7.1.1.1.6.2 | حفاری شمع ها از تراز زیر گذر به پایین ستون های میانی محور P1-P34~42 (ضلع شمالی پل های شرقی) | 10d | 2025-12-26 A | 2026-01-05 A | 124, 164 | 100% |  |  |  | حفر چاه ماشینی [322 مترطول] | 8,050,000 | 8,050,000 | 0% | 0% | 0% | 0% | 0% | 0% | 0% | 0% | No | حفر چاه ماشینی | اجرا | روگذر | ضلع جنوب پل های شرقی | پیمانکار حفر ماشینی 1 | 0.15 | 0.22 |
| 126 | 7.1.1.1.6.3 | پیش ساخت آرماتور شمع ها ستون های میانی محور P1-P34~42 (ضلع شمالی پل های شرقی) | 16d | 2025-11-29 A | 2025-12-14 A | 113 | 100% |  |  |  | آرماتوربندی شمع [49914 کیلوگرم]; Ø12 [12275.7 کیلوگرم]; Ø20 [4214.79 کیلوگرم]; Ø25 [28523.9 کیلوگرم] | 14,599,845 | 14,599,845 | 0% | 0% | 0% | 0% | 0% | 0% | 0% | 0% | No | آرماتوربندی | پیش ساخت | روگذر | ضلع جنوب پل های شرقی | پیمانکار آرماتوربندی 1 | 0.28 | 0.36 |
| 127 | 7.1.1.1.6.4 | نصب آرماتور شمع ها ستون های میانی محور P1-P34~42 (ضلع شمالی پل های شرقی) | 7d | 2026-01-05 A | 2026-01-11 | 125FS-1d, 126FS-2d | 57% | 3d | 0d |  | نصب آرماتوربندی شمع [50178 کیلوگرم] | 7,903,035 | 4,516,020 | 0% | 0% | 0% | 0% | 0% | 0% | 0% | 0% | No | آرماتوربندی | نصب | روگذر | ضلع جنوب پل های شرقی | پیمانکار آرماتوربندی 1 | 0.15 | 0.16 |
| 128 | 7.1.1.1.6.5 | بتن ریزی شمع ها ستون های میانی محور P1-P34~42 (ضلع شمالی پل های شرقی) | 3d | 2026-01-11 | 2026-01-13 | 127FS-1d |  |  | 0d |  | بتن ریزی [364 مترمکعب] | 8,008,000 |  | 0% | 0% | 0% | 0% | 0% | 0% | 0% | 0% | No | بتن ریزی | اجرا | روگذر | ضلع جنوب پل های شرقی | پیمانکار بتن ریزی 1 | 0.15 | 0.07 |
| 129 | 7.1.1.1.6.6 | قالب بندی ستون (قسمت نما) ستون های میانی محور P1-P34~42 (ضلع شمالی پل های شرقی) | 6d | 2026-01-14 | 2026-01-20 | 128 |  |  | 0d |  | قالب بندی [243 مترمربع] | 1,458,000 |  | 0% | 0% | 0% | 0% | 0% | 0% | 0% | 0% | No | قالب بندی | اجرا | روگذر | ضلع جنوب پل های شرقی | پیمانکار قالب بندی 1 | 0.03 | 0.13 |
| 130 | 7.1.1.1.6.7 | بتن ریزی ستون های میانی محور P1-P34~42 (ضلع شمالی پل های شرقی) | 1d | 2026-01-21 | 2026-01-21 | 129 |  |  | 0d |  | بتن ریزی [72 مترمکعب] | 1,584,000 |  | 0% | 0% | 0% | 0% | 0% | 0% | 0% | 0% | No | بتن ریزی | اجرا | روگذر | ضلع جنوب پل های شرقی | پیمانکار بتن ریزی 1 | 0.03 | 0.02 |
| 131 | 7.1.1.1.6.8 | قالب برداری و پرکردن اطراف ستون ها تا تراز زیر عرشه ستون های میانی محور P1-P34~42 (ضلع شمالی پل های شرقی) | 1d | 2026-01-22 | 2026-01-22 | 130 |  |  | 0d |  | خاکریزی [327 مترمکعب] | 490,500 |  | 0% | 0% | 0% | 0% | 0% | 0% | 0% | 0% | No | خاکریزی | اجرا | روگذر | ضلع جنوب پل های شرقی | پیمانکار خاکبرداری و خاکریزی 1 | 0.01 | 0.02 |
| 132 | 7.1.1.2 | **اجرای شمع های بتنی (ضلع جنوبی پل های شرقی)** | 108d | 2025-09-26 A | 2026-01-13 |  | 97% | 3.26d | 328d |  |  | 347,990,975 | 333,841,775 | 0% | 0% | 0% | 0% | 0% | 0% | 0% | 0% | No |  |  |  |  |  |  |  |
| 133 | 7.1.1.2.1 | **اجرای شمع های بتنی W8-P1~51 (ضلع جنوبی پل های شرقی)** | 66d | 2025-09-26 A | 2025-12-01 A |  | 100% |  |  |  |  | 35,950,310 | 35,950,310 | 0% | 0% | 0% | 0% | 0% | 0% | 0% | 0% | No |  |  |  |  |  |  |  |
| 134 | 7.1.1.2.1.1 | حفاری شمع های بتنی W8-P1~51 (ضلع جنوبی پل های شرقی) | 21d | 2025-11-05 A | 2025-11-26 A | 31 | 100% |  |  |  | حفر چاه دستی [510 مترطول] | 7,650,000 | 7,650,000 | 0% | 0% | 0% | 0% | 0% | 0% | 0% | 0% | No | حفر چاه دستی | اجرا | روگذر | ضلع شمال پل های شرقی | پیمانکار حفاری دستی 2 | 0.15 | 0.49 |
| 135 | 7.1.1.2.1.2 | پیش ساخت آرماتور شمع های بتنی W8-P1~51 (ضلع جنوبی پل های شرقی) | 15d | 2025-09-26 A | 2025-10-10 A | 6FS-10d | 100% |  |  |  | آرماتوربندی شمع [46858 کیلوگرم]; Ø12 [7055.3 کیلوگرم]; Ø20 [15887.1 کیلوگرم]; Ø25 [17556 کیلوگرم] | 13,705,965 | 13,705,965 | 17% | 14% | 20% | 23% | 28% | 32% | 35% | 35% | No | آرماتوربندی | پیش ساخت | روگذر | ضلع شمال پل های شرقی | پیمانکار آرماتوربندی 2 | 0.26 | 0.33 |
| 136 | 7.1.1.2.1.3 | نصب آرماتور شمع های بتنی W8-P1~51 (ضلع جنوبی پل های شرقی) | 7d | 2025-11-22 A | 2025-11-29 A | 134FS-4d, 135 | 100% |  |  |  | نصب آرماتوربندی شمع [47126 کیلوگرم] | 7,422,345 | 7,422,345 | 0% | 0% | 0% | 0% | 0% | 0% | 0% | 0% | No | آرماتوربندی | نصب | روگذر | ضلع شمال پل های شرقی | پیمانکار آرماتوربندی 2 | 0.14 | 0.16 |
| 137 | 7.1.1.2.1.4 | بتن ریزی شمع های بتنی W8-P1~51 (ضلع جنوبی پل های شرقی) | 2d | 2025-11-30 A | 2025-12-01 A | 136 | 100% |  |  |  | بتن ریزی [326 مترمکعب] | 7,172,000 | 7,172,000 | 0% | 0% | 0% | 0% | 0% | 0% | 0% | 0% | No | بتن ریزی | اجرا | روگذر | ضلع شمال پل های شرقی | پیمانکار بتن ریزی 1 | 0.14 | 0.04 |

| ID | WBS | Task | Duration | Start | Finish | Predecessors | Complete | Remaining | Total slack | Free slack | Resources | Cost | Actual cost | Task Category | 1404.07.07 | 1404.07.14 | 1404.07.21 | 1404.07.28 | 1404.08.05 | 1404.08.12 | 1404.08.19 | 1404.08.26 | معارض | Activity Category | Activity Type | Task Sub Category | نام پیمانکار | Text7 | Text8 |
| --- | --- | --- | --- | --- | --- | --- | --- | --- | --- | --- | --- | --- | --- | --- | --- | --- | --- | --- | --- | --- | --- | --- | --- | --- | --- | --- | --- | --- | --- |
| 138 | 7.1.1.2.2 | **اجرای شمع های بتنی محور A1-P1~24 (ضلع جنوبی پل های شرقی)** | 62d | 2025-10-11 A | 2025-12-12 A |  | 100% |  |  |  |  | 74,158,655 | 74,158,655 | روگذر | 0% | 0% | 0% | 0% | 0% | 0% | 0% | 0% | No |  |  |  |  |  |  |
| 139 | 7.1.1.2.2.1 | حفاری شمع های بتنی A1-P1~24 (ضلع جنوبی پل های شرقی) | 20d | 2025-11-05 A | 2025-11-25 A | 527 | 100% |  |  |  | حفر چاه ماشینی [71 مترطول] | 1,775,000 | 1,775,000 | روگذر | 0% | 0% | 0% | 0% | 0% | 0% | 0% | 0% | No | حفر چاه ماشینی | اجرا | ضلع شمال پل های شرقی | پیمانکار حفر ماشینی 2 | 0.03 | 0.45 |
| 140 | 7.1.1.2.2.2 | پیش ساخت آرماتور شمع های بتنی A1-P1~24 (ضلع جنوبی پل های شرقی) | 38d | 2025-10-11 A | 2025-11-17 A | 135 | 100% |  |  |  | آرماتوربندی شمع [125452 کیلوگرم]; Ø12 [30049.9 کیلوگرم]; Ø20 [8536.32 کیلوگرم]; Ø25 [13305.6 کیلوگرم] | 36,694,710 | 36,694,710 | روگذر | 0% | 0% | 0% | 0% | 0% | 0% | 0% | 0% | No | آرماتوربندی | پیش ساخت | ضلع شمال پل های شرقی | پیمانکار آرماتوربندی 2 | 0.71 | 0.85 |
| 141 | 7.1.1.2.2.3 | نصب آرماتور شمع های بتنی A1-P1~24 (ضلع جنوبی پل های شرقی) | 15d | 2025-11-23 A | 2025-12-08 A | 140FS-5d, 139FS-2d | 100% |  |  |  | نصب آرماتوربندی شمع [125606 کیلوگرم] | 19,782,945 | 19,782,945 | روگذر | 0% | 0% | 0% | 0% | 0% | 0% | 0% | 0% | No | آرماتوربندی | نصب | ضلع شمال پل های شرقی | پیمانکار آرماتوربندی 2 | 0.38 | 0.33 |
| 142 | 7.1.1.2.2.4 | بتن ریزی شمع های بتنی A1-P1~24 (ضلع جنوبی پل های شرقی) | 5d | 2025-12-08 A | 2025-12-12 A | 141FS-1d | 100% |  |  |  | بتن ریزی [723 مترمکعب] | 15,906,000 | 15,906,000 | روگذر | 0% | 0% | 0% | 0% | 0% | 0% | 0% | 0% | No | بتن ریزی | اجرا | ضلع شمال پل های شرقی | پیمانکار بتن ریزی 1 | 0.31 | 0.11 |
| 143 | 7.1.1.2.3 | **اجرای شمع های بتنی W6-P1~23 خارج میدان (ضلع جنوبی پل های شرقی)** | 19d | 2025-11-18 A | 2025-12-07 A |  | 100% |  |  |  |  | 8,238,030 | 8,238,030 |  | 0% | 0% | 0% | 0% | 0% | 0% | 0% | 0% | No |  |  |  |  |  |  |
| 144 | 7.1.1.2.3.1 | حفاری شمع های بتنی W6-P1~23 خارج میدان (ضلع جنوبی پل های شرقی) | 8d | 2025-11-27 A | 2025-12-04 A | 134 | 100% |  |  |  | حفر چاه دستی [166 مترطول] | 2,490,000 | 2,490,000 | روگذر | 0% | 0% | 23% | 23% | 23% | 0% | 0% | 0% | No | حفر چاه دستی | اجرا | ضلع شمال پل های شرقی | پیمانکار حفاری دستی 2 | 0.05 | 0.18 |
| 145 | 7.1.1.2.3.2 | پیش ساخت آرماتور شمع های بتنی W6-P1~23 خارج میدان (ضلع جنوبی پل های شرقی) | 3d | 2025-11-18 A | 2025-11-20 A | 140 | 100% |  |  |  | آرماتوربندی شمع [8700 کیلوگرم]; Ø12 [1385.22 کیلوگرم]; Ø20 [5826.73 کیلوگرم] | 2,544,750 | 2,544,750 | روگذر | 0% | 24% | 30% | 33% | 38% | 0% | 10% | 10% | No | آرماتوربندی | پیش ساخت | ضلع شمال پل های شرقی | پیمانکار آرماتوربندی 2 | 0.05 | 0.07 |
| 146 | 7.1.1.2.3.3 | نصب آرماتور شمع های بتنی W6-P1~23 خارج میدان (ضلع جنوبی پل های شرقی) | 2d | 2025-12-05 A | 2025-12-06 A | 145, 144 | 100% |  |  |  | نصب آرماتوربندی شمع [9024 کیلوگرم] | 1,421,280 | 1,421,280 | روگذر | 0% | 0% | 23% | 23% | 23% | 0% | 0% | 0% | No | آرماتوربندی | نصب | ضلع شمال پل های شرقی | پیمانکار آرماتوربندی 2 | 0.03 | 0.04 |
| 147 | 7.1.1.2.3.4 | بتن ریزی شمع های بتنی W6-P1~23 خارج میدان (ضلع جنوبی پل های شرقی) | 1d | 2025-12-07 A | 2025-12-07 A | 146 | 100% |  |  |  | بتن ریزی [81 مترمکعب] | 1,782,000 | 1,782,000 | روگذر | 0% | 0% | 23% | 23% | 23% | 0% | 0% | 0% | No | بتن ریزی | اجرا | ضلع شمال پل های شرقی | پیمانکار بتن ریزی 1 | 0.03 | 0.02 |
| 148 | 7.1.1.2.4 | **اجرای شمع های بتنی W6-P24~56 داخل میدان موجود (ضلع جنوبی پل های شرقی)** | 89d | 2025-10-01 A | 2025-12-29 A |  | 100% |  |  |  |  | 155,593,950 | 155,593,950 |  | 0% | 0% | 0% | 0% | 0% | 0% | 0% | 0% | No |  |  |  |  |  |  |
| 149 | 7.1.1.2.4.1 | روتبال و قطاعی داخل میدان موجود (ضلع جنوبی پل های شرقی) | 4d | 2025-10-01 A | 2025-10-04 A | 40 | 100% |  |  |  | روتبال و قطاعی [500 اصله] | 8,250,000 | 8,250,000 | روگذر | 100% | 100% | 100% | 100% | 100% | 100% | 100% | 100% | No | روتبال و قطاعی | اجرا | ضلع شمال پل های شرقی | پیمانکار روتبال 2 | 0.16 | 0.09 |
| 150 | 7.1.1.2.4.2 | اجرای خاک برداری تا تراز روی شمع های بتنی W6-P24~56 داخل میدان موجود (ضلع جنوبی پل های شرقی) | 37d | 2025-10-05 A | 2025-11-10 A | 149 | 100% |  |  |  | خاکبرداری [72779 مترمکعب] | 109,168,500 | 109,168,500 | روگذر | 80% | 100% | 100% | 100% | 100% | 100% | 100% | 100% | No | خاکبرداری | اجرا | ضلع شمال پل های شرقی | پیمانکار خاکبرداری و خاکریزی 1 | 2.10 | 0.82 |
| 151 | 7.1.1.2.4.3 | حفاری شمع های بتنی W6-P24~56 داخل میدان موجود (ضلع جنوبی پل های شرقی) | 20d | 2025-12-05 A | 2025-12-24 A | 150, 144 | 100% |  |  |  | حفر چاه دستی [464 مترطول] | 6,960,000 | 6,960,000 | روگذر | 14% | 17% | 17% | 17% | 17% | 17% | 30% | 30% | No | حفر چاه دستی | اجرا | ضلع شمال پل های شرقی | پیمانکار حفاری دستی 2 | 0.13 | 0.45 |
| 152 | 7.1.1.2.4.4 | پیش ساخت آرماتور شمع های بتنی W6-P24~56 داخل میدان موجود (ضلع جنوبی پل های شرقی) | 15d | 2025-11-21 A | 2025-12-06 A | 145 | 100% |  |  |  | آرماتوربندی شمع [52410 کیلوگرم]; Ø12 [7666.5 کیلوگرم]; Ø20 [11773.8 کیلوگرم]; Ø25 [26056.8 کیلوگرم] | 15,329,925 | 15,329,925 | روگذر | 43% | 28% | 28% | 31% | 36% | 40% | 50% | 50% | No | آرماتوربندی | پیش ساخت | ضلع شمال پل های شرقی | پیمانکار آرماتوربندی 2 | 0.29 | 0.33 |
| 153 | 7.1.1.2.4.5 | نصب آرماتور شمع های بتنی W6-P24~56 داخل میدان موجود (ضلع جنوبی پل های شرقی) | 7d | 2025-12-21 A | 2025-12-27 A | 151FS-4d, 152 | 100% |  |  |  | نصب آرماتوربندی شمع [52670 کیلوگرم] | 8,295,525 | 8,295,525 | روگذر | 14% | 0% | 0% | 0% | 0% | 17% | 30% | 30% | No | آرماتوربندی | نصب | ضلع شمال پل های شرقی | پیمانکار آرماتوربندی 2 | 0.16 | 0.16 |
| 154 | 7.1.1.2.4.6 | بتن ریزی شمع های بتنی W6-P24~56 داخل میدان موجود (ضلع جنوبی پل های شرقی) | 3d | 2025-12-27 A | 2025-12-29 A | 153FS-1d | 100% |  |  |  | بتن ریزی [345 مترمکعب] | 7,590,000 | 7,590,000 | روگذر | 14% | 0% | 0% | 0% | 0% | 17% | 30% | 30% | No | بتن ریزی | اجرا | ضلع شمال پل های شرقی | پیمانکار بتن ریزی 1 | 0.15 | 0.07 |
| 155 | 7.1.1.2.5 | **اجرای دیوارهای نمایی جنوب شرقی محور A1 (پل های شرقی)** | 31d | 2025-12-13 A | 2026-01-13 |  | 84% | 5d | 328d |  |  | 31,424,150 | 19,835,450 |  | 0% | 0% | 0% | 0% | 0% | 0% | 0% | 0% | No |  |  |  |  |  |  |
| 156 | 7.1.1.2.5.1 | بغل تراشی خاک (دیوارهای نمایی جنوب شرقی محور A1) | 3d | 2025-12-13 A | 2025-12-15 A | 142 | 100% |  |  |  | بغل تراشی خاک [520 مترمکعب] | 1,820,000 | 1,820,000 | روگذر | 0% | 0% | 0% | 0% | 0% | 0% | 0% | 0% | No | بغل تراشی خاک | اجرا | ضلع شمال پل های شرقی | پیمانکار بغل تراشی 1 | 0.04 | 0.07 |
| 157 | 7.1.1.2.5.2 | اجرای لایه زهكش (دیوارهای نمایی جنوب شرقی محور A1) | 2d | 2025-12-16 A | 2025-12-17 A | 156 | 100% |  |  |  | زهکش [500 مترمربع] | 3,375,000 | 3,375,000 | روگذر | 0% | 0% | 0% | 0% | 0% | 0% | 0% | 0% | No | زهکش | اجرا | ضلع شمال پل های شرقی | پیمانکار اجرای زهکش 1 | 0.06 | 0.04 |
| 158 | 7.1.1.2.5.3 | آرماتوربندی دیوار (دیوارهای نمایی جنوب شرقی محور A1) | 6d | 2025-12-18 A | 2025-12-23 A | 157 | 100% |  |  |  | آرماتوربندی دیواره [11541 کیلوگرم] | 5,193,450 | 5,193,450 | روگذر | 0% | 0% | 0% | 0% | 0% | 0% | 0% | 0% | No | آرماتوربندی | اجرا | ضلع شمال پل های شرقی | پیمانکار آرماتوربندی 2 | 0.10 | 0.13 |
| 159 | 7.1.1.2.5.4 | قالب بندی دیوار نمایی (دیوارهای نمایی جنوب شرقی محور A1) | 13d | 2025-12-24 A | 2026-01-06 A | 158 | 100% |  |  |  | قالب بندی [502 مترمربع] | 3,012,000 | 3,012,000 | روگذر | 0% | 0% | 0% | 0% | 0% | 0% | 0% | 0% | No | قالب بندی | اجرا | ضلع شمال پل های شرقی | پیمانکار قالب بندی 1 | 0.06 | 0.29 |
| 160 | 7.1.1.2.5.5 | بتن ریزی دیوار (دیوارهای نمایی جنوب شرقی محور A1) | 4d | 2026-01-07 A | 2026-01-10 | 159 | 50% | 2d | 328d | 0d | بتن ریزی [585 مترمکعب] | 12,870,000 | 6,435,000 | روگذر | 0% | 0% | 0% | 0% | 0% | 0% | 0% | 0% | No | بتن ریزی | اجرا | ضلع شمال پل های شرقی | پیمانکار بتن ریزی 1 | 0.25 | 0.09 |
| 161 | 7.1.1.2.5.6 | اجرای سرشمع ها و قرنیز (دیوارهای نمایی جنوب شرقی محور A1) | 3d | 2026-01-11 | 2026-01-13 | 160 |  |  | 328d |  | سرشمع و قرنیز [82 مترطول] | 5,153,700 |  | روگذر | 0% | 0% | 0% | 0% | 0% | 0% | 0% | 0% | No | سرشمع و قرنیز | اجرا | ضلع شمال پل های شرقی | پیمانکار ساخت و نصب و اجرای سرشمع و قرنیز 1 | 0.10 | 0.07 |

| ID | WBS | Task | Duration | Start | Finish | Predecessors | Complete | Remaining | Total slack | Free slack | Resources | Cost | Actual cost | 1404.07.07 | 1404.07.14 | 1404.07.21 | 1404.07.28 | 1404.08.05 | 1404.08.12 | 1404.08.19 | 1404.08.26 | معارض | Activity Category | Activity Type | Task Category | Task Sub Category | نام پیمانکار | Text7 | Text8 |
| --- | --- | --- | --- | --- | --- | --- | --- | --- | --- | --- | --- | --- | --- | --- | --- | --- | --- | --- | --- | --- | --- | --- | --- | --- | --- | --- | --- | --- | --- |
| 162 | 7.1.1.2.6 | **اجرای ستون های میانی محور P2-25~33 (ضلع جنوبی پل های شرقی)** | 61d | 2025-11-11 A | 2026-01-12 |  | 91% | 5.55d | 9d |  |  | 42,625,880 | 40,065,380 | 0% | 0% | 0% | 0% | 0% | 0% | 0% | 0% | No |  |  |  |  |  |  |  |
| 163 | 7.1.1.2.6.1 | حفاری تا تراز زیر گذر ستون های میانی محور P2-25~33 (ضلع جنوبی پل های شرقی) | 1d | 2025-11-11 A | 2025-11-11 A | 150 | 100% |  |  |  | خاکبرداری [355 مترمکعب] | 532,500 | 532,500 | 0% | 0% | 0% | 0% | 0% | 0% | 0% | 0% | No | خاکبرداری | اجرا | روگذر | ضلع شمال پل های شرقی | پیمانکار خاکبرداری و خاکریزی 1 | 0.01 | 0.02 |
| 164 | 7.1.1.2.6.2 | حفاری شمع ها از تراز زیر گذر به پایین ستون های میانی محور P2-25~33 (ضلع جنوبی پل های شرقی) | 10d | 2025-12-16 A | 2025-12-25 A | 163, 100 | 100% |  |  |  | حفر چاه ماشینی [322 مترطول] | 8,050,000 | 8,050,000 | 0% | 0% | 0% | 0% | 0% | 0% | 0% | 0% | No | حفر چاه ماشینی | اجرا | روگذر | ضلع شمال پل های شرقی | پیمانکار حفر ماشینی 1 | 0.15 | 0.22 |
| 165 | 7.1.1.2.6.3 | پیش ساخت آرماتور شمع ها ستون های میانی محور P2-25~33 (ضلع جنوبی پل های شرقی) | 15d | 2025-12-07 A | 2025-12-21 A | 152 | 100% |  |  |  | آرماتوربندی شمع [49914 کیلوگرم]; Ø12 [12275.7 کیلوگرم]; Ø20 [4214.79 کیلوگرم]; Ø25 [28523.9 کیلوگرم] | 14,599,845 | 14,599,845 | 0% | 0% | 0% | 0% | 0% | 0% | 0% | 0% | No | آرماتوربندی | پیش ساخت | روگذر | ضلع شمال پل های شرقی | پیمانکار آرماتوربندی 2 | 0.28 | 0.33 |
| 166 | 7.1.1.2.6.4 | نصب آرماتور شمع ها ستون های میانی محور P2-25~33 (ضلع جنوبی پل های شرقی) | 7d | 2025-12-26 A | 2026-01-01 A | 165FS-4d, 164 | 100% |  |  |  | نصب آرماتوربندی شمع [50178 کیلوگرم] | 7,903,035 | 7,903,035 | 0% | 0% | 0% | 0% | 0% | 0% | 0% | 0% | No | آرماتوربندی | نصب | روگذر | ضلع شمال پل های شرقی | پیمانکار آرماتوربندی 2 | 0.15 | 0.16 |
| 167 | 7.1.1.2.6.5 | بتن ریزی شمع ها ستون های میانی محور P2-25~33 (ضلع جنوبی پل های شرقی) | 3d | 2026-01-01 A | 2026-01-04 A | 166FS-1d | 100% |  |  |  | بتن ریزی [364 مترمکعب] | 8,008,000 | 8,008,000 | 0% | 0% | 0% | 0% | 0% | 0% | 0% | 0% | No | بتن ریزی | اجرا | روگذر | ضلع شمال پل های شرقی | پیمانکار بتن ریزی 1 | 0.15 | 0.07 |
| 168 | 7.1.1.2.6.6 | قالب بندی ستون (قسمت نما) ستون های میانی محور P2-25~33 (ضلع جنوبی پل های شرقی) | 6d | 2026-01-05 A | 2026-01-10 | 167 | 67% | 2d | 9d | 0d | قالب بندی [243 مترمربع] | 1,458,000 | 972,000 | 0% | 0% | 0% | 0% | 0% | 0% | 0% | 0% | No | قالب بندی | اجرا | روگذر | ضلع شمال پل های شرقی | پیمانکار قالب بندی 1 | 0.03 | 0.13 |
| 169 | 7.1.1.2.6.7 | بتن ریزی ستون های میانی محور P2-25~33 (ضلع جنوبی پل های شرقی) | 1d | 2026-01-11 | 2026-01-11 | 168 |  |  | 9d | 0d | بتن ریزی [72 مترمکعب] | 1,584,000 |  | 0% | 0% | 0% | 0% | 0% | 0% | 0% | 0% | No | بتن ریزی | اجرا | روگذر | ضلع شمال پل های شرقی | پیمانکار بتن ریزی 1 | 0.03 | 0.02 |
| 170 | 7.1.1.2.6.8 | قالب برداری و پرکردن اطراف ستون ها تا تراز زیر عرشه ستون های میانی محور P2-25~33 (ضلع جنوبی پل های شرقی) | 1d | 2026-01-12 | 2026-01-12 | 169 |  |  | 9d |  | خاکریزی [327 مترمکعب] | 490,500 |  | 0% | 0% | 0% | 0% | 0% | 0% | 0% | 0% | No | خاکریزی | اجرا | روگذر | ضلع شمال پل های شرقی | پیمانکار خاکبرداری و خاکریزی 1 | 0.01 | 0.02 |
| 171 | 7.1.2 | **اجرای عرشه و پیش دال و مسیر رو گذر** | 69d | 2026-01-23 | 2026-04-11 |  |  |  | 0d |  |  | 279,138,900 |  | 0% | 0% | 0% | 0% | 0% | 0% | 0% | 0% | No |  |  |  |  |  |  |  |
| 172 | 7.1.2.1 | **پل شماره 1 (دور برگردان شرقی)** | 56d | 2026-01-23 | 2026-03-27 |  |  |  | 0d |  |  | 137,008,050 |  | 0% | 0% | 0% | 0% | 0% | 0% | 0% | 0% | No |  |  |  |  |  |  |  |
| 173 | 7.1.2.1.1 | **اجرای عرشه پل شماره 1 بصورت تاپ دان (دور برگردان شرقی)** | 44d | 2026-01-23 | 2026-03-09 |  |  |  | 0d |  |  | 113,293,050 |  | 0% | 0% | 0% | 0% | 0% | 0% | 0% | 0% | No |  |  |  |  |  |  |  |
| 174 | 7.1.2.1.1.1 | اجرای خاک برداری تا تراز زیر عرشه پل شماره 1 (دور برگردان شرقی) | 3d | 2026-01-23 | 2026-01-25 | 170, 131 |  |  | 0d |  | خاکبرداری [5628 مترمکعب] | 8,442,000 |  | 0% | 0% | 0% | 0% | 0% | 0% | 0% | 0% | No | خاکبرداری | اجرا | روگذر | پل شماره 1 دوربرگردان شرقی | پیمانکار خاکبرداری و خاکریزی 1 | 0.16 | 0.07 |
| 175 | 7.1.2.1.1.2 | اجرای قالب بندی عرشه پل شماره 1 (دور برگردان شرقی) | 10d | 2026-01-26 | 2026-02-05 | 174 |  |  | 250d | 0d | قالب بندی [1342 مترمربع] | 8,052,000 |  | 0% | 0% | 0% | 0% | 0% | 0% | 0% | 0% | No | قالب بندی | اجرا | روگذر | پل شماره 1 دوربرگردان شرقی | پیمانکار قالب بندی 1 | 0.15 | 0.22 |
| 176 | 7.1.2.1.1.3 | اجرای آرماتوربندی عرشه پل شماره 1 (دور برگردان شرقی) | 25d | 2026-02-03 | 2026-03-01 | 175FS-2d |  |  | 263d | 0d | آرماتوربندی [151299 کیلوگرم] | 68,084,550 |  | 0% | 0% | 0% | 0% | 0% | 0% | 0% | 0% | No | آرماتوربندی | اجرا | روگذر | پل شماره 1 دوربرگردان شرقی | پیمانکار آرماتوربندی 1 | 1.31 | 0.56 |
| 177 | 7.1.2.1.1.4 | بتن ریزی عرشه پل شماره 1 (دور برگردان شرقی) | 4d | 2026-03-01 | 2026-03-04 | 176FS-1d |  |  | 263d | 0d | بتن ریزی [666 مترمکعب] | 14,652,000 |  | 0% | 0% | 0% | 0% | 0% | 0% | 0% | 0% | No | بتن ریزی | اجرا | روگذر | پل شماره 1 دوربرگردان شرقی | پیمانکار بتن ریزی 1 | 0.28 | 0.09 |
| 178 | 7.1.2.1.1.5 | خاک برداری زیر عرشه تا تراز زیر گذر پل شماره 1 (دور برگردان شرقی) | 5d | 2026-03-05 | 2026-03-09 | 177 |  |  | 276d |  | خاکبرداری [9375 مترمکعب] | 14,062,500 |  | 0% | 0% | 0% | 0% | 0% | 0% | 0% | 0% | No | خاکبرداری | اجرا | روگذر | پل شماره 1 دوربرگردان شرقی | پیمانکار خاکبرداری و خاکریزی 1 | 0.27 | 0.11 |
| 179 | 7.1.2.1.2 | **اجرای پیش دال پل شماره 1** | 5d | 2026-03-05 | 2026-03-09 |  |  |  | 263d |  |  | 3,761,700 |  | 0% | 0% | 0% | 0% | 0% | 0% | 0% | 0% | No |  |  |  |  |  |  |  |
| 180 | 7.1.2.1.2.1 | اجرای قالب بندی لبه پیش دال پل شماره 1 (دور برگردان شرقی) | 2d | 2026-03-05 | 2026-03-06 | 177 |  |  | 263d | 0d | قالب بندی [46 مترمربع] | 276,000 |  | 0% | 0% | 0% | 0% | 0% | 0% | 0% | 0% | No | قالب بندی | اجرا | روگذر | پل شماره 1 دوربرگردان شرقی | پیمانکار قالب بندی 1 | 0.01 | 0.04 |
| 181 | 7.1.2.1.2.2 | اجرای آرماتوربندی پیش دال پل شماره 1 (دور برگردان شرقی) | 2d | 2026-03-07 | 2026-03-08 | 180 |  |  | 263d | 0d | آرماتوربندی [5546 کیلوگرم] | 2,495,700 |  | 0% | 0% | 0% | 0% | 0% | 0% | 0% | 0% | No | آرماتوربندی | اجرا | روگذر | پل شماره 1 دوربرگردان شرقی | پیمانکار آرماتوربندی 1 | 0.05 | 0.04 |
| 182 | 7.1.2.1.2.3 | بتن ریزی پیش دال پل شماره 1 (دور برگردان شرقی) | 1d | 2026-03-09 | 2026-03-09 | 181 |  |  | 263d | 0d | بتن ریزی [45 مترمکعب] | 990,000 |  | 0% | 0% | 0% | 0% | 0% | 0% | 0% | 0% | No | بتن ریزی | اجرا | روگذر | پل شماره 1 دوربرگردان شرقی | پیمانکار بتن ریزی 1 | 0.02 | 0.02 |
| 183 | 7.1.2.1.3 | **احداث مسیر پل شماره 1** | 11d | 2026-03-10 | 2026-03-26 |  |  |  | 263d |  |  | 8,041,400 |  | 0% | 0% | 0% | 0% | 0% | 0% | 0% | 0% | No |  |  |  |  |  |  |  |
| 184 | 7.1.2.1.3.1 | عملیات خاکی و اجرای رگلاژ و بستر سازی پل شماره 1 (دور برگردان شرقی) | 1d | 2026-03-10 | 2026-03-10 | 182 |  |  | 263d | 0d | رگلاژ و بسترسازی [1278 مترمربع] | 639,000 |  | 0% | 0% | 0% | 0% | 0% | 0% | 0% | 0% | No | رگلاژ و بسترسازی | اجرا | روگذر | پل شماره 1 دوربرگردان شرقی | پیمانکار رگلاژ و بسترسازی 1 | 0.01 | 0.02 |
| 185 | 7.1.2.1.3.2 | اجرای زیر اساس پل شماره 1 (دور برگردان شرقی) | 1d | 2026-03-12 | 2026-03-12 | 184 |  |  | 263d | 0d | زیراساس [743 مترمربع] | 445,800 |  | 0% | 0% | 0% | 0% | 0% | 0% | 0% | 0% | No | زیراساس | اجرا | روگذر | پل شماره 1 دوربرگردان شرقی | پیمانکار آسفالت 1 | 0.01 | 0.02 |
| 186 | 7.1.2.1.3.3 | اجرای جدول گذاری و احداث کانال بتنی پل شماره 1 (دور برگردان شرقی) | 7d | 2026-03-13 | 2026-03-19 | 185 |  |  | 263d | 0d | جدول و کانال بتنی [181 مترطول] | 2,262,500 |  | 0% | 0% | 0% | 0% | 0% | 0% | 0% | 0% | No | جدول گذاری و کانال بتنی | اجرا | روگذر | پل شماره 1 دوربرگردان شرقی | پیمانکار اجرای جدول و کانال بتنی 1 | 0.04 | 0.16 |
| 187 | 7.1.2.1.3.4 | اجرای اساس پل شماره 1 (دور برگردان شرقی) | 1d | 2026-03-25 | 2026-03-25 | 186 |  |  | 263d | 0d | اساس [679 مترمربع] | 611,100 |  | 0% | 0% | 0% | 0% | 0% | 0% | 0% | 0% | No | اساس | اجرا | روگذر | پل شماره 1 دوربرگردان شرقی | پیمانکار آسفالت 1 | 0.01 | 0.02 |
| 188 | 7.1.2.1.3.5 | اجرای عایق و آسفالت پل شماره 1 (دور برگردان شرقی) | 1d | 2026-03-26 | 2026-03-26 | 187 |  |  | 263d | 0d | آسفالت [1361 مترمربع] | 4,083,000 |  | 0% | 0% | 0% | 0% | 0% | 0% | 0% | 0% | No | آسفالت | اجرا | روگذر | پل شماره 1 دوربرگردان شرقی | پیمانکار آسفالت 1 | 0.08 | 0.02 |

| ID | WBS | Task | Duration | Start | Finish | Predecessors | Total slack | Free slack | Resources | Cost | 1404.07.07 | 1404.07.14 | 1404.07.21 | 1404.07.28 | 1404.08.05 | 1404.08.12 | 1404.08.19 | 1404.08.26 | معارض | Activity Category | Activity Type | Task Category | Task Sub Category | نام پیمانکار | Text7 | Text8 |
| --- | --- | --- | --- | --- | --- | --- | --- | --- | --- | --- | --- | --- | --- | --- | --- | --- | --- | --- | --- | --- | --- | --- | --- | --- | --- | --- |
| 189 | 7.1.2.1.4 | **تکمیل مسیر رو گذر پل شماره 1** | 53d | 2026-01-26 | 2026-03-27 |  | 0d |  |  | 11,911,900 | 0% | 0% | 0% | 0% | 0% | 0% | 0% | 0% | No |  |  |  |  |  |  |  |
| 190 | 7.1.2.1.4.1 | ساخت قرنیز پیش ساخته پل شماره 1 (دور برگردان شرقی) | 8d | 2026-01-26 | 2026-02-02 | 174 | 0d |  | ساخت قرنیز [216 مترطول] | 194,400 | 0% | 0% | 0% | 0% | 0% | 0% | 0% | 0% | No | سرشمع و قرنیز | ساخت | روگذر | پل شماره 1 دوربرگردان شرقی | پیمانکار ساخت و نصب و اجرای سرشمع و قرنیز 1 | 0.00 | 0.18 |
| 191 | 7.1.2.1.4.2 | نصب قرنیز پیش ساخته پل شماره 1 (دور برگردان شرقی) | 3d | 2026-03-05 | 2026-03-07 | 190, 177 | 264d | 0d | سرشمع و قرنیز [90 مترطول] | 5,656,500 | 0% | 0% | 0% | 0% | 0% | 0% | 0% | 0% | No | سرشمع و قرنیز | نصب | روگذر | پل شماره 1 دوربرگردان شرقی | پیمانکار ساخت و نصب و اجرای سرشمع و قرنیز 1 | 0.11 | 0.07 |
| 192 | 7.1.2.1.4.3 | تکمیل آرماتوربندی و بتن ریزی پیاده رو پل شماره 1 (دور برگردان شرقی) | 5d | 2026-03-08 | 2026-03-13 | 191 | 264d | 0d | پیاده رو [146 مترمربع] | 803,000 | 0% | 0% | 0% | 0% | 0% | 0% | 0% | 0% | No | پیاده رو | اجرا | روگذر | پل شماره 1 دوربرگردان شرقی | پیمانکار پیاده روسازی 1 | 0.02 | 0.11 |
| 193 | 7.1.2.1.4.4 | نصب جدول و عملیات تکمیلی پیاده رو پل شماره 1 (دور برگردان شرقی) | 6d | 2026-03-14 | 2026-03-19 | 192 | 264d | 0d | جدول و کانال بتنی [175 مترطول] | 2,187,500 | 0% | 0% | 0% | 0% | 0% | 0% | 0% | 0% | No | جدول گذاری و کانال بتنی | اجرا | روگذر | پل شماره 1 دوربرگردان شرقی | پیمانکار اجرای جدول و کانال بتنی 1 | 0.04 | 0.13 |
| 194 | 7.1.2.1.4.5 | ساخت گارد ریل پل شماره 1 (دور برگردان شرقی) | 5d | 2026-01-26 | 2026-01-30 | 174 | 179d | 0d | ساخت گاردریل [176 مترطول مسیر] | 1,848,000 | 0% | 0% | 0% | 0% | 0% | 0% | 0% | 0% | No | گاردریل | ساخت | روگذر | پل شماره 1 دوربرگردان شرقی | پیمانکار ساخت و نصب گاردریل 1 | 0.04 | 0.11 |
| 195 | 7.1.2.1.4.6 | نصب گارد ریل پل شماره 1 (دور برگردان شرقی) | 3d | 2026-03-18 | 2026-03-25 | 192, 193FS-2d, 194 | 264d | 1d | نصب گاردریل [191 مترطول مسیر] | 859,500 | 0% | 0% | 0% | 0% | 0% | 0% | 0% | 0% | No | گاردریل | نصب | روگذر | پل شماره 1 دوربرگردان شرقی | پیمانکار ساخت و نصب گاردریل 1 | 0.02 | 0.07 |
| 196 | 7.1.2.1.4.7 | اجرای خط کشی مسیر و نصب علایم پل شماره 1 (دور برگردان شرقی) | 1d | 2026-03-27 | 2026-03-27 | 188, 195 | 263d |  | رنگ آمیزی مسیر [121 مترطول مسیر] | 363,000 | 0% | 0% | 0% | 0% | 0% | 0% | 0% | 0% | No | رنگ آمیزی مسیر | اجرا | روگذر | پل شماره 1 دوربرگردان شرقی | پیمانکار نصب علائم و رنگ آمیزی 1 | 0.01 | 0.02 |
| 197 | 7.1.2.2 | **پل شماره 2 (دور میدان شرقی)** | 66d | 2026-01-26 | 2026-04-11 |  | 184d |  |  | 142,130,850 | 0% | 0% | 0% | 0% | 0% | 0% | 0% | 0% | No |  |  |  |  |  |  |  |
| 198 | 7.1.2.2.1 | **اجرای عرشه پل شماره 2 بصورت تاپ دان (دور میدان شرقی)** | 51d | 2026-01-26 | 2026-03-25 |  | 257d |  |  | 115,923,200 | 0% | 0% | 0% | 0% | 0% | 0% | 0% | 0% | No |  |  |  |  |  |  |  |
| 199 | 7.1.2.2.1.1 | اجرای خاک برداری تا تراز زیر عرشه پل شماره 2 (دور میدان شرقی) | 3d | 2026-01-26 | 2026-01-28 | 131, 170, 174 | 257d | 7d | خاکبرداری [5628 مترمکعب] | 8,442,000 | 0% | 0% | 0% | 0% | 0% | 0% | 0% | 0% | No | خاکبرداری | اجرا | روگذر | پل شماره 2 دور میدان شرقی | پیمانکار خاکبرداری و خاکریزی 2 | 0.16 | 0.07 |
| 200 | 7.1.2.2.1.2 | اجرای قالب بندی عرشه پل شماره 2 (دور میدان شرقی) | 10d | 2026-02-06 | 2026-02-16 | 175, 199 | 250d | 0d | قالب بندی [1231 مترمربع] | 7,386,000 | 0% | 0% | 0% | 0% | 0% | 0% | 0% | 0% | No | قالب بندی | اجرا | روگذر | پل شماره 2 دور میدان شرقی | پیمانکار قالب بندی 1 | 0.14 | 0.22 |
| 201 | 7.1.2.2.1.3 | اجرای آرماتوربندی عرشه پل شماره 2 (دور میدان شرقی) | 25d | 2026-02-15 | 2026-03-12 | 200FS-2d | 250d | 0d | آرماتوربندی [163886 کیلوگرم] | 73,748,700 | 0% | 0% | 0% | 0% | 0% | 0% | 0% | 0% | No | آرماتوربندی | اجرا | روگذر | پل شماره 2 دور میدان شرقی | پیمانکار آرماتوربندی 2 | 1.42 | 0.56 |
| 202 | 7.1.2.2.1.4 | بتن ریزی عرشه پل شماره 2 (دور میدان شرقی) | 4d | 2026-03-12 | 2026-03-15 | 201FS-1d | 250d | 0d | بتن ریزی [611 مترمکعب] | 13,442,000 | 0% | 0% | 0% | 0% | 0% | 0% | 0% | 0% | No | بتن ریزی | اجرا | روگذر | پل شماره 2 دور میدان شرقی | پیمانکار بتن ریزی 1 | 0.26 | 0.09 |
| 203 | 7.1.2.2.1.5 | خاک برداری زیر عرشه تا تراز زیر گذر پل شماره 2 (دور میدان شرقی) | 5d | 2026-03-16 | 2026-03-25 | 202 | 266d |  | خاکبرداری [8603 مترمکعب] | 12,904,500 | 0% | 0% | 0% | 0% | 0% | 0% | 0% | 0% | No | خاکبرداری | اجرا | روگذر | پل شماره 2 دور میدان شرقی | پیمانکار خاکبرداری و خاکریزی 2 | 0.25 | 0.11 |
| 204 | 7.1.2.2.2 | **اجرای پیش دال پل شماره 2** | 5d | 2026-03-16 | 2026-03-25 |  | 253d |  |  | 3,761,700 | 0% | 0% | 0% | 0% | 0% | 0% | 0% | 0% | No |  |  |  |  |  |  |  |
| 205 | 7.1.2.2.2.1 | اجرای قالب بندی لبه پیش دال پل شماره 2 (دور میدان شرقی) | 2d | 2026-03-16 | 2026-03-17 | 202 | 253d | 0d | قالب بندی [46 مترمربع] | 276,000 | 0% | 0% | 0% | 0% | 0% | 0% | 0% | 0% | No | قالب بندی | اجرا | روگذر | پل شماره 2 دور میدان شرقی | پیمانکار قالب بندی 1 | 0.01 | 0.04 |
| 206 | 7.1.2.2.2.2 | اجرای آرماتوربندی پیش دال پل شماره 2 (دور میدان شرقی) | 2d | 2026-03-18 | 2026-03-19 | 205 | 253d | 0d | آرماتوربندی [5546 کیلوگرم] | 2,495,700 | 0% | 0% | 0% | 0% | 0% | 0% | 0% | 0% | No | آرماتوربندی | اجرا | روگذر | پل شماره 2 دور میدان شرقی | پیمانکار آرماتوربندی 2 | 0.05 | 0.04 |
| 207 | 7.1.2.2.2.3 | بتن ریزی پیش دال پل شماره 2 (دور میدان شرقی) | 1d | 2026-03-25 | 2026-03-25 | 206 | 253d | 0d | بتن ریزی [45 مترمکعب] | 990,000 | 0% | 0% | 0% | 0% | 0% | 0% | 0% | 0% | No | بتن ریزی | اجرا | روگذر | پل شماره 2 دور میدان شرقی | پیمانکار بتن ریزی 1 | 0.02 | 0.02 |
| 208 | 7.1.2.2.3 | **احداث مسیر پل شماره 2** | 11d | 2026-03-26 | 2026-04-07 |  | 253d |  |  | 7,546,400 | 0% | 0% | 0% | 0% | 0% | 0% | 0% | 0% | No |  |  |  |  |  |  |  |
| 209 | 7.1.2.2.3.1 | عملیات خاکی و اجرای رگلاژ و بستر سازی پل شماره 2 (دور میدان شرقی) | 1d | 2026-03-26 | 2026-03-26 | 207 | 253d | 0d | رگلاژ و بسترسازی [1278 مترمربع] | 639,000 | 0% | 0% | 0% | 0% | 0% | 0% | 0% | 0% | No | رگلاژ و بسترسازی | اجرا | روگذر | پل شماره 2 دور میدان شرقی | پیمانکار رگلاژ و بسترسازی 1 | 0.01 | 0.02 |
| 210 | 7.1.2.2.3.2 | اجرای زیر اساس پل شماره 2 (دور میدان شرقی) | 1d | 2026-03-27 | 2026-03-27 | 209 | 253d | 0d | زیراساس [633 مترمربع] | 379,800 | 0% | 0% | 0% | 0% | 0% | 0% | 0% | 0% | No | زیراساس | اجرا | روگذر | پل شماره 2 دور میدان شرقی | پیمانکار آسفالت 2 | 0.01 | 0.02 |
| 211 | 7.1.2.2.3.3 | اجرای جدول گذاری و احداث کانال بتنی پل شماره 2 (دور میدان شرقی) | 7d | 2026-03-28 | 2026-04-05 | 210 | 253d | 0d | جدول و کانال بتنی [181 مترطول] | 2,262,500 | 0% | 0% | 0% | 0% | 0% | 0% | 0% | 0% | No | جدول گذاری و کانال بتنی | اجرا | روگذر | پل شماره 2 دور میدان شرقی | پیمانکار اجرای جدول و کانال بتنی 2 | 0.04 | 0.16 |
| 212 | 7.1.2.2.3.4 | اجرای اساس پل شماره 2 (دور میدان شرقی) | 1d | 2026-04-06 | 2026-04-06 | 211 | 253d | 0d | اساس [569 مترمربع] | 512,100 | 0% | 0% | 0% | 0% | 0% | 0% | 0% | 0% | No | اساس | اجرا | روگذر | پل شماره 2 دور میدان شرقی | پیمانکار آسفالت 2 | 0.01 | 0.02 |
| 213 | 7.1.2.2.3.5 | اجرای عایق و آسفالت پل شماره 2 (دور میدان شرقی) | 1d | 2026-04-07 | 2026-04-07 | 212 | 253d | 3d | آسفالت [1251 مترمربع] | 3,753,000 | 0% | 0% | 0% | 0% | 0% | 0% | 0% | 0% | No | آسفالت | اجرا | روگذر | پل شماره 2 دور میدان شرقی | پیمانکار آسفالت 2 | 0.07 | 0.02 |

| ID | WBS | Task | Duration | Start | Finish | Predecessors | Complete | Remaining | Total slack | Free slack | Resources | Cost | Actual cost | 1404.07.07 | 1404.07.14 | 1404.07.21 | 1404.07.28 | 1404.08.05 | 1404.08.12 | 1404.08.19 | 1404.08.26 | معارض | Activity Category | Activity Type | Task Category | Task Sub Category | نام پیمانکار | Text7 | Text8 |
| --- | --- | --- | --- | --- | --- | --- | --- | --- | --- | --- | --- | --- | --- | --- | --- | --- | --- | --- | --- | --- | --- | --- | --- | --- | --- | --- | --- | --- | --- |
| 214 | 7.1.2.2.4 | **تکمیل مسیر رو گذر پل شماره 2** | 61d | 2026-01-31 | 2026-04-11 |  |  |  | 179d |  |  | 14,899,550 |  | 0% | 0% | 0% | 0% | 0% | 0% | 0% | 0% | No |  |  |  |  |  |  |  |
| 215 | 7.1.2.2.4.1 | ساخت قرنیز پیش ساخته پل شماره 2 (دور میدان شرقی) | 14d | 2026-02-03 | 2026-02-18 | 190 |  |  | 248d | 0d | ساخت قرنیز [294 مترطول] | 264,600 |  | 0% | 0% | 0% | 0% | 0% | 0% | 0% | 0% | No | سرشمع و قرنیز | ساخت | روگذر | پل شماره 2 دور میدان شرقی | پیمانکار ساخت و نصب و اجرای سرشمع و قرنیز 1 | 0.01 | 0.33 |
| 216 | 7.1.2.2.4.2 | نصب قرنیز پیش ساخته پل شماره 2 (دور میدان شرقی) | 7d | 2026-03-16 | 2026-03-27 | 215, 202 |  |  | 250d | 0d | سرشمع و قرنیز [167 مترطول] | 10,495,950 |  | 0% | 0% | 0% | 0% | 0% | 0% | 0% | 0% | No | سرشمع و قرنیز | نصب | روگذر | پل شماره 2 دور میدان شرقی | پیمانکار ساخت و نصب و اجرای سرشمع و قرنیز 1 | 0.20 | 0.16 |
| 217 | 7.1.2.2.4.3 | تکمیل آرماتوربندی و بتن ریزی پیاده رو پل شماره 2 (دور میدان شرقی) | 6d | 2026-03-28 | 2026-04-04 | 216 |  |  | 250d | 0d | پیاده رو [198 مترمربع] | 1,089,000 |  | 0% | 0% | 0% | 0% | 0% | 0% | 0% | 0% | No | پیاده رو | اجرا | روگذر | پل شماره 2 دور میدان شرقی | پیمانکار آرماتوربندی 2 | 0.02 | 0.13 |
| 218 | 7.1.2.2.4.4 | نصب جدول و عملیات تکمیلی پیاده رو پل شماره 2 (دور میدان شرقی) | 4d | 2026-04-05 | 2026-04-08 | 217 |  |  | 250d | 0d | پیاده رو [131 مترمربع] | 720,500 |  | 0% | 0% | 0% | 0% | 0% | 0% | 0% | 0% | No | جدول گذاری و کانال بتنی | اجرا | روگذر | پل شماره 2 دور میدان شرقی | پیمانکار اجرای جدول و کانال بتنی 2 | 0.01 | 0.09 |
| 219 | 7.1.2.2.4.5 | ساخت گارد ریل پل شماره 2 (دور میدان شرقی) | 4d | 2026-01-31 | 2026-02-03 | 194 |  |  | 179d | 0d | ساخت گاردریل [121 مترطول مسیر] | 1,270,500 |  | 0% | 0% | 0% | 0% | 0% | 0% | 0% | 0% | No | گاردریل | ساخت | روگذر | پل شماره 2 دور میدان شرقی | پیمانکار ساخت و نصب گاردریل 1 | 0.02 | 0.09 |
| 220 | 7.1.2.2.4.6 | نصب گارد ریل پل شماره 2 (دور میدان شرقی) | 2d | 2026-04-09 | 2026-04-10 | 217, 218, 219 |  |  | 250d | 0d | نصب گاردریل [136 مترطول مسیر] | 612,000 |  | 0% | 0% | 0% | 0% | 0% | 0% | 0% | 0% | No | گاردریل | نصب | روگذر | پل شماره 2 دور میدان شرقی | پیمانکار ساخت و نصب گاردریل 1 | 0.01 | 0.04 |
| 221 | 7.1.2.2.4.7 | اجرای خط کشی مسیر و نصب علایم پل شماره 2 (دور میدان شرقی) | 1d | 2026-04-11 | 2026-04-11 | 213, 220 |  |  | 250d |  | رنگ آمیزی مسیر [149 مترطول مسیر] | 447,000 |  | 0% | 0% | 0% | 0% | 0% | 0% | 0% | 0% | No | رنگ آمیزی مسیر | اجرا | روگذر | پل شماره 2 دور میدان شرقی | پیمانکار نصب علائم و رنگ آمیزی 1 | 0.01 | 0.02 |
| 222 | 7.2 | **احداث پل های غربی** | 311d | 2025-10-04 A | 2026-08-25 |  | 16% | 262.51d | 117d |  |  | 1,523,564,930 | 225,090,928.74 | 0% | 0% | 0% | 0% | 0% | 0% | 0% | 0% | No |  |  |  |  |  |  |  |
| 223 | 7.2.1 | **اجرای شمع های بتنی (پل های غربی)** | 269d | 2025-10-04 A | 2026-07-14 |  | 22% | 209.36d | 159d |  |  | 923,797,790 | 225,090,928.74 | 0% | 0% | 0% | 0% | 0% | 0% | 0% | 0% | No |  |  |  |  |  |  |  |
| 224 | 7.2.1.1 | **اجرای شمع های بتنی (ضلع شمالی پل های غربی)** | 267d | 2025-10-04 A | 2026-07-12 |  | 28% | 191.22d | 161d |  |  | 371,573,762.5 | 120,220,828 | 0% | 0% | 0% | 0% | 0% | 0% | 0% | 0% | No |  |  |  |  |  |  |  |
| 225 | 7.2.1.1.1 | **اجرای شمع های بتنی W3-P1~25 خارج از میدان (ضلع شمالی پل های غربی)** | 11d | 2025-12-15 A | 2025-12-25 A |  | 100% |  |  |  |  | 13,432,062.5 | 13,432,062.5 | 0% | 0% | 0% | 0% | 0% | 0% | 0% | 0% | No |  |  |  |  |  |  |  |
| 226 | 7.2.1.1.1.1 | حفاری شمع های بتنی W3-P1~25 خارج از میدان (ضلع شمالی پل های غربی) | 8d | 2025-12-17 A | 2025-12-24 A | 112 | 100% |  |  |  | حفر چاه دستی [201 مترطول] | 3,015,000 | 3,015,000 | 0% | 0% | 0% | 0% | 0% | 0% | 0% | 0% | No | حفر چاه دستی | اجرا | روگذر | ضلع جنوب پل های غربی | پیمانکار حفاری دستی 3 | 0.06 | 0.18 |
| 227 | 7.2.1.1.1.2 | پیش ساخت آرماتور شمع های بتنی W3-P1~25 خارج از میدان (ضلع شمالی پل های غربی) | 4d | 2025-12-15 A | 2025-12-18 A | 126 | 100% |  |  |  | آرماتوربندی شمع [15021 کیلوگرم]; Ø12 [5845.4 کیلوگرم]; Ø20 [8753.97 کیلوگرم]; Ø25 [19588.8 کیلوگرم] | 4,393,642.5 | 4,393,642.5 | 0% | 28% | 28% | 31% | 36% | 40% | 43% | 43% | No | آرماتوربندی | پیش ساخت | روگذر | ضلع جنوب پل های غربی | پیمانکار آرماتوربندی 3 | 0.08 | 0.09 |
| 228 | 7.2.1.1.1.3 | نصب آرماتور شمع های بتنی W3-P1~25 خارج از میدان (ضلع شمالی پل های غربی) | 2d | 2025-12-23 A | 2025-12-24 A | 227FS-3d, 226FS-2d | 100% |  |  |  | نصب آرماتوربندی شمع [15336 کیلوگرم] | 2,415,420 | 2,415,420 | 0% | 0% | 0% | 0% | 0% | 0% | 0% | 0% | No | آرماتوربندی | نصب | روگذر | ضلع جنوب پل های غربی | پیمانکار آرماتوربندی 3 | 0.05 | 0.04 |
| 229 | 7.2.1.1.1.4 | بتن ریزی شمع های بتنی W3-P1~25 خارج از میدان (ضلع شمالی پل های غربی) | 1d | 2025-12-25 A | 2025-12-25 A | 228 | 100% |  |  |  | بتن ریزی [164 مترمکعب] | 3,608,000 | 3,608,000 | 0% | 0% | 0% | 0% | 0% | 0% | 0% | 0% | No | بتن ریزی | اجرا | روگذر | ضلع جنوب پل های غربی | پیمانکار بتن ریزی 1 | 0.07 | 0.02 |
| 230 | 7.2.1.1.2 | **اجرای شمع های بتنی W3-P26~31 داخل میدان موجود (ضلع شمالی پل های غربی)** | 86d | 2025-10-04 A | 2025-12-29 A |  | 100% |  |  |  |  | 77,998,082.5 | 77,998,082.5 | 0% | 0% | 0% | 0% | 0% | 0% | 0% | 0% | No |  |  |  |  |  |  |  |
| 231 | 7.2.1.1.2.1 | روتبال و قطاعی داخل میدان موجود (ضلع شمالی پل های غربی) | 18d | 2025-10-04 A | 2025-10-21 A | 110 | 100% |  |  |  | روتبال و قطاعی [500 اصله] | 8,250,000 | 8,250,000 | 35% | 30% | 30% | 35% | 45% | 70% | 85% | 100% | No | روتبال و قطاعی | اجرا | روگذر | ضلع جنوب پل های غربی | پیمانکار روتبال 1 | 0.16 | 0.42 |
| 232 | 7.2.1.1.2.2 | اجرای خاک برداری تا تراز روی شمع های بتنی W3-P26~31 داخل میدان موجود (ضلع شمالی پل های غربی) | 16d | 2025-10-22 A | 2025-11-06 A | 231 | 100% |  |  |  | خاکبرداری [37730 مترمکعب] | 56,595,000 | 56,595,000 | 90% | 93% | 93% | 98% | 98% | 98% | 100% | 100% | No | خاکبرداری | اجرا | روگذر | ضلع جنوب پل های غربی | پیمانکار خاکبرداری و خاکریزی 2 | 1.09 | 0.36 |
| 233 | 7.2.1.1.2.3 | حفاری شمع های بتنی W3-P26~31 داخل میدان موجود (ضلع شمالی پل های غربی) | 3d | 2025-12-25 A | 2025-12-27 A | 232, 226 | 100% |  |  |  | حفر چاه دستی [136 مترطول] | 2,040,000 | 2,040,000 | 0% | 0% | 0% | 0% | 65% | 50% | 50% | 50% | No | حفر چاه دستی | اجرا | روگذر | ضلع جنوب پل های غربی | پیمانکار حفاری دستی 3 | 0.04 | 0.07 |
| 234 | 7.2.1.1.2.4 | پیش ساخت آرماتور شمع های بتنی W3-P26~31 داخل میدان موجود (ضلع شمالی پل های غربی) | 3d | 2025-12-19 A | 2025-12-21 A | 227 | 100% |  |  |  | آرماتوربندی شمع [17938 کیلوگرم]; Ø12 [306.52 کیلوگرم]; Ø20 [1328.86 کیلوگرم]; Ø25 [1635.38 کیلوگرم] | 5,246,865 | 5,246,865 | 100% | 19% | 19% | 22% | 27% | 65% | 70% | 100% | No | آرماتوربندی | پیش ساخت | روگذر | ضلع جنوب پل های غربی | پیمانکار آرماتوربندی 3 | 0.10 | 0.07 |
| 235 | 7.2.1.1.2.5 | نصب آرماتور شمع های بتنی W3-P26~31 داخل میدان موجود (ضلع شمالی پل های غربی) | 1d | 2025-12-28 A | 2025-12-28 A | 234FS-2d, 233 | 100% |  |  |  | نصب آرماتوربندی شمع [18249 کیلوگرم] | 2,874,217.5 | 2,874,217.5 | 0% | 0% | 0% | 0% | 0% | 50% | 50% | 50% | No | آرماتوربندی | نصب | روگذر | ضلع جنوب پل های غربی | پیمانکار آرماتوربندی 3 | 0.06 | 0.02 |
| 236 | 7.2.1.1.2.6 | بتن ریزی شمع های بتنی W3-P26~31 داخل میدان موجود (ضلع شمالی پل های غربی) | 1d | 2025-12-29 A | 2025-12-29 A | 235 | 100% |  |  |  | بتن ریزی [136 مترمکعب] | 2,992,000 | 2,992,000 | 0% | 0% | 0% | 0% | 0% | 50% | 50% | 50% | No | بتن ریزی | اجرا | روگذر | ضلع جنوب پل های غربی | پیمانکار بتن ریزی 1 | 0.06 | 0.02 |
| 237 | 7.2.1.1.3 | **اجرای شمع های بتنی محور A2-P110~151 (ضلع شمالی پل های غربی)** | 142d | 2025-12-22 A | 2026-05-24 |  | 15% | 120.05d | 161d |  |  | 154,258,377.5 | 24,226,683 | 0% | 0% | 0% | 0% | 0% | 0% | 0% | 0% | No |  |  |  |  |  |  |  |
| 238 | 7.2.1.1.3.1 | حفاری شمع های بتنی P110~151 (ضلع شمالی پل های غربی) | 32d | 2026-03-29 | 2026-05-01 | 277 |  |  | 116d | 0d | حفر چاه ماشینی [1115 مترطول] | 27,875,000 |  | 0% | 0% | 0% | 0% | 0% | 0% | 0% | 0% | No | حفر چاه ماشینی | اجرا | روگذر | ضلع جنوب پل های غربی | پیمانکار حفر ماشینی 2 | 0.54 | 0.76 |
| 239 | 7.2.1.1.3.2 | پیش ساخت آرماتور شمع های بتنی P110~151 (ضلع شمالی پل های غربی) | 45d | 2025-12-22 A | 2026-02-07 | 234 | 38% | 28d | 30d | 0d | آرماتوربندی شمع [219246 کیلوگرم]; Ø12 [52587.4 کیلوگرم]; Ø20 [14938.6 کیلوگرم]; Ø25 [23284.8 کیلوگرم]; Ø32 [108128 کیلوگرم] | 64,129,455 | 24,226,683 | 0% | 2% | 0% | 0% | 0% | 0% | 0% | 0% | No | آرماتوربندی | پیش ساخت | روگذر | ضلع جنوب پل های غربی | پیمانکار آرماتوربندی 3 | 1.23 | 1.00 |
| 240 | 7.2.1.1.3.3 | نصب آرماتور شمع های بتنی P110~151 (ضلع شمالی پل های غربی) | 25d | 2026-04-25 | 2026-05-19 | 239, 238FS-7d |  |  | 161d | 0d | نصب آرماتوربندی شمع [219263 کیلوگرم] | 34,533,922.5 |  | 0% | 0% | 0% | 0% | 0% | 0% | 0% | 0% | No | آرماتوربندی | نصب | روگذر | ضلع جنوب پل های غربی | پیمانکار آرماتوربندی 3 | 0.66 | 0.56 |
| 241 | 7.2.1.1.3.4 | بتن ریزی شمع های بتنی P110~151 (ضلع شمالی پل های غربی) | 8d | 2026-05-17 | 2026-05-24 | 240FS-3d |  |  | 161d | 0d | بتن ریزی [1260 مترمکعب] | 27,720,000 |  | 0% | 0% | 0% | 0% | 0% | 0% | 0% | 0% | No | بتن ریزی | اجرا | روگذر | ضلع جنوب پل های غربی | پیمانکار بتن ریزی 1 | 0.53 | 0.18 |

| ID | WBS | Task | Duration | Start | Finish | Predecessors | Complete | Remaining | Total slack | Free slack | Resources | Cost | Actual cost | 1404.07.07 | 1404.07.14 | 1404.07.21 | 1404.07.28 | 1404.08.05 | 1404.08.12 | 1404.08.19 | 1404.08.26 | معارض | Activity Category | Activity Type | Task Category | Task Sub Category | نام پیمانکار | Text7 | Text8 |
| --- | --- | --- | --- | --- | --- | --- | --- | --- | --- | --- | --- | --- | --- | --- | --- | --- | --- | --- | --- | --- | --- | --- | --- | --- | --- | --- | --- | --- | --- |
| 242 | 7.2.1.1.4 | **اجرای شمع های بتنی W1-P1~78 (ضلع شمالی پل های غربی)** | 56d | 2025-12-28 A | 2026-02-25 |  | 22% | 43.92d | 30d |  |  | 48,021,910 | 4,031,500 | 0% | 0% | 0% | 0% | 0% | 0% | 0% | 0% | No |  |  |  |  |  |  |  |
| 243 | 7.2.1.1.4.1 | حفاری شمع های بتنی W1-P1~78 (ضلع شمالی پل های غربی) | 30d | 2025-12-28 A | 2026-01-28 | 233 | 37% | 19d | 52d | 22d | حفر چاه دستی [733 مترطول] | 10,995,000 | 4,031,500 | 0% | 0% | 0% | 0% | 0% | 0% | 0% | 0% | No | حفر چاه دستی | اجرا | روگذر | ضلع جنوب پل های غربی | پیمانکار حفاری دستی 3 | 0.21 | 0.67 |
| 244 | 7.2.1.1.4.2 | پیش ساخت آرماتور شمع های بتنی W1-P1~78 (ضلع شمالی پل های غربی) | 12d | 2026-02-08 | 2026-02-20 | 239 |  |  | 30d | 0d | آرماتوربندی شمع [60733 کیلوگرم]; Ø12 [9511.84 کیلوگرم]; Ø20 [26410.3 کیلوگرم]; Ø25 [16539.6 کیلوگرم] | 17,764,402.5 |  | 35% | 30% | 30% | 33% | 38% | 42% | 45% | 45% | No | آرماتوربندی | پیش ساخت | روگذر | ضلع جنوب پل های غربی | پیمانکار آرماتوربندی 3 | 0.34 | 0.27 |
| 245 | 7.2.1.1.4.3 | نصب آرماتور شمع های بتنی W1-P1~78 (ضلع شمالی پل های غربی) | 6d | 2026-02-18 | 2026-02-23 | 243FS-4d, 244FS-3d |  |  | 30d | 0d | نصب آرماتوربندی شمع [60981 کیلوگرم] | 9,604,507.5 |  | 0% | 0% | 0% | 0% | 0% | 0% | 0% | 0% | No | آرماتوربندی | نصب | روگذر | ضلع جنوب پل های غربی | پیمانکار آرماتوربندی 3 | 0.18 | 0.13 |
| 246 | 7.2.1.1.4.4 | بتن ریزی شمع های بتنی W1-P1~78 (ضلع شمالی پل های غربی) | 3d | 2026-02-23 | 2026-02-25 | 245FS-1d |  |  | 30d | 0d | بتن ریزی [439 مترمکعب] | 9,658,000 |  | 0% | 0% | 0% | 0% | 0% | 0% | 0% | 0% | No | بتن ریزی | اجرا | روگذر | ضلع جنوب پل های غربی | پیمانکار بتن ریزی 1 | 0.19 | 0.07 |
| 247 | 7.2.1.1.5 | **اجرای دیوارهای نمایی شمال غربی محور A2 (پل های غربی)** | 47d | 2026-05-25 | 2026-07-12 |  |  |  | 161d |  |  | 35,531,450 |  | 0% | 0% | 0% | 0% | 0% | 0% | 0% | 0% | No |  |  |  |  |  |  |  |
| 248 | 7.2.1.1.5.1 | بغل تراشی خاک (دیوارهای نمایی شمال غربی محور A2) | 6d | 2026-05-25 | 2026-05-30 | 241, 287 |  |  | 161d | 0d | بغل تراشی خاک [873 مترمکعب] | 3,055,500 |  | 0% | 0% | 0% | 0% | 0% | 0% | 0% | 0% | No | بغل تراشی خاک | اجرا | روگذر | ضلع جنوب پل های غربی | پیمانکار بغل تراشی 2 | 0.06 | 0.13 |
| 249 | 7.2.1.1.5.2 | اجرای لایه زهكش (دیوارهای نمایی شمال غربی محور A2) | 4d | 2026-05-31 | 2026-06-03 | 248 |  |  | 161d | 0d | زهکش [857 مترمربع] | 5,784,750 |  | 0% | 0% | 0% | 0% | 0% | 0% | 0% | 0% | No | زهکش | اجرا | روگذر | ضلع جنوب پل های غربی | پیمانکار اجرای زهکش 1 | 0.11 | 0.09 |
| 250 | 7.2.1.1.5.3 | آرماتوربندی دیوار (دیوارهای نمایی شمال غربی محور A2) | 9d | 2026-06-06 | 2026-06-14 | 249 |  |  | 161d | 0d | آرماتوربندی دیواره [19570 کیلوگرم] | 8,806,500 |  | 0% | 0% | 0% | 0% | 0% | 0% | 0% | 0% | No | آرماتوربندی | اجرا | روگذر | ضلع جنوب پل های غربی | پیمانکار آرماتوربندی 3 | 0.17 | 0.20 |
| 251 | 7.2.1.1.5.4 | قالب بندی دیوار نمایی (دیوارهای نمایی شمال غربی محور A2) | 22d | 2026-06-15 | 2026-07-06 | 250 |  |  | 161d | 0d | قالب بندی [859 مترمربع] | 5,154,000 |  | 0% | 0% | 0% | 0% | 0% | 0% | 0% | 0% | No | قالب بندی | اجرا | روگذر | ضلع جنوب پل های غربی | پیمانکار قالب بندی 1 | 0.10 | 0.49 |
| 252 | 7.2.1.1.5.5 | بتن ریزی دیوار (دیوارهای نمایی شمال غربی محور A2) | 2d | 2026-07-07 | 2026-07-08 | 251 |  |  | 161d | 0d | بتن ریزی [173 مترمکعب] | 3,806,000 |  | 0% | 0% | 0% | 0% | 0% | 0% | 0% | 0% | No | بتن ریزی | اجرا | روگذر | ضلع جنوب پل های غربی | پیمانکار بتن ریزی 1 | 0.07 | 0.04 |
| 253 | 7.2.1.1.5.6 | اجرای سرشمع ها و قرنیز (دیوارهای نمایی شمال غربی محور A2) | 4d | 2026-07-09 | 2026-07-12 | 252 |  |  | 161d |  | سرشمع و قرنیز [142 مترطول] | 8,924,700 |  | 0% | 0% | 0% | 0% | 0% | 0% | 0% | 0% | No | سرشمع و قرنیز | اجرا | روگذر | ضلع جنوب پل های غربی | پیمانکار ساخت و نصب و اجرای سرشمع و قرنیز 1 | 0.17 | 0.09 |
| 254 | 7.2.1.1.6 | **اجرای ستون های میانی محور P1-P92~100 (ضلع شمالی پل های غربی)** | 210d | 2025-10-28 A | 2026-06-09 |  | 3% | 204.47d | 122d |  |  | 42,331,880 | 532,500 | 0% | 0% | 0% | 0% | 0% | 0% | 0% | 0% | No |  |  |  |  |  |  |  |
| 255 | 7.2.1.1.6.1 | حفاری تا تراز زیر گذر ستون های میانی محور P1-P92~100 (ضلع جنوبی پل های غربی) | 1d | 2025-10-28 A | 2025-10-28 A | 294 | 100% |  |  |  | خاکبرداری [355 مترمکعب] | 532,500 | 532,500 | 0% | 0% | 0% | 0% | 0% | 0% | 0% | 0% | No | خاکبرداری | اجرا | روگذر | ضلع جنوب پل های غربی | پیمانکار خاکبرداری و خاکریزی 2 | 0.01 | 0.02 |
| 256 | 7.2.1.1.6.2 | حفاری شمع ها از تراز زیر گذر به پایین ستون های میانی محور P1-P92~100 (ضلع جنوبی پل های غربی) | 10d | 2026-05-13 | 2026-05-22 | 255, 295 |  |  | 116d | 0d | حفر چاه ماشینی [322 مترطول] | 8,050,000 |  | 0% | 0% | 0% | 0% | 0% | 0% | 0% | 0% | No | حفر چاه ماشینی | اجرا | روگذر | ضلع جنوب پل های غربی | پیمانکار حفر ماشینی 1 | 0.15 | 0.22 |
| 257 | 7.2.1.1.6.3 | پیش ساخت آرماتور شمع ها ستون های میانی محور P1-P92~100 (ضلع جنوبی پل های غربی) | 10d | 2026-02-21 | 2026-03-02 | 244 |  |  | 197d | 75d | آرماتوربندی شمع [49914 کیلوگرم]; Ø12 [12275.7 کیلوگرم]; Ø20 [4214.79 کیلوگرم]; Ø25 [28523.9 کیلوگرم] | 14,599,845 |  | 0% | 0% | 0% | 0% | 0% | 0% | 0% | 0% | No | آرماتوربندی | پیش ساخت | روگذر | ضلع جنوب پل های غربی | پیمانکار آرماتوربندی 3 | 0.28 | 0.24 |
| 258 | 7.2.1.1.6.4 | نصب آرماتور شمع ها ستون های میانی محور P1-P92~100 (ضلع جنوبی پل های غربی) | 6d | 2026-05-23 | 2026-05-28 | 257FS-2d, 256 |  |  | 122d | 0d | نصب آرماتوربندی شمع [50178 کیلوگرم] | 7,903,035 |  | 0% | 0% | 0% | 0% | 0% | 0% | 0% | 0% | No | آرماتوربندی | نصب | روگذر | ضلع جنوب پل های غربی | پیمانکار آرماتوربندی 3 | 0.15 | 0.13 |
| 259 | 7.2.1.1.6.5 | بتن ریزی شمع ها ستون های میانی محور P1-P92~100 (ضلع جنوبی پل های غربی) | 3d | 2026-05-28 | 2026-05-30 | 258FS-1d |  |  | 122d | 0d | بتن ریزی [364 مترمکعب] | 8,008,000 |  | 0% | 0% | 0% | 0% | 0% | 0% | 0% | 0% | No | بتن ریزی | اجرا | روگذر | ضلع جنوب پل های غربی | پیمانکار بتن ریزی 1 | 0.15 | 0.07 |
| 260 | 7.2.1.1.6.6 | قالب بندی ستون (قسمت نما) ستون های میانی محور P1-P92~100 (ضلع جنوبی پل های غربی) | 6d | 2026-05-31 | 2026-06-07 | 259 |  |  | 122d | 0d | قالب بندی [243 مترمربع] | 1,458,000 |  | 0% | 0% | 0% | 0% | 0% | 0% | 0% | 0% | No | قالب بندی | اجرا | روگذر | ضلع جنوب پل های غربی | پیمانکار قالب بندی 1 | 0.03 | 0.13 |
| 261 | 7.2.1.1.6.7 | بتن ریزی ستون های میانی محور P1-P92~100 (ضلع جنوبی پل های غربی) | 1d | 2026-06-08 | 2026-06-08 | 260 |  |  | 122d | 0d | بتن ریزی [72 مترمکعب] | 1,584,000 |  | 0% | 0% | 0% | 0% | 0% | 0% | 0% | 0% | No | بتن ریزی | اجرا | روگذر | ضلع جنوب پل های غربی | پیمانکار بتن ریزی 1 | 0.03 | 0.02 |
| 262 | 7.2.1.1.6.8 | قالب برداری و پرکردن اطراف ستون ها تا تراز زیر عرشه ستون های میانی محور P1-P92~100 (ضلع جنوبی پل های غربی) | 1d | 2026-06-09 | 2026-06-09 | 261 |  |  | 122d | 0d | خاکریزی [131 مترمکعب] | 196,500 |  | 0% | 0% | 0% | 0% | 0% | 0% | 0% | 0% | No | خاکریزی | اجرا | روگذر | ضلع جنوب پل های غربی | پیمانکار خاکبرداری و خاکریزی 2 | 0.00 | 0.02 |
| 263 | 7.2.1.2 | **اجرای شمع های بتنی (ضلع جنوبی پل های غربی)** | 268d | 2025-10-05 A | 2026-07-14 |  | 17% | 222.95d | 159d |  |  | 552,224,027.5 | 104,870,100.74 | 0% | 0% | 0% | 0% | 0% | 0% | 0% | 0% | No |  |  |  |  |  |  |  |
| 264 | 7.2.1.2.1 | **اجرای شمع های بتنی W4-P1~16 خارج از میدان (ضلع جنوبی پل های غربی)** | 9d | 2025-12-22 A | 2025-12-30 A |  | 100% |  |  |  |  | 5,185,317.5 | 5,185,317.5 | 0% | 0% | 0% | 0% | 0% | 0% | 0% | 0% | No |  |  |  |  |  |  |  |
| 265 | 7.2.1.2.1.1 | حفاری شمع های بتنی W4-P1~16 خارج از میدان (ضلع جنوبی پل های غربی) | 4d | 2025-12-25 A | 2025-12-28 A | 151 | 100% |  |  |  | حفر چاه دستی [104 مترطول] | 1,560,000 | 1,560,000 | 0% | 0% | 0% | 0% | 0% | 0% | 0% | 0% | No | حفر چاه دستی | اجرا | روگذر | ضلع شمال پل های غربی | پیمانکار حفاری دستی 4 | 0.03 | 0.09 |
| 266 | 7.2.1.2.1.2 | پیش ساخت آرماتور شمع های بتنی W4-P1~16 خارج از میدان (ضلع جنوبی پل های غربی) | 2d | 2025-12-22 A | 2025-12-23 A | 165 | 100% |  |  |  | آرماتوربندی شمع [5350 کیلوگرم]; Ø12 [2698.12 کیلوگرم]; Ø20 [7523.63 کیلوگرم]; Ø25 [4435.2 کیلوگرم] | 1,564,875 | 1,564,875 | 0% | 19% | 19% | 22% | 27% | 31% | 34% | 34% | No | آرماتوربندی | پیش ساخت | روگذر | ضلع شمال پل های غربی | پیمانکار آرماتوربندی 4 | 0.03 | 0.04 |
| 267 | 7.2.1.2.1.3 | نصب آرماتور شمع های بتنی W4-P1~16 خارج از میدان (ضلع جنوبی پل های غربی) | 1d | 2025-12-29 A | 2025-12-29 A | 266, 265 | 100% |  |  |  | نصب آرماتوربندی شمع [5679 کیلوگرم] | 894,442.5 | 894,442.5 | 0% | 0% | 0% | 0% | 0% | 0% | 0% | 0% | No | آرماتوربندی | نصب | روگذر | ضلع شمال پل های غربی | پیمانکار آرماتوربندی 4 | 0.02 | 0.02 |
| 268 | 7.2.1.2.1.4 | بتن ریزی شمع های بتنی W4-P1~16 خارج از میدان (ضلع جنوبی پل های غربی) | 1d | 2025-12-30 A | 2025-12-30 A | 267 | 100% |  |  |  | بتن ریزی [53 مترمکعب] | 1,166,000 | 1,166,000 | 0% | 0% | 0% | 0% | 0% | 0% | 0% | 0% | No | بتن ریزی | اجرا | روگذر | ضلع شمال پل های غربی | پیمانکار بتن ریزی 1 | 0.02 | 0.02 |

| ID | WBS | Task | Duration | Start | Finish | Predecessors | Complete | Remaining | Total slack | Free slack | Resources | Cost | Actual cost | 1404.07.07 | 1404.07.14 | 1404.07.21 | 1404.07.28 | 1404.08.05 | 1404.08.12 | 1404.08.19 | 1404.08.26 | معارض | Activity Category | Activity Type | Task Category | Task Sub Category | نام پیمانکار | Text7 | Text8 |
| --- | --- | --- | --- | --- | --- | --- | --- | --- | --- | --- | --- | --- | --- | --- | --- | --- | --- | --- | --- | --- | --- | --- | --- | --- | --- | --- | --- | --- | --- |
| 269 | 7.2.1.2.2 | **اجرای شمع های بتنی W4-P17~37 داخل میدان موجود (ضلع جنوبی پل های غربی)** | 98d | 2025-10-05 A | 2026-01-12 |  | 90% | 9.33d | 234d |  |  | 77,928,410 | 71,688,960 | 0% | 0% | 0% | 0% | 0% | 0% | 0% | 0% | No |  |  |  |  |  |  |  |
| 270 | 7.2.1.2.2.1 | روتبال و قطاعی داخل میدان موجود (ضلع جنوبی پل های غربی) | 4d | 2025-10-05 A | 2025-10-08 A | 149 | 100% |  |  |  | روتبال و قطاعی [500 اصله] | 8,250,000 | 8,250,000 | 35% | 30% | 30% | 35% | 45% | 70% | 85% | 85% | No | روتبال و قطاعی | اجرا | روگذر | ضلع شمال پل های غربی | پیمانکار روتبال 2 | 0.16 | 0.09 |
| 271 | 7.2.1.2.2.2 | اجرای خاک برداری تا تراز روی شمع های بتنی W4-P17~37 داخل میدان موجود (ضلع جنوبی پل های غربی) | 18d | 2025-10-09 A | 2025-10-26 A | 270 | 100% |  |  |  | خاکبرداری [36071 مترمکعب] | 54,106,500 | 54,106,500 | 90% | 93% | 93% | 93% | 93% | 98% | 98% | 100% | No | خاکبرداری | اجرا | روگذر | ضلع شمال پل های غربی | پیمانکار خاکبرداری و خاکریزی 2 | 1.04 | 0.42 |
| 272 | 7.2.1.2.2.3 | حفاری شمع های بتنی W4-P17~37 داخل میدان موجود (ضلع جنوبی پل های غربی) | 10d | 2025-12-29 A | 2026-01-08 A | 271, 265 | 100% |  |  |  | حفر چاه دستی [237 مترطول] | 3,555,000 | 3,555,000 | 0% | 0% | 0% | 0% | 0% | 0% | 0% | 0% | No | حفر چاه دستی | اجرا | روگذر | ضلع شمال پل های غربی | پیمانکار حفاری دستی 4 | 0.07 | 0.22 |
| 273 | 7.2.1.2.2.4 | پیش ساخت آرماتور شمع های بتنی W4-P17~37 داخل میدان موجود (ضلع جنوبی پل های غربی) | 6d | 2025-12-24 A | 2025-12-29 A | 266 | 100% |  |  |  | آرماتوربندی شمع [19752 کیلوگرم]; Ø12 [1237.11 کیلوگرم]; Ø20 [5228.99 کیلوگرم] | 5,777,460 | 5,777,460 | 76% | 19% | 76% | 79% | 83% | 86% | 86% | 86% | No | آرماتوربندی | پیش ساخت | روگذر | ضلع شمال پل های غربی | پیمانکار آرماتوربندی 4 | 0.11 | 0.13 |
| 274 | 7.2.1.2.2.5 | نصب آرماتور شمع های بتنی W4-P17~37 داخل میدان موجود (ضلع جنوبی پل های غربی) | 3d | 2026-01-09 | 2026-01-11 | 273FS-3d, 272 |  |  | 234d | 0d | نصب آرماتوربندی شمع [20060 کیلوگرم] | 3,159,450 |  | 0% | 0% | 0% | 0% | 0% | 0% | 0% | 0% | No | آرماتوربندی | نصب | روگذر | ضلع شمال پل های غربی | پیمانکار آرماتوربندی 4 | 0.06 | 0.07 |
| 275 | 7.2.1.2.2.6 | بتن ریزی شمع های بتنی W4-P17~37 داخل میدان موجود (ضلع جنوبی پل های غربی) | 1d | 2026-01-12 | 2026-01-12 | 274 |  |  | 234d | 0d | بتن ریزی [140 مترمکعب] | 3,080,000 |  | 0% | 0% | 0% | 0% | 0% | 0% | 0% | 0% | No | بتن ریزی | اجرا | روگذر | ضلع شمال پل های غربی | پیمانکار بتن ریزی 1 | 0.06 | 0.02 |
| 276 | 7.2.1.2.3 | **اجرای شمع های بتنی محور A1-P1~91 (ضلع جنوبی پل های غربی)** | 113d | 2025-12-30 A | 2026-05-03 |  | 7% | 104.78d | 159d |  |  | 333,748,780 | 27,463,323.24 | 0% | 0% | 0% | 0% | 0% | 0% | 0% | 0% | No |  |  |  |  |  |  |  |
| 277 | 7.2.1.2.3.1 | حفاری شمع های بتنی های بتنی محور A1-P1~91 (ضلع جنوبی پل های غربی) | 73d | 2026-01-06 A | 2026-03-28 | 125 | 4% | 70d | 116d | 0d | حفر چاه ماشینی [2411 مترطول] | 60,275,000 | 2,477,054.79 | 0% | 0% | 0% | 0% | 0% | 0% | 5% | 5% | No | حفر چاه ماشینی | اجرا | روگذر | ضلع شمال پل های غربی | پیمانکار حفر ماشینی 2 | 1.16 | 1.63 |
| 278 | 7.2.1.2.3.2 | پیش ساخت آرماتور شمع های بتنی های بتنی محور A1-P1~91 (ضلع جنوبی پل های غربی) | 50d | 2025-12-30 A | 2026-02-21 | 273 | 18% | 41d | 130d | 0d | آرماتوربندی شمع [474573 کیلوگرم]; Ø12 [113939 کیلوگرم]; Ø20 [32366.9 کیلوگرم]; Ø25 [50450.4 کیلوگرم]; Ø32 [234278 کیلوگرم] | 138,812,602.5 | 24,986,268.45 | 0% | 0% | 0% | 0% | 0% | 0% | 0% | 0% | No | آرماتوربندی | پیش ساخت | روگذر | ضلع شمال پل های غربی | پیمانکار آرماتوربندی 4 | 2.67 | 1.11 |
| 279 | 7.2.1.2.3.3 | نصب آرماتور شمع های بتنی های بتنی محور A1-P1~91 (ضلع جنوبی پل های غربی) | 25d | 2026-03-25 | 2026-04-20 | 277FS-4d, 278 |  |  | 159d | 0d | نصب آرماتوربندی شمع [474217 کیلوگرم] | 74,689,177.5 |  | 0% | 0% | 0% | 0% | 0% | 0% | 0% | 0% | No | آرماتوربندی | نصب | روگذر | ضلع شمال پل های غربی | پیمانکار آرماتوربندی 4 | 1.44 | 0.56 |
| 280 | 7.2.1.2.3.4 | بتن ریزی شمع های بتنی های بتنی محور A1-P1~91 (ضلع جنوبی پل های غربی) | 17d | 2026-04-17 | 2026-05-03 | 279FS-4d |  |  | 159d | 0d | بتن ریزی [2726 مترمکعب] | 59,972,000 |  | 0% | 0% | 0% | 0% | 0% | 0% | 0% | 0% | No | بتن ریزی | اجرا | روگذر | ضلع شمال پل های غربی | پیمانکار بتن ریزی 1 | 1.15 | 0.38 |
| 281 | 7.2.1.2.4 | **اجرای شمع های بتنی W2-P1~48 (ضلع جنوبی پل های غربی)** | 49d | 2026-01-09 | 2026-03-01 |  |  |  | 130d |  |  | 15,888,190 |  | 0% | 0% | 0% | 0% | 0% | 0% | 0% | 0% | No |  |  |  |  |  |  |  |
| 282 | 7.2.1.2.4.1 | حفاری شمع های بتنی شمع های بتنی W2-P1~48 (ضلع جنوبی پل های غربی) | 13d | 2026-01-09 | 2026-01-22 | 272 |  |  | 162d | 32d | حفر چاه دستی [319 مترطول] | 4,785,000 |  | 100% | 100% | 100% | 100% | 100% | 100% | 100% | 100% | No | حفر چاه دستی | اجرا | روگذر | ضلع شمال پل های غربی | پیمانکار حفاری دستی 4 | 0.09 | 0.29 |
| 283 | 7.2.1.2.4.2 | پیش ساخت آرماتور شمع های بتنی شمع های بتنی W2-P1~48 (ضلع جنوبی پل های غربی) | 5d | 2026-02-22 | 2026-02-26 | 278 |  |  | 130d | 0d | آرماتوربندی شمع [16889 کیلوگرم]; Ø12 [3347.06 کیلوگرم]; Ø20 [14408.5 کیلوگرم] | 4,940,032.5 |  | 100% | 100% | 100% | 100% | 100% | 100% | 100% | 100% | No | آرماتوربندی | پیش ساخت | روگذر | ضلع شمال پل های غربی | پیمانکار آرماتوربندی 4 | 0.10 | 0.11 |
| 284 | 7.2.1.2.4.3 | نصب آرماتور شمع های بتنی شمع های بتنی W2-P1~48 (ضلع جنوبی پل های غربی) | 3d | 2026-02-26 | 2026-02-28 | 282, 283FS-1d |  |  | 130d | 0d | نصب آرماتوربندی شمع [17201 کیلوگرم] | 2,709,157.5 |  | 100% | 80% | 80% | 80% | 80% | 80% | 80% | 83% | No | آرماتوربندی | نصب | روگذر | ضلع شمال پل های غربی | پیمانکار آرماتوربندی 4 | 0.05 | 0.07 |
| 285 | 7.2.1.2.4.4 | بتن ریزی شمع های بتنی شمع های بتنی W2-P1~48 (ضلع جنوبی پل های غربی) | 1d | 2026-03-01 | 2026-03-01 | 284 |  |  | 130d | 0d | بتن ریزی [157 مترمکعب] | 3,454,000 |  | 90% | 55% | 55% | 55% | 55% | 55% | 55% | 83% | No | بتن ریزی | اجرا | روگذر | ضلع شمال پل های غربی | پیمانکار بتن ریزی 1 | 0.07 | 0.02 |
| 286 | 7.2.1.2.5 | **اجرای دیوارهای نمایی جنوب غربی محور A1 (پل های غربی)** | 70d | 2026-05-04 | 2026-07-14 |  |  |  | 159d |  |  | 75,857,450 |  | 0% | 0% | 0% | 0% | 0% | 0% | 0% | 0% | No |  |  |  |  |  |  |  |
| 287 | 7.2.1.2.5.1 | بغل تراشی خاک (دیوارهای نمایی جنوب غربی محور A1) | 11d | 2026-05-04 | 2026-05-14 | 280 |  |  | 159d | 0d | بغل تراشی خاک [1845 مترمکعب] | 6,457,500 |  | 0% | 0% | 0% | 0% | 0% | 0% | 0% | 0% | No | بغل تراشی خاک | اجرا | روگذر | ضلع شمال پل های غربی | پیمانکار بغل تراشی 2 | 0.12 | 0.24 |
| 288 | 7.2.1.2.5.2 | اجرای لایه زهكش (دیوارهای نمایی جنوب غربی محور A1) | 8d | 2026-05-15 | 2026-05-22 | 287 |  |  | 159d | 0d | زهکش [1829 مترمربع] | 12,345,750 |  | 0% | 0% | 0% | 0% | 0% | 0% | 0% | 0% | No | زهکش | اجرا | روگذر | ضلع شمال پل های غربی | پیمانکار اجرای زهکش 1 | 0.24 | 0.18 |
| 289 | 7.2.1.2.5.3 | آرماتوربندی دیوار (دیوارهای نمایی جنوب غربی محور A1) | 15d | 2026-05-23 | 2026-06-08 | 288 |  |  | 159d | 0d | آرماتوربندی دیواره [41924 کیلوگرم] | 18,865,800 |  | 0% | 0% | 0% | 0% | 0% | 0% | 0% | 0% | No | آرماتوربندی | اجرا | روگذر | ضلع شمال پل های غربی | پیمانکار آرماتوربندی 4 | 0.36 | 0.33 |
| 290 | 7.2.1.2.5.4 | قالب بندی دیوار نمایی (دیوارهای نمایی جنوب غربی محور A1) | 25d | 2026-06-09 | 2026-07-03 | 289 |  |  | 159d | 0d | قالب بندی [1831 مترمربع] | 10,986,000 |  | 0% | 0% | 0% | 0% | 0% | 0% | 0% | 0% | No | قالب بندی | اجرا | روگذر | ضلع شمال پل های غربی | پیمانکار قالب بندی 1 | 0.21 | 0.56 |
| 291 | 7.2.1.2.5.5 | بتن ریزی دیوار (دیوارهای نمایی جنوب غربی محور A1) | 3d | 2026-07-04 | 2026-07-06 | 290 |  |  | 159d | 0d | بتن ریزی [368 مترمکعب] | 8,096,000 |  | 0% | 0% | 0% | 0% | 0% | 0% | 0% | 0% | No | بتن ریزی | اجرا | روگذر | ضلع شمال پل های غربی | پیمانکار بتن ریزی 1 | 0.16 | 0.07 |
| 292 | 7.2.1.2.5.6 | اجرای سرشمع ها و قرنیز (دیوارهای نمایی جنوب غربی محور A1) | 8d | 2026-07-07 | 2026-07-14 | 291 |  |  | 159d |  | سرشمع و قرنیز [304 مترطول] | 19,106,400 |  | 0% | 0% | 0% | 0% | 0% | 0% | 0% | 0% | No | سرشمع و قرنیز | اجرا | روگذر | ضلع شمال پل های غربی | پیمانکار ساخت و نصب و اجرای سرشمع و قرنیز 1 | 0.37 | 0.18 |

| ID | WBS | Task | Duration | Start | Finish | Predecessors | Complete | Remaining | Total slack | Free slack | Resources | Cost | Actual cost | 1404.07.07 | 1404.07.14 | 1404.07.21 | 1404.07.28 | 1404.08.05 | 1404.08.12 | 1404.08.19 | 1404.08.26 | معارض | Activity Category | Activity Type | Task Category | Task Sub Category | نام پیمانکار | Text7 | Text8 |
| --- | --- | --- | --- | --- | --- | --- | --- | --- | --- | --- | --- | --- | --- | --- | --- | --- | --- | --- | --- | --- | --- | --- | --- | --- | --- | --- | --- | --- | --- |
| 293 | 7.2.1.2.6 | **اجرای ستون های میانی محور P2-101~109 (ضلع جنوبی پل های غربی)** | 200d | 2025-10-27 A | 2026-05-27 |  | 2% | 195.45d | 133d |  |  | 43,615,880 | 532,500 | 0% | 0% | 0% | 0% | 0% | 0% | 0% | 0% | No |  |  |  |  |  |  |  |
| 294 | 7.2.1.2.6.1 | حفاری تا تراز زیر گذر ستون های میانی محور P2-101~109 (ضلع جنوبی پل های غربی) | 1d | 2025-10-27 A | 2025-10-27 A | 271 | 100% |  |  |  | خاکبرداری [355 مترمکعب] | 532,500 | 532,500 | 0% | 0% | 0% | 0% | 0% | 0% | 0% | 0% | No | خاکبرداری | اجرا | روگذر | ضلع شمال پل های غربی | پیمانکار خاکبرداری و خاکریزی 2 | 0.01 | 0.02 |
| 295 | 7.2.1.2.6.2 | حفاری شمع ها از تراز زیر گذر به پایین ستون های میانی محور P2-101~109 (ضلع جنوبی پل های غربی) | 11d | 2026-05-02 | 2026-05-12 | 294, 238 |  |  | 116d | 0d | حفر چاه ماشینی [364 مترطول] | 9,100,000 |  | 0% | 0% | 0% | 0% | 0% | 0% | 0% | 0% | No | حفر چاه ماشینی | اجرا | روگذر | ضلع شمال پل های غربی | پیمانکار حفر ماشینی 1 | 0.18 | 0.24 |
| 296 | 7.2.1.2.6.3 | پیش ساخت آرماتور شمع ها ستون های میانی محور P2-101~109 (ضلع جنوبی پل های غربی) | 14d | 2026-02-27 | 2026-03-13 | 283 |  |  | 171d | 0d | آرماتوربندی شمع [49914 کیلوگرم]; Ø12 [12275.7 کیلوگرم]; Ø20 [4214.79 کیلوگرم]; Ø25 [28523.9 کیلوگرم] | 14,599,845 |  | 0% | 0% | 0% | 0% | 0% | 0% | 0% | 0% | No | آرماتوربندی | پیش ساخت | روگذر | ضلع شمال پل های غربی | پیمانکار آرماتوربندی 4 | 0.28 | 0.33 |
| 297 | 7.2.1.2.6.4 | نصب آرماتور شمع ها ستون های میانی محور P2-101~109 (ضلع جنوبی پل های غربی) | 7d | 2026-05-10 | 2026-05-16 | 295FS-3d, 296FS-2d |  |  | 133d | 0d | نصب آرماتوربندی شمع [50178 کیلوگرم] | 7,903,035 |  | 0% | 0% | 0% | 0% | 0% | 0% | 0% | 0% | No | آرماتوربندی | نصب | روگذر | ضلع شمال پل های غربی | پیمانکار آرماتوربندی 4 | 0.15 | 0.16 |
| 298 | 7.2.1.2.6.5 | بتن ریزی شمع ها ستون های میانی محور P2-101~109 (ضلع جنوبی پل های غربی) | 3d | 2026-05-17 | 2026-05-19 | 297 |  |  | 133d | 0d | بتن ریزی [364 مترمکعب] | 8,008,000 |  | 0% | 0% | 0% | 0% | 0% | 0% | 0% | 0% | No | بتن ریزی | اجرا | روگذر | ضلع شمال پل های غربی | پیمانکار بتن ریزی 1 | 0.15 | 0.07 |
| 299 | 7.2.1.2.6.6 | قالب بندی ستون (قسمت نما) ستون های میانی محور P2-101~109 (ضلع جنوبی پل های غربی) | 6d | 2026-05-20 | 2026-05-25 | 298 |  |  | 133d | 0d | قالب بندی [243 مترمربع] | 1,458,000 |  | 0% | 0% | 0% | 0% | 0% | 0% | 0% | 0% | No | قالب بندی | اجرا | روگذر | ضلع شمال پل های غربی | پیمانکار قالب بندی 1 | 0.03 | 0.13 |
| 300 | 7.2.1.2.6.7 | بتن ریزی ستون های میانی محور P2-101~109 (ضلع جنوبی پل های غربی) | 1d | 2026-05-26 | 2026-05-26 | 299 |  |  | 133d | 0d | بتن ریزی [72 مترمکعب] | 1,584,000 |  | 0% | 0% | 0% | 0% | 0% | 0% | 0% | 0% | No | بتن ریزی | اجرا | روگذر | ضلع شمال پل های غربی | پیمانکار بتن ریزی 1 | 0.03 | 0.02 |
| 301 | 7.2.1.2.6.8 | قالب برداری و پرکردن اطراف ستون ها تا تراز زیر عرشه ستون های میانی محور P2-101~109 (ضلع جنوبی پل های غربی) | 1d | 2026-05-27 | 2026-05-27 | 300 |  |  | 133d | 11d | خاکریزی [287 مترمکعب] | 430,500 |  | 0% | 0% | 0% | 0% | 0% | 0% | 0% | 0% | No | خاکریزی | اجرا | روگذر | ضلع شمال پل های غربی | پیمانکار خاکبرداری و خاکریزی 2 | 0.01 | 0.02 |
| 302 | 7.2.2 | **اجرای عرشه و پیش دال و مسیر رو گذر (ضلع غربی)** | 212d | 2026-01-13 | 2026-08-25 |  |  |  | 117d |  |  | 599,767,140 |  | 0% | 0% | 0% | 0% | 0% | 0% | 0% | 0% | No |  |  |  |  |  |  |  |
| 303 | 7.2.2.1 | **پل شماره 3 (دور میدان غربی)** | 212d | 2026-01-13 | 2026-08-25 |  |  |  | 117d |  |  | 309,675,240 |  | 0% | 0% | 0% | 0% | 0% | 0% | 0% | 0% | No |  |  |  |  |  |  |  |
| 304 | 7.2.2.1.1 | **اجرای شمع ها و ستون ها و تیر و دال بتنی و پل شماره 3 (دور میدان غربی)** | 162d | 2026-01-13 | 2026-07-06 |  |  |  | 167d |  |  | 67,472,140 |  | 0% | 0% | 0% | 0% | 0% | 0% | 0% | 0% | No |  |  |  |  |  |  |  |
| 305 | 7.2.2.1.1.1 | **اجرای شمع ها و ستون های بتنی شماره 152 تا 161 پل شماره 3 (دور میدان غربی)** | 145d | 2026-01-13 | 2026-06-19 |  |  |  | 184d |  |  | 56,951,790 |  | 0% | 0% | 0% | 0% | 0% | 0% | 0% | 0% | No |  |  |  |  |  |  |  |
| 306 | 7.2.2.1.1.1.1 | اجرای خاک برداری تا تراز زیر گذر پل شماره 3 (دور میدان غربی) | 1d | 2026-01-13 | 2026-01-13 | 275, 268 |  |  | 234d | 118d | خاکبرداری [385 مترمکعب] | 577,500 |  | 0% | 0% | 0% | 0% | 0% | 0% | 0% | 0% | No | خاکبرداری | اجرا | روگذر | پل شماره 3 دور میدان غربی | پیمانکار خاکبرداری و خاکریزی 2 | 0.01 | 0.02 |
| 307 | 7.2.2.1.1.1.2 | حفاری شمع ها و ستون های بتنی شماره 152 تا 161 پل شماره 3 (دور میدان غربی) | 6d | 2026-05-23 | 2026-05-28 | 306, 256 |  |  | 116d | 0d | حفر چاه ماشینی [423 مترطول] | 10,575,000 |  | 0% | 0% | 0% | 0% | 0% | 0% | 0% | 0% | No | حفر چاه ماشینی | اجرا | روگذر | پل شماره 3 دور میدان غربی | پیمانکار حفر ماشینی 1 | 0.20 | 0.13 |
| 308 | 7.2.2.1.1.1.3 | پیش ساخت آرماتور شمع های بتنی شماره 152 تا 161 پل شماره 3 (دور میدان غربی) | 15d | 2026-03-14 | 2026-04-04 | 296 |  |  | 171d | 0d | آرماتوربندی شمع [55416 کیلوگرم]; Ø12 [13639.7 کیلوگرم]; Ø20 [4683.1 کیلوگرم]; Ø25 [31693.2 کیلوگرم] | 16,209,180 |  | 0% | 0% | 0% | 0% | 0% | 0% | 0% | 0% | No | آرماتوربندی | پیش ساخت | روگذر | پل شماره 3 دور میدان غربی | پیمانکار آرماتوربندی 3 | 0.31 | 0.33 |
| 309 | 7.2.2.1.1.1.4 | نصب آرماتور شمع های بتنی شماره 152 تا 161 پل شماره 3 (دور میدان غربی) | 7d | 2026-05-29 | 2026-06-06 | 308FS-1d, 307 |  |  | 116d | 0d | نصب آرماتوربندی شمع [55672 کیلوگرم] | 8,768,340 |  | 0% | 0% | 0% | 0% | 0% | 0% | 0% | 0% | No | آرماتوربندی | نصب | روگذر | پل شماره 3 دور میدان غربی | پیمانکار آرماتوربندی 3 | 0.17 | 0.16 |
| 310 | 7.2.2.1.1.1.5 | بتن ریزی شمع های بتنی شماره 152 تا 161 پل شماره 3 (دور میدان غربی) | 3d | 2026-06-06 | 2026-06-08 | 309FS-1d |  |  | 116d | 0d | بتن ریزی [404 مترمکعب] | 8,888,000 |  | 0% | 0% | 0% | 0% | 0% | 0% | 0% | 0% | No | بتن ریزی | اجرا | روگذر | پل شماره 3 دور میدان غربی | پیمانکار بتن ریزی 1 | 0.17 | 0.07 |
| 311 | 7.2.2.1.1.1.6 | پیش ساخت آرماتور ستون های بتنی شماره 152 تا 161 پل شماره 3 (دور میدان غربی) | 1d | 2026-04-05 | 2026-04-05 | 308 |  |  | 257d |  | آرماتوربندی شمع [793 کیلوگرم] | 231,952.5 |  | 0% | 0% | 0% | 0% | 0% | 0% | 0% | 0% | No | آرماتوربندی | پیش ساخت | روگذر | پل شماره 3 دور میدان غربی | پیمانکار آرماتوربندی 3 | 0.00 | 0.02 |
| 312 | 7.2.2.1.1.1.7 | نصب آرماتور ستون های بتنی شماره 152 تا 161 پل شماره 3 (دور میدان غربی) | 1d | 2026-06-09 | 2026-06-09 | 310 |  |  | 116d | 0d | نصب آرماتوربندی شمع [1129 کیلوگرم] | 177,817.5 |  | 0% | 0% | 0% | 0% | 0% | 0% | 0% | 0% | No | آرماتوربندی | نصب | روگذر | پل شماره 3 دور میدان غربی | پیمانکار آرماتوربندی 3 | 0.00 | 0.02 |
| 313 | 7.2.2.1.1.1.8 | قالب بندی ستون های بتنی شماره 152 تا 161 پل شماره 3 (دور میدان غربی) | 7d | 2026-06-10 | 2026-06-16 | 312 |  |  | 116d | 0d | قالب بندی [421 مترمربع] | 2,526,000 |  | 0% | 0% | 0% | 0% | 0% | 0% | 0% | 0% | No | قالب بندی | اجرا | روگذر | پل شماره 3 دور میدان غربی | پیمانکار قالب بندی 1 | 0.05 | 0.16 |
| 314 | 7.2.2.1.1.1.9 | بتن ریزی ستون های بتنی شماره 152 تا 161 پل شماره 3 (دور میدان غربی) | 3d | 2026-06-17 | 2026-06-19 | 313 |  |  | 116d | 0d | بتن ریزی [409 مترمکعب] | 8,998,000 |  | 0% | 0% | 0% | 0% | 0% | 0% | 0% | 0% | No | بتن ریزی | اجرا | روگذر | پل شماره 3 دور میدان غربی | پیمانکار بتن ریزی 1 | 0.17 | 0.07 |
| 315 | 7.2.2.1.1.2 | **اجرای تیر و دال بتنی پل شماره 3** | 17d | 2026-06-20 | 2026-07-06 |  |  |  | 116d |  |  | 10,520,350 |  | 0% | 0% | 0% | 0% | 0% | 0% | 0% | 0% | No |  |  |  |  |  |  |  |
| 316 | 7.2.2.1.1.2.1 | اجرای کفراژ تیرهای بتنی پل شماره 3 (دور میدان غربی) | 4d | 2026-06-20 | 2026-06-23 | 314 |  |  | 116d | 0d | داربست بندی [1261 مترمکعب] | 630,500 |  | 0% | 0% | 0% | 0% | 0% | 0% | 0% | 0% | No | داربست بندی | اجرا | روگذر | پل شماره 3 دور میدان غربی | پیمانکار داربست بندی 1 | 0.01 | 0.09 |
| 317 | 7.2.2.1.1.2.2 | قالب بندی تیر بتنی پل شماره 3 (دور میدان غربی) | 8d | 2026-06-23 | 2026-06-30 | 316FS-1d |  |  | 116d | 0d | قالب بندی [319 مترمربع] | 1,914,000 |  | 0% | 0% | 0% | 0% | 0% | 0% | 0% | 0% | No | قالب بندی | اجرا | روگذر | پل شماره 3 دور میدان غربی | پیمانکار قالب بندی 1 | 0.04 | 0.18 |
| 318 | 7.2.2.1.1.2.3 | آرماتوربندی تیر بتنی پل شماره 3 (دور میدان غربی) | 7d | 2026-06-29 | 2026-07-05 | 317FS-2d |  |  | 116d | 0d | آرماتوربندی [15133 کیلوگرم] | 6,809,850 |  | 0% | 0% | 0% | 0% | 0% | 0% | 0% | 0% | No | آرماتوربندی | اجرا | روگذر | پل شماره 3 دور میدان غربی | پیمانکار آرماتوربندی 5 | 0.13 | 0.16 |
| 319 | 7.2.2.1.1.2.4 | بتن ریزی تیر بتنی پل شماره 3 (دور میدان غربی) | 1d | 2026-07-06 | 2026-07-06 | 318 |  |  | 116d | 0d | بتن ریزی [53 مترمکعب] | 1,166,000 |  | 0% | 0% | 0% | 0% | 0% | 0% | 0% | 0% | No | بتن ریزی | اجرا | روگذر | پل شماره 3 دور میدان غربی | پیمانکار بتن ریزی 1 | 0.02 | 0.02 |

| ID | WBS | Task | Duration | Start | Finish | Predecessors | Total slack | Free slack | Resources | Cost | 1404.07.07 | 1404.07.14 | 1404.07.21 | 1404.07.28 | 1404.08.05 | 1404.08.12 | 1404.08.19 | 1404.08.26 | معارض | Activity Category | Activity Type | Task Category | Task Sub Category | نام پیمانکار | Text7 | Text8 |
| --- | --- | --- | --- | --- | --- | --- | --- | --- | --- | --- | --- | --- | --- | --- | --- | --- | --- | --- | --- | --- | --- | --- | --- | --- | --- | --- |
| 320 | 7.2.2.1.2 | **اجرای عرشه پل شماره 3 بصورت تاپ دان (دور میدان غربی)** | 58d | 2026-06-14 | 2026-08-10 |  | 132d |  |  | 212,284,300 | 0% | 0% | 0% | 0% | 0% | 0% | 0% | 0% | No |  |  |  |  |  |  |  |
| 321 | 7.2.2.1.2.1 | اجرای خاک برداری تا تراز زیر عرشه پل شماره 3 (دور میدان غربی) | 4d | 2026-06-14 | 2026-06-17 | 262, 301, 346 | 132d | 16d | خاکبرداری [7005 مترمکعب] | 10,507,500 | 0% | 0% | 0% | 0% | 0% | 0% | 0% | 0% | No | خاکبرداری | اجرا | روگذر | پل شماره 3 دور میدان غربی | پیمانکار خاکبرداری و خاکریزی 2 | 0.20 | 0.09 |
| 322 | 7.2.2.1.2.2 | اجرای قالب بندی عرشه پل شماره 3 (دور میدان غربی) | 12d | 2026-07-04 | 2026-07-15 | 321, 319FS-3d, 347 | 116d | 0d | قالب بندی [1672 مترمربع] | 10,032,000 | 0% | 0% | 0% | 0% | 0% | 0% | 0% | 0% | No | قالب بندی | اجرا | روگذر | پل شماره 3 دور میدان غربی | پیمانکار قالب بندی 1 | 0.19 | 0.27 |
| 323 | 7.2.2.1.2.3 | اجرای آرماتوربندی عرشه پل شماره 3 (دور میدان غربی) | 20d | 2026-07-12 | 2026-07-31 | 322FS-4d | 116d | 0d | آرماتوربندی [346324 کیلوگرم] | 155,845,800 | 0% | 0% | 0% | 0% | 0% | 0% | 0% | 0% | No | آرماتوربندی | اجرا | روگذر | پل شماره 3 دور میدان غربی | پیمانکار آرماتوربندی 3 | 3.00 | 0.45 |
| 324 | 7.2.2.1.2.4 | بتن ریزی عرشه پل شماره 3 (دور میدان غربی) | 5d | 2026-07-31 | 2026-08-04 | 323FS-1d | 116d | 0d | بتن ریزی [832 مترمکعب] | 18,304,000 | 0% | 0% | 0% | 0% | 0% | 0% | 0% | 0% | No | بتن ریزی | اجرا | روگذر | پل شماره 3 دور میدان غربی | پیمانکار بتن ریزی 1 | 0.35 | 0.11 |
| 325 | 7.2.2.1.2.5 | خاک برداری زیر عرشه تا تراز زیر گذر پل شماره 3 (دور میدان غربی) | 6d | 2026-08-05 | 2026-08-10 | 324 | 132d |  | خاکبرداری [11730 مترمکعب] | 17,595,000 | 0% | 0% | 0% | 0% | 0% | 0% | 0% | 0% | No | خاکبرداری | اجرا | روگذر | پل شماره 3 دور میدان غربی | پیمانکار خاکبرداری و خاکریزی 2 | 0.34 | 0.13 |
| 326 | 7.2.2.1.3 | **اجرای پیش دال پل شماره 3** | 9d | 2026-08-05 | 2026-08-13 |  | 116d |  |  | 4,591,600 | 0% | 0% | 0% | 0% | 0% | 0% | 0% | 0% | No |  |  |  |  |  |  |  |
| 327 | 7.2.2.1.3.1 | اجرای قالب بندی لبه پیش دال پل شماره 3 (دور میدان غربی) | 5d | 2026-08-05 | 2026-08-09 | 324 | 116d | 0d | قالب بندی [54 مترمربع] | 324,000 | 0% | 0% | 0% | 0% | 0% | 0% | 0% | 0% | No | قالب بندی | اجرا | روگذر | پل شماره 3 دور میدان غربی | پیمانکار قالب بندی 1 | 0.01 | 0.11 |
| 328 | 7.2.2.1.3.2 | اجرای آرماتوربندی پیش دال پل شماره 3 (دور میدان غربی) | 3d | 2026-08-10 | 2026-08-12 | 327 | 116d | 0d | آرماتوربندی [6648 کیلوگرم] | 2,991,600 | 0% | 0% | 0% | 0% | 0% | 0% | 0% | 0% | No | آرماتوربندی | اجرا | روگذر | پل شماره 3 دور میدان غربی | پیمانکار آرماتوربندی 3 | 0.06 | 0.07 |
| 329 | 7.2.2.1.3.3 | بتن ریزی پیش دال پل شماره 3 (دور میدان غربی) | 1d | 2026-08-13 | 2026-08-13 | 328 | 116d | 0d | بتن ریزی [58 مترمکعب] | 1,276,000 | 0% | 0% | 0% | 0% | 0% | 0% | 0% | 0% | No | بتن ریزی | اجرا | روگذر | پل شماره 3 دور میدان غربی | پیمانکار بتن ریزی 1 | 0.02 | 0.02 |
| 330 | 7.2.2.1.4 | **احداث مسیر پل شماره 3** | 11d | 2026-08-14 | 2026-08-24 |  | 116d |  |  | 9,093,900 | 0% | 0% | 0% | 0% | 0% | 0% | 0% | 0% | No |  |  |  |  |  |  |  |
| 331 | 7.2.2.1.4.1 | عملیات خاکی و اجرای رگلاژ و بستر سازی پل شماره 3 (دور میدان غربی) | 1d | 2026-08-14 | 2026-08-14 | 329 | 116d | 0d | رگلاژ و بسترسازی [1278 مترمربع] | 639,000 | 0% | 0% | 0% | 0% | 0% | 0% | 0% | 0% | No | رگلاژ و بسترسازی | اجرا | روگذر | پل شماره 3 دور میدان غربی | پیمانکار رگلاژ و بسترسازی 1 | 0.01 | 0.02 |
| 332 | 7.2.2.1.4.2 | اجرای زیر اساس پل شماره 3 (دور میدان غربی) | 1d | 2026-08-15 | 2026-08-15 | 331 | 116d | 0d | زیراساس [743 مترمربع] | 445,800 | 0% | 0% | 0% | 0% | 0% | 0% | 0% | 0% | No | زیراساس | اجرا | روگذر | پل شماره 3 دور میدان غربی | پیمانکار آسفالت 1 | 0.01 | 0.02 |
| 333 | 7.2.2.1.4.3 | اجرای جدول گذاری و احداث کانال بتنی پل شماره 3 (دور میدان غربی) | 7d | 2026-08-16 | 2026-08-22 | 332 | 116d | 0d | جدول و کانال بتنی [186 مترطول] | 2,325,000 | 0% | 0% | 0% | 0% | 0% | 0% | 0% | 0% | No | جدول گذاری و کانال بتنی | اجرا | روگذر | پل شماره 3 دور میدان غربی | پیمانکار اجرای جدول و کانال بتنی 1 | 0.04 | 0.16 |
| 334 | 7.2.2.1.4.4 | اجرای اساس پل شماره 3 (دور میدان غربی) | 1d | 2026-08-23 | 2026-08-23 | 333 | 116d | 0d | اساس [679 مترمربع] | 611,100 | 0% | 0% | 0% | 0% | 0% | 0% | 0% | 0% | No | اساس | اجرا | روگذر | پل شماره 3 دور میدان غربی | پیمانکار آسفالت 1 | 0.01 | 0.02 |
| 335 | 7.2.2.1.4.5 | اجرای عایق و آسفالت پل شماره 3 (دور میدان غربی) | 1d | 2026-08-24 | 2026-08-24 | 334 | 116d | 0d | آسفالت [1691 مترمربع] | 5,073,000 | 0% | 0% | 0% | 0% | 0% | 0% | 0% | 0% | No | آسفالت | اجرا | روگذر | پل شماره 3 دور میدان غربی | پیمانکار آسفالت 1 | 0.10 | 0.02 |
| 336 | 7.2.2.1.5 | **تکمیل مسیر رو گذر پل شماره 3** | 191d | 2026-02-05 | 2026-08-25 |  | 116d |  |  | 16,233,300 | 0% | 0% | 0% | 0% | 0% | 0% | 0% | 0% | No |  |  |  |  |  |  |  |
| 337 | 7.2.2.1.5.1 | ساخت قرنیز پیش ساخته پل شماره 3 (دور میدان غربی) | 14d | 2026-02-19 | 2026-03-04 | 215 | 248d | 0d | ساخت قرنیز [305 مترطول] | 274,500 | 0% | 0% | 0% | 0% | 0% | 0% | 0% | 0% | No | سرشمع و قرنیز | ساخت | روگذر | پل شماره 3 دور میدان غربی | پیمانکار ساخت و نصب و اجرای سرشمع و قرنیز 1 | 0.01 | 0.36 |
| 338 | 7.2.2.1.5.2 | نصب قرنیز پیش ساخته پل شماره 3 (دور میدان غربی) | 5d | 2026-08-05 | 2026-08-09 | 324, 337 | 119d | 0d | سرشمع و قرنیز [178 مترطول] | 11,187,300 | 0% | 0% | 0% | 0% | 0% | 0% | 0% | 0% | No | سرشمع و قرنیز | نصب | روگذر | پل شماره 3 دور میدان غربی | پیمانکار ساخت و نصب و اجرای سرشمع و قرنیز 1 | 0.22 | 0.11 |
| 339 | 7.2.2.1.5.3 | تکمیل آرماتوربندی و بتن ریزی پیاده رو پل شماره 3 (دور میدان غربی) | 6d | 2026-08-10 | 2026-08-15 | 338 | 119d | 0d | پیاده رو [219 مترمربع] | 1,204,500 | 0% | 0% | 0% | 0% | 0% | 0% | 0% | 0% | No | پیاده رو | اجرا | روگذر | پل شماره 3 دور میدان غربی | پیمانکار پیاده روسازی 1 | 0.02 | 0.13 |
| 340 | 7.2.2.1.5.4 | نصب جدول و عملیات تکمیلی پیاده رو پل شماره 3 (دور میدان غربی) | 5d | 2026-08-16 | 2026-08-20 | 339 | 119d | 0d | پیاده رو [153 مترمربع] | 841,500 | 0% | 0% | 0% | 0% | 0% | 0% | 0% | 0% | No | جدول گذاری و کانال بتنی | اجرا | روگذر | پل شماره 3 دور میدان غربی | پیمانکار اجرای جدول و کانال بتنی 1 | 0.02 | 0.11 |
| 341 | 7.2.2.1.5.5 | ساخت گارد ریل پل شماره 3 (دور میدان غربی) | 4d | 2026-02-05 | 2026-02-08 | 219 | 179d | 0d | ساخت گاردریل [143 مترطول مسیر] | 1,501,500 | 0% | 0% | 0% | 0% | 0% | 0% | 0% | 0% | No | گاردریل | ساخت | روگذر | پل شماره 3 دور میدان غربی | پیمانکار ساخت و نصب گاردریل 1 | 0.03 | 0.09 |
| 342 | 7.2.2.1.5.6 | نصب گارد ریل پل شماره 3 (دور میدان غربی) | 2d | 2026-08-20 | 2026-08-21 | 339, 340FS-1d, 341 | 119d | 3d | نصب گاردریل [158 مترطول مسیر] | 711,000 | 0% | 0% | 0% | 0% | 0% | 0% | 0% | 0% | No | گاردریل | نصب | روگذر | پل شماره 3 دور میدان غربی | پیمانکار ساخت و نصب گاردریل 1 | 0.01 | 0.04 |
| 343 | 7.2.2.1.5.7 | اجرای خط کشی مسیر و نصب علایم پل شماره 3 (دور میدان غربی) | 1d | 2026-08-25 | 2026-08-25 | 335, 342 | 116d |  | رنگ آمیزی مسیر [171 مترطول مسیر] | 513,000 | 0% | 0% | 0% | 0% | 0% | 0% | 0% | 0% | No | رنگ آمیزی مسیر | اجرا | روگذر | پل شماره 3 دور میدان غربی | پیمانکار نصب علائم و رنگ آمیزی 1 | 0.01 | 0.02 |

| ID | WBS | Task | Duration | Start | Finish | Predecessors | Total slack | Free slack | Resources | Cost | 1404.07.07 | 1404.07.14 | 1404.07.21 | 1404.07.28 | 1404.08.05 | 1404.08.12 | 1404.08.19 | 1404.08.26 | معارض | Activity Category | Activity Type | Task Category | Task Sub Category | نام پیمانکار | Text7 | Text8 |
| --- | --- | --- | --- | --- | --- | --- | --- | --- | --- | --- | --- | --- | --- | --- | --- | --- | --- | --- | --- | --- | --- | --- | --- | --- | --- | --- |
| 344 | 7.2.2.2 | **پل شماره 4 (دور برگردان غربی)** | 174d | 2026-02-09 | 2026-08-12 |  | 130d |  |  | 290,091,900 | 0% | 0% | 0% | 0% | 0% | 0% | 0% | 0% | No |  |  |  |  |  |  |  |
| 345 | 7.2.2.2.1 | **اجرای عرشه پل شماره 4 بصورت تاپ دان (دور برگردان غربی)** | 53d | 2026-06-10 | 2026-08-01 |  | 122d |  |  | 259,895,600 | 0% | 0% | 0% | 0% | 0% | 0% | 0% | 0% | No |  |  |  |  |  |  |  |
| 346 | 7.2.2.2.1.1 | اجرای خاک برداری تا تراز زیر عرشه پل شماره 4 (دور برگردان غربی) | 4d | 2026-06-10 | 2026-06-13 | 262, 301 | 122d | 0d | خاکبرداری [7281 مترمکعب] | 10,921,500 | 0% | 0% | 0% | 0% | 0% | 0% | 0% | 0% | No | خاکبرداری | اجرا | روگذر | پل شماره 4 دوربرگردان غربی | پیمانکار خاکبرداری و خاکریزی 1 | 0.21 | 0.09 |
| 347 | 7.2.2.2.1.2 | اجرای قالب بندی عرشه پل شماره 4 (دور برگردان غربی) | 14d | 2026-06-14 | 2026-06-27 | 346 | 122d | 0d | قالب بندی [1837 مترمربع] | 11,022,000 | 0% | 0% | 0% | 0% | 0% | 0% | 0% | 0% | No | قالب بندی | اجرا | روگذر | پل شماره 4 دوربرگردان غربی | پیمانکار قالب بندی 1 | 0.21 | 0.33 |
| 348 | 7.2.2.2.1.3 | اجرای آرماتوربندی عرشه پل شماره 4 (دور برگردان غربی) | 23d | 2026-06-27 | 2026-07-19 | 347FS-1d | 129d | 0d | آرماتوربندی [441278 کیلوگرم] | 198,575,100 | 0% | 0% | 0% | 0% | 0% | 0% | 0% | 0% | No | آرماتوربندی | اجرا | روگذر | پل شماره 4 دوربرگردان غربی | پیمانکار آرماتوربندی 4 | 3.82 | 0.56 |
| 349 | 7.2.2.2.1.4 | بتن ریزی عرشه پل شماره 4 (دور برگردان غربی) | 6d | 2026-07-20 | 2026-07-25 | 348 | 129d | 0d | بتن ریزی [914 مترمکعب] | 20,108,000 | 0% | 0% | 0% | 0% | 0% | 0% | 0% | 0% | No | بتن ریزی | اجرا | روگذر | پل شماره 4 دوربرگردان غربی | پیمانکار بتن ریزی 1 | 0.39 | 0.13 |
| 350 | 7.2.2.2.1.5 | خاک برداری زیر عرشه تا تراز زیر گذر پل شماره 4 (دور برگردان غربی) | 7d | 2026-07-26 | 2026-08-01 | 349 | 141d |  | خاکبرداری [12846 مترمکعب] | 19,269,000 | 0% | 0% | 0% | 0% | 0% | 0% | 0% | 0% | No | خاکبرداری | اجرا | روگذر | پل شماره 4 دوربرگردان غربی | پیمانکار خاکبرداری و خاکریزی 1 | 0.37 | 0.16 |
| 351 | 7.2.2.2.2 | **اجرای پیش دال دور برگردان پل شماره 4** | 6d | 2026-07-26 | 2026-07-31 |  | 129d |  |  | 4,814,100 | 0% | 0% | 0% | 0% | 0% | 0% | 0% | 0% | No |  |  |  |  |  |  |  |
| 352 | 7.2.2.2.2.1 | اجرای قالب بندی لبه پیش دال پل شماره 4 (دور برگردان غربی) | 2d | 2026-07-26 | 2026-07-27 | 349 | 129d | 0d | قالب بندی [59 مترمربع] | 354,000 | 0% | 0% | 0% | 0% | 0% | 0% | 0% | 0% | No | قالب بندی | اجرا | روگذر | پل شماره 4 دوربرگردان غربی | پیمانکار قالب بندی 1 | 0.01 | 0.04 |
| 353 | 7.2.2.2.2.2 | اجرای آرماتوربندی پیش دال پل شماره 4 (دور برگردان غربی) | 3d | 2026-07-28 | 2026-07-30 | 352 | 129d | 0d | آرماتوربندی [6978 کیلوگرم] | 3,140,100 | 0% | 0% | 0% | 0% | 0% | 0% | 0% | 0% | No | آرماتوربندی | اجرا | روگذر | پل شماره 4 دوربرگردان غربی | پیمانکار آرماتوربندی 4 | 0.06 | 0.07 |
| 354 | 7.2.2.2.2.3 | بتن ریزی پیش دال پل شماره 4 (دور برگردان غربی) | 1d | 2026-07-31 | 2026-07-31 | 353 | 129d | 0d | بتن ریزی [60 مترمکعب] | 1,320,000 | 0% | 0% | 0% | 0% | 0% | 0% | 0% | 0% | No | بتن ریزی | اجرا | روگذر | پل شماره 4 دوربرگردان غربی | پیمانکار بتن ریزی 1 | 0.03 | 0.02 |
| 355 | 7.2.2.2.3 | **احداث مسیر دور برگردان پل شماره 4** | 11d | 2026-08-01 | 2026-08-11 |  | 129d |  |  | 9,148,900 | 0% | 0% | 0% | 0% | 0% | 0% | 0% | 0% | No |  |  |  |  |  |  |  |
| 356 | 7.2.2.2.3.1 | عملیات خاکی و اجرای رگلاژ و بستر سازی پل شماره 4 (دور برگردان غربی) | 1d | 2026-08-01 | 2026-08-01 | 354 | 129d | 0d | رگلاژ و بسترسازی [1388 مترمربع] | 694,000 | 0% | 0% | 0% | 0% | 0% | 0% | 0% | 0% | No | رگلاژ و بسترسازی | اجرا | روگذر | پل شماره 4 دوربرگردان غربی | پیمانکار رگلاژ و بسترسازی 1 | 0.01 | 0.02 |
| 357 | 7.2.2.2.3.2 | اجرای زیر اساس پل شماره 4 (دور برگردان غربی) | 1d | 2026-08-02 | 2026-08-02 | 356 | 129d | 0d | زیراساس [743 مترمربع] | 445,800 | 0% | 0% | 0% | 0% | 0% | 0% | 0% | 0% | No | زیراساس | اجرا | روگذر | پل شماره 4 دوربرگردان غربی | پیمانکار آسفالت 2 | 0.01 | 0.02 |
| 358 | 7.2.2.2.3.3 | اجرای جدول گذاری و احداث کانال بتنی پل شماره 4 (دور برگردان غربی) | 7d | 2026-08-03 | 2026-08-09 | 357 | 129d | 0d | جدول و کانال بتنی [186 مترطول] | 2,325,000 | 0% | 0% | 0% | 0% | 0% | 0% | 0% | 0% | No | جدول گذاری و کانال بتنی | اجرا | روگذر | پل شماره 4 دوربرگردان غربی | پیمانکار اجرای جدول و کانال بتنی 2 | 0.04 | 0.16 |
| 359 | 7.2.2.2.3.4 | اجرای اساس پل شماره 4 (دور برگردان غربی) | 1d | 2026-08-10 | 2026-08-10 | 358 | 129d | 0d | اساس [679 مترمربع] | 611,100 | 0% | 0% | 0% | 0% | 0% | 0% | 0% | 0% | No | اساس | اجرا | روگذر | پل شماره 4 دوربرگردان غربی | پیمانکار آسفالت 2 | 0.01 | 0.02 |
| 360 | 7.2.2.2.3.5 | اجرای عایق و آسفالت پل شماره 4 (دور برگردان غربی) | 1d | 2026-08-11 | 2026-08-11 | 359 | 129d | 0d | آسفالت [1691 مترمربع] | 5,073,000 | 0% | 0% | 0% | 0% | 0% | 0% | 0% | 0% | No | آسفالت | اجرا | روگذر | پل شماره 4 دوربرگردان غربی | پیمانکار آسفالت 2 | 0.10 | 0.02 |
| 361 | 7.2.2.2.4 | **تکمیل مسیر رو گذر پل شماره 4** | 174d | 2026-02-09 | 2026-08-12 |  | 129d |  |  | 16,233,300 | 0% | 0% | 0% | 0% | 0% | 0% | 0% | 0% | No |  |  |  |  |  |  |  |
| 362 | 7.2.2.2.4.1 | ساخت قرنیز پیش ساخته پل شماره 4 (دور برگردان غربی) | 14d | 2026-03-05 | 2026-03-19 | 337 | 248d | 119d | ساخت قرنیز [305 مترطول] | 274,500 | 0% | 0% | 0% | 0% | 0% | 0% | 0% | 0% | No | سرشمع و قرنیز | ساخت | روگذر | پل شماره 4 دوربرگردان غربی | پیمانکار ساخت و نصب و اجرای سرشمع و قرنیز 1 | 0.01 | 0.36 |
| 363 | 7.2.2.2.4.2 | نصب قرنیز پیش ساخته پل شماره 4 (دور برگردان غربی) | 5d | 2026-07-26 | 2026-07-30 | 362, 349 | 129d | 0d | سرشمع و قرنیز [178 مترطول] | 11,187,300 | 0% | 0% | 0% | 0% | 0% | 0% | 0% | 0% | No | سرشمع و قرنیز | نصب | روگذر | پل شماره 4 دوربرگردان غربی | پیمانکار ساخت و نصب و اجرای سرشمع و قرنیز 1 | 0.22 | 0.11 |
| 364 | 7.2.2.2.4.3 | تکمیل آرماتوربندی و بتن ریزی پیاده رو پل شماره 4 (دور برگردان غربی) | 6d | 2026-07-31 | 2026-08-05 | 363 | 129d | 0d | پیاده رو [219 مترمربع] | 1,204,500 | 0% | 0% | 0% | 0% | 0% | 0% | 0% | 0% | No | پیاده رو | اجرا | روگذر | پل شماره 4 دوربرگردان غربی | پیمانکار آرماتوربندی 2 | 0.02 | 0.13 |
| 365 | 7.2.2.2.4.4 | نصب جدول و عملیات تکمیلی پیاده رو پل شماره 4 (دور برگردان غربی) | 5d | 2026-08-06 | 2026-08-10 | 364 | 129d | 0d | پیاده رو [153 مترمربع] | 841,500 | 0% | 0% | 0% | 0% | 0% | 0% | 0% | 0% | No | جدول گذاری و کانال بتنی | اجرا | روگذر | پل شماره 4 دوربرگردان غربی | پیمانکار اجرای جدول و کانال بتنی 2 | 0.02 | 0.11 |
| 366 | 7.2.2.2.4.5 | ساخت گارد ریل پل شماره 4 (دور برگردان غربی) | 4d | 2026-02-09 | 2026-02-13 | 341 | 179d | 0d | ساخت گاردریل [143 مترطول مسیر] | 1,501,500 | 0% | 0% | 0% | 0% | 0% | 0% | 0% | 0% | No | گاردریل | ساخت | روگذر | پل شماره 4 دوربرگردان غربی | پیمانکار ساخت و نصب گاردریل 1 | 0.03 | 0.09 |
| 367 | 7.2.2.2.4.6 | نصب گارد ریل پل شماره 4 (دور برگردان غربی) | 2d | 2026-08-10 | 2026-08-11 | 364, 365FS-1d, 366 | 129d | 0d | نصب گاردریل [158 مترطول مسیر] | 711,000 | 0% | 0% | 0% | 0% | 0% | 0% | 0% | 0% | No | گاردریل | نصب | روگذر | پل شماره 4 دوربرگردان غربی | پیمانکار ساخت و نصب گاردریل 1 | 0.01 | 0.04 |
| 368 | 7.2.2.2.4.7 | اجرای خط کشی مسیر و نصب علایم پل شماره 4 (دور برگردان غربی) | 1d | 2026-08-12 | 2026-08-12 | 360, 367 | 129d |  | رنگ آمیزی مسیر [171 مترطول مسیر] | 513,000 | 0% | 0% | 0% | 0% | 0% | 0% | 0% | 0% | No | رنگ آمیزی مسیر | اجرا | روگذر | پل شماره 4 دوربرگردان غربی | پیمانکار نصب علائم و رنگ آمیزی 1 | 0.01 | 0.02 |

| ID | WBS | Task | Duration | Start | Finish | Predecessors | Complete | Remaining | Total slack | Free slack | Resources | Cost | Actual cost | 1404.07.07 | 1404.07.14 | 1404.07.21 | 1404.07.28 | 1404.08.05 | 1404.08.12 | 1404.08.19 | 1404.08.26 | معارض | Activity Category | Activity Type | Task Category | Task Sub Category | نام پیمانکار | Text7 | Text8 |
| --- | --- | --- | --- | --- | --- | --- | --- | --- | --- | --- | --- | --- | --- | --- | --- | --- | --- | --- | --- | --- | --- | --- | --- | --- | --- | --- | --- | --- | --- |
| 369 | 8 | **احداث مسیر زیر گذر باند شمالی و جنوبی و سپتیک جمع آوری آب های سطحی** | 350d | 2025-12-02 A | 2026-11-30 |  | 5% | 332.93d | 20d |  |  | 1,202,961,823 | 43,446,250 | 0% | 0% | 0% | 0% | 0% | 0% | 0% | 0% | No |  |  |  |  |  |  |  |
| 370 | 8.1 | **احداث مسیر زیر گذر باند شمالی** | 348d | 2025-12-04 A | 2026-11-30 |  | 5% | 329.13d | 20d |  |  | 481,306,200 | 21,188,800 | 0% | 0% | 0% | 0% | 0% | 0% | 0% | 0% | No |  |  |  |  |  |  |  |
| 371 | 8.1.1 | **اجرای دیوار مسیر زیر گذر باند شمالی** | 147d | 2025-12-04 A | 2026-05-11 |  | 13% | 128.06d | 221d |  |  | 124,900,300 | 21,188,800 | 0% | 0% | 0% | 0% | 0% | 0% | 0% | 0% | No |  |  |  |  |  |  |  |
| 372 | 8.1.1.1 | **اجرای دیوار W7 مسیر زیر گذر باند شمالی** | 89d | 2025-12-04 A | 2026-03-06 |  | 20% | 71.52d | 279d |  |  | 36,511,000 | 9,892,100 | 0% | 0% | 0% | 0% | 0% | 0% | 0% | 0% | No |  |  |  |  |  |  |  |
| 373 | 8.1.1.1.1 | بغل تراشی خاک (دیوار W7 مسیر زیر گذر باند شمالی) | 4d | 2025-12-04 A | 2025-12-07 A | 98 | 100% |  |  |  | بغل تراشی خاک [628 مترمکعب] | 2,198,000 | 2,198,000 | 0% | 0% | 0% | 0% | 0% | 0% | 0% | 0% | No | بغل تراشی خاک | اجرا | زیرگذر | باند شمالی | پیمانکار بغل تراشی 2 | 0.04 | 0.09 |
| 374 | 8.1.1.1.2 | اجرای لایه زهكش (دیوار W7 مسیر زیر گذر باند شمالی) | 3d | 2025-12-08 A | 2025-12-10 A | 373 | 100% |  |  |  | زهکش [612 مترمربع] | 4,131,000 | 4,131,000 | 0% | 0% | 0% | 0% | 0% | 0% | 0% | 0% | No | زهکش | اجرا | زیرگذر | باند شمالی | پیمانکار اجرای زهکش 1 | 0.08 | 0.07 |
| 375 | 8.1.1.1.3 | اجرای آرماتوربندی دیوار (دیوار W7 مسیر زیر گذر باند شمالی) | 4d | 2025-12-11 A | 2025-12-14 A | 374 | 100% |  |  |  | آرماتوربندی دیواره [7918 کیلوگرم] | 3,563,100 | 3,563,100 | 0% | 0% | 0% | 0% | 0% | 0% | 0% | 0% | No | آرماتوربندی | اجرا | زیرگذر | باند شمالی | پیمانکار آرماتوربندی 1 | 0.07 | 0.09 |
| 376 | 8.1.1.1.4 | ساخت قطعات پیش ساخته (دیوار W7 مسیر زیر گذر باند شمالی) | 15d | 2026-02-03 | 2026-02-19 | 190 |  |  | 49d | 0d | ساخت قطعات پیش ساخته نما [602 مترمربع] | 9,872,800 |  | 0% | 0% | 0% | 0% | 0% | 0% | 0% | 1% | No | قطعات پیش ساخته نما | ساخت | زیرگذر | باند شمالی | پیمانکار ساخت و نصب قطعات پیش ساخته 1 | 0.19 | 0.38 |
| 377 | 8.1.1.1.5 | نصب قطعات پیش ساخته (دیوار W7 مسیر زیر گذر باند شمالی) | 8d | 2026-02-20 | 2026-02-27 | 376, 375 |  |  | 279d | 0d | نصب قطعات پیش ساخته نما [627 مترمربع] | 2,257,200 |  | 0% | 0% | 0% | 0% | 0% | 0% | 0% | 0% | No | قطعات پیش ساخته نما | نصب | زیرگذر | باند شمالی | پیمانکار ساخت و نصب قطعات پیش ساخته 1 | 0.04 | 0.18 |
| 378 | 8.1.1.1.6 | بتن ریزی دیوار (دیوار W7 مسیر زیر گذر باند شمالی) | 2d | 2026-02-28 | 2026-03-01 | 377 |  |  | 279d | 0d | بتن ریزی [184 مترمکعب] | 4,048,000 |  | 0% | 0% | 0% | 0% | 0% | 0% | 0% | 0% | No | بتن ریزی | اجرا | زیرگذر | باند شمالی | پیمانکار بتن ریزی 1 | 0.08 | 0.04 |
| 379 | 8.1.1.1.7 | ساخت قرنیز پیش ساخته (دیوار W7 مسیر زیر گذر باند شمالی) | 15d | 2026-02-03 | 2026-02-19 | 190 |  |  | 0d |  | ساخت قرنیز [288 مترطول] | 259,200 |  | 0% | 0% | 0% | 0% | 0% | 0% | 0% | 0% | No | سرشمع و قرنیز | ساخت | زیرگذر | باند شمالی | پیمانکار ساخت و نصب و اجرای سرشمع و قرنیز 1 | 0.00 | 0.33 |
| 380 | 8.1.1.1.8 | اجرای سرشمع ها و قرنیز (دیوار W7 مسیر زیر گذر باند شمالی) | 5d | 2026-03-02 | 2026-03-06 | 378, 379 |  |  | 279d |  | سرشمع و قرنیز [162 مترطول] | 10,181,700 |  | 0% | 0% | 0% | 0% | 0% | 0% | 0% | 0% | No | سرشمع و قرنیز | اجرا | زیرگذر | باند شمالی | پیمانکار ساخت و نصب و اجرای سرشمع و قرنیز 1 | 0.20 | 0.11 |
| 381 | 8.1.1.2 | **اجرای دیوار W5 مسیر زیر گذر باند شمالی** | 73d | 2025-12-21 A | 2026-03-07 |  | 21% | 57.9d | 278d |  |  | 18,212,100 | 5,165,800 | 0% | 0% | 0% | 0% | 0% | 0% | 0% | 0% | No |  |  |  |  |  |  |  |
| 382 | 8.1.1.2.1 | بغل تراشی خاک (دیوار W5 مسیر زیر گذر باند شمالی) | 2d | 2025-12-21 A | 2025-12-22 A | 108, 115, 373 | 100% |  |  |  | بغل تراشی خاک [335 مترمکعب] | 1,172,500 | 1,172,500 | 0% | 0% | 0% | 0% | 5% | 0% | 0% | 0% | No | بغل تراشی خاک | اجرا | زیرگذر | باند شمالی | پیمانکار بغل تراشی 2 | 0.02 | 0.04 |
| 383 | 8.1.1.2.2 | اجرای لایه زهكش (دیوار W5 مسیر زیر گذر باند شمالی) | 2d | 2025-12-23 A | 2025-12-24 A | 382 | 100% |  |  |  | زهکش [317 مترمربع] | 2,139,750 | 2,139,750 | 0% | 0% | 0% | 0% | 0% | 0% | 0% | 0% | No | زهکش | اجرا | زیرگذر | باند شمالی | پیمانکار اجرای زهکش 1 | 0.04 | 0.04 |
| 384 | 8.1.1.2.3 | اجرای آرماتوربندی دیوار (دیوار W5 مسیر زیر گذر باند شمالی) | 2d | 2025-12-25 A | 2025-12-26 A | 383 | 100% |  |  |  | آرماتوربندی دیواره [4119 کیلوگرم] | 1,853,550 | 1,853,550 | 0% | 0% | 0% | 0% | 0% | 0% | 0% | 0% | No | آرماتوربندی | اجرا | زیرگذر | باند شمالی | پیمانکار آرماتوربندی 2 | 0.04 | 0.04 |
| 385 | 8.1.1.2.4 | ساخت قطعات پیش ساخته (دیوار W5 مسیر زیر گذر باند شمالی) | 9d | 2026-02-20 | 2026-02-28 | 376 |  |  | 49d | 0d | ساخت قطعات پیش ساخته نما [307 مترمربع] | 5,034,800 |  | 0% | 0% | 0% | 0% | 0% | 0% | 0% | 1% | No | قطعات پیش ساخته نما | ساخت | زیرگذر | باند شمالی | پیمانکار ساخت و نصب قطعات پیش ساخته 1 | 0.10 | 0.20 |
| 386 | 8.1.1.2.5 | نصب قطعات پیش ساخته (دیوار W5 مسیر زیر گذر باند شمالی) | 4d | 2026-03-01 | 2026-03-04 | 385, 384 |  |  | 278d | 0d | نصب قطعات پیش ساخته نما [332 مترمربع] | 1,195,200 |  | 0% | 0% | 0% | 0% | 0% | 0% | 0% | 0% | No | قطعات پیش ساخته نما | نصب | زیرگذر | باند شمالی | پیمانکار ساخت و نصب قطعات پیش ساخته 1 | 0.02 | 0.09 |
| 387 | 8.1.1.2.6 | بتن ریزی دیوار (دیوار W5 مسیر زیر گذر باند شمالی) | 1d | 2026-03-05 | 2026-03-05 | 386 |  |  | 278d | 0d | بتن ریزی [96 مترمکعب] | 2,112,000 |  | 0% | 0% | 0% | 0% | 0% | 0% | 0% | 0% | No | بتن ریزی | اجرا | زیرگذر | باند شمالی | پیمانکار بتن ریزی 1 | 0.04 | 0.02 |
| 388 | 8.1.1.2.7 | ساخت قرنیز پیش ساخته (دیوار W5 مسیر زیر گذر باند شمالی) | 7d | 2026-02-20 | 2026-02-26 | 379 |  |  | 0d |  | ساخت قرنیز [199 مترطول] | 179,100 |  | 0% | 0% | 0% | 0% | 0% | 0% | 0% | 0% | No | سرشمع و قرنیز | ساخت | زیرگذر | باند شمالی | پیمانکار ساخت و نصب و اجرای سرشمع و قرنیز 1 | 0.00 | 0.16 |
| 389 | 8.1.1.2.8 | اجرای سرشمع ها و قرنیز (دیوار W5 مسیر زیر گذر باند شمالی) | 2d | 2026-03-06 | 2026-03-07 | 388, 387 |  |  | 278d |  | سرشمع و قرنیز [72 مترطول] | 4,525,200 |  | 0% | 0% | 0% | 0% | 0% | 0% | 0% | 0% | No | سرشمع و قرنیز | اجرا | زیرگذر | باند شمالی | پیمانکار ساخت و نصب و اجرای سرشمع و قرنیز 1 | 0.09 | 0.04 |
| 390 | 8.1.1.3 | **اجرای دیوار W3 مسیر زیر گذر باند شمالی** | 109d | 2025-12-30 A | 2026-04-29 |  | 22% | 84.78d | 233d |  |  | 21,706,550 | 6,130,900 | 0% | 0% | 0% | 0% | 0% | 0% | 0% | 0% | No |  |  |  |  |  |  |  |
| 391 | 8.1.1.3.1 | بغل تراشی خاک (دیوار W3 مسیر زیر گذر باند شمالی) | 3d | 2025-12-30 A | 2026-01-01 A | 236, 229, 382 | 100% |  |  |  | بغل تراشی خاک [395 مترمکعب] | 1,382,500 | 1,382,500 | 0% | 0% | 0% | 0% | 0% | 0% | 0% | 0% | No | بغل تراشی خاک | اجرا | زیرگذر | باند شمالی | پیمانکار بغل تراشی 2 | 0.03 | 0.07 |
| 392 | 8.1.1.3.2 | اجرای لایه زهكش (دیوار W3 مسیر زیر گذر باند شمالی) | 2d | 2026-01-02 A | 2026-01-04 A | 391 | 100% |  |  |  | زهکش [377 مترمربع] | 2,544,750 | 2,544,750 | 0% | 0% | 0% | 0% | 0% | 0% | 0% | 0% | No | زهکش | اجرا | زیرگذر | باند شمالی | پیمانکار اجرای زهکش 1 | 0.05 | 0.04 |
| 393 | 8.1.1.3.3 | اجرای آرماتوربندی دیوار (دیوار W3 مسیر زیر گذر باند شمالی) | 3d | 2026-01-05 A | 2026-01-07 A | 392 | 100% |  |  |  | آرماتوربندی دیواره [4897 کیلوگرم] | 2,203,650 | 2,203,650 | 0% | 0% | 0% | 0% | 0% | 0% | 0% | 0% | No | آرماتوربندی | اجرا | زیرگذر | باند شمالی | پیمانکار آرماتوربندی 3 | 0.04 | 0.07 |
| 394 | 8.1.1.3.4 | ساخت قطعات پیش ساخته (دیوار W3 مسیر زیر گذر باند شمالی) | 11d | 2026-04-10 | 2026-04-20 | 435 |  |  | 49d | 0d | ساخت قطعات پیش ساخته نما [367 مترمربع] | 6,018,800 |  | 0% | 0% | 0% | 0% | 0% | 0% | 0% | 1% | No | قطعات پیش ساخته نما | ساخت | زیرگذر | باند شمالی | پیمانکار ساخت و نصب قطعات پیش ساخته 1 | 0.12 | 0.24 |
| 395 | 8.1.1.3.5 | نصب قطعات پیش ساخته (دیوار W3 مسیر زیر گذر باند شمالی) | 5d | 2026-04-21 | 2026-04-25 | 394, 393 |  |  | 233d | 0d | نصب قطعات پیش ساخته نما [392 مترمربع] | 1,411,200 |  | 0% | 0% | 0% | 0% | 0% | 0% | 0% | 0% | No | قطعات پیش ساخته نما | نصب | زیرگذر | باند شمالی | پیمانکار ساخت و نصب قطعات پیش ساخته 1 | 0.03 | 0.11 |
| 396 | 8.1.1.3.6 | بتن ریزی دیوار (دیوار W3 مسیر زیر گذر باند شمالی) | 1d | 2026-04-26 | 2026-04-26 | 395 |  |  | 233d | 0d | بتن ریزی [113 مترمکعب] | 2,486,000 |  | 0% | 0% | 0% | 0% | 0% | 0% | 0% | 0% | No | بتن ریزی | اجرا | زیرگذر | باند شمالی | پیمانکار بتن ریزی 1 | 0.05 | 0.02 |
| 397 | 8.1.1.3.7 | ساخت قرنیز پیش ساخته (دیوار W3 مسیر زیر گذر باند شمالی) | 8d | 2026-04-03 | 2026-04-10 | 438 |  |  | 0d |  | ساخت قرنیز [213 مترطول] | 191,700 |  | 0% | 0% | 0% | 0% | 0% | 0% | 0% | 0% | No | سرشمع و قرنیز | ساخت | زیرگذر | باند شمالی | پیمانکار ساخت و نصب و اجرای سرشمع و قرنیز 1 | 0.00 | 0.18 |
| 398 | 8.1.1.3.8 | اجرای سرشمع ها و قرنیز (دیوار W3 مسیر زیر گذر باند شمالی) | 3d | 2026-04-27 | 2026-04-29 | 397, 396 |  |  | 233d |  | سرشمع و قرنیز [87 مترطول] | 5,467,950 |  | 0% | 0% | 0% | 0% | 0% | 0% | 0% | 0% | No | سرشمع و قرنیز | اجرا | زیرگذر | باند شمالی | پیمانکار ساخت و نصب و اجرای سرشمع و قرنیز 1 | 0.11 | 0.07 |

| ID | WBS | Task | Duration | Start | Finish | Predecessors | Complete | Remaining | Total slack | Free slack | Resources | Cost | Actual cost | 1404.07.07 | 1404.07.14 | 1404.07.21 | 1404.07.28 | 1404.08.05 | 1404.08.12 | 1404.08.19 | 1404.08.26 | معارض | Activity Category | Activity Type | Task Category | Task Sub Category | نام پیمانکار | Text7 | Text8 |
| --- | --- | --- | --- | --- | --- | --- | --- | --- | --- | --- | --- | --- | --- | --- | --- | --- | --- | --- | --- | --- | --- | --- | --- | --- | --- | --- | --- | --- | --- |
| 399 | 8.1.1.4 | **اجرای دیوار W1 مسیر زیر گذر باند شمالی** | 67d | 2026-02-26 | 2026-05-11 |  |  |  | 30d |  |  | 48,470,650 |  | 0% | 0% | 0% | 0% | 0% | 0% | 0% | 0% | No |  |  |  |  |  |  |  |
| 400 | 8.1.1.4.1 | بغل تراشی خاک (دیوار W1 مسیر زیر گذر باند شمالی) | 5d | 2026-02-26 | 2026-03-02 | 246, 391 |  |  | 30d | 0d | بغل تراشی خاک [835 مترمکعب] | 2,922,500 |  | 0% | 0% | 0% | 0% | 0% | 0% | 0% | 0% | No | بغل تراشی خاک | اجرا | زیرگذر | باند شمالی | پیمانکار بغل تراشی 2 | 0.06 | 0.11 |
| 401 | 8.1.1.4.2 | اجرای لایه زهكش (دیوار W1 مسیر زیر گذر باند شمالی) | 4d | 2026-03-03 | 2026-03-06 | 400 |  |  | 30d | 0d | زهکش [813 مترمربع] | 5,487,750 |  | 0% | 0% | 0% | 0% | 0% | 0% | 0% | 0% | No | زهکش | اجرا | زیرگذر | باند شمالی | پیمانکار اجرای زهکش 1 | 0.11 | 0.09 |
| 402 | 8.1.1.4.3 | اجرای آرماتوربندی دیوار (دیوار W1 مسیر زیر گذر باند شمالی) | 5d | 2026-03-07 | 2026-03-12 | 401 |  |  | 30d | 0d | آرماتوربندی دیواره [10495 کیلوگرم] | 4,722,750 |  | 0% | 0% | 0% | 0% | 0% | 0% | 0% | 0% | No | آرماتوربندی | اجرا | زیرگذر | باند شمالی | پیمانکار آرماتوربندی 4 | 0.09 | 0.11 |
| 403 | 8.1.1.4.4 | ساخت قطعات پیش ساخته (دیوار W1 مسیر زیر گذر باند شمالی) | 21d | 2026-04-21 | 2026-05-11 | 394 |  |  | 49d | 0d | ساخت قطعات پیش ساخته نما [803 مترمربع] | 13,169,200 |  | 0% | 0% | 0% | 0% | 0% | 0% | 0% | 1% | No | قطعات پیش ساخته نما | ساخت | زیرگذر | باند شمالی | پیمانکار ساخت و نصب قطعات پیش ساخته 1 | 0.25 | 0.51 |
| 404 | 8.1.1.4.5 | نصب قطعات پیش ساخته (دیوار W1 مسیر زیر گذر باند شمالی) | 10d | 2026-03-13 | 2026-03-27 | 401, 402 |  |  | 30d | 0d | نصب قطعات پیش ساخته نما [828 مترمربع] | 2,980,800 |  | 0% | 0% | 0% | 0% | 0% | 0% | 0% | 0% | No | قطعات پیش ساخته نما | نصب | زیرگذر | باند شمالی | پیمانکار ساخت و نصب قطعات پیش ساخته 1 | 0.06 | 0.22 |
| 405 | 8.1.1.4.6 | بتن ریزی دیوار (دیوار W1 مسیر زیر گذر باند شمالی) | 2d | 2026-03-28 | 2026-03-29 | 404 |  |  | 30d |  | بتن ریزی [244 مترمکعب] | 5,368,000 |  | 0% | 0% | 0% | 0% | 0% | 0% | 0% | 0% | No | بتن ریزی | اجرا | زیرگذر | باند شمالی | پیمانکار بتن ریزی 1 | 0.10 | 0.04 |
| 406 | 8.1.1.4.7 | ساخت قرنیز پیش ساخته (دیوار W1 مسیر زیر گذر باند شمالی) | 20d | 2026-04-11 | 2026-04-30 | 397 |  |  | 0d |  | ساخت قرنیز [341 مترطول] | 306,900 |  | 0% | 0% | 0% | 0% | 0% | 0% | 0% | 0% | No | سرشمع و قرنیز | ساخت | زیرگذر | باند شمالی | پیمانکار ساخت و نصب و اجرای سرشمع و قرنیز 1 | 0.01 | 0.45 |
| 407 | 8.1.1.4.8 | اجرای سرشمع ها و قرنیز (دیوار W1 مسیر زیر گذر باند شمالی) | 6d | 2026-05-01 | 2026-05-06 | 406, 405 |  |  | 0d |  | سرشمع و قرنیز [215 مترطول] | 13,512,750 |  | 0% | 0% | 0% | 0% | 0% | 0% | 0% | 0% | No | سرشمع و قرنیز | اجرا | زیرگذر | باند شمالی | پیمانکار ساخت و نصب و اجرای سرشمع و قرنیز 1 | 0.26 | 0.13 |
| 408 | 8.1.2 | **مسیر زیر گذر باند شمالی** | 160d | 2026-05-07 | 2026-10-15 |  |  |  | 0d |  |  | 318,765,400 |  | 0% | 0% | 0% | 0% | 0% | 0% | 0% | 0% | No |  |  |  |  |  |  |  |
| 409 | 8.1.2.1 | اجرای خاک برداری (مسیر زیر گذر باند شمالی) | 60d | 2026-05-07 | 2026-07-07 | 407 |  |  | 0d |  | خاکبرداری [127562 مترمکعب] | 191,343,000 |  | 70% | 70% | 85% | 88% | 91% | 94% | 97% | 97% | No | خاکبرداری | اجرا | زیرگذر | باند شمالی | پیمانکار خاکبرداری و خاکریزی 3 | 3.68 | 1.45 |
| 410 | 8.1.2.2 | اجرای رگلاژ و بستر سازی (مسیر زیر گذر باند شمالی) | 22d | 2026-07-08 | 2026-07-29 | 409 |  |  | 0d |  | رگلاژ و بسترسازی [28552 مترمربع] | 14,276,000 |  | 0% | 0% | 0% | 0% | 0% | 0% | 0% | 50% | No | رگلاژ و بسترسازی | اجرا | زیرگذر | باند شمالی | پیمانکار رگلاژ و بسترسازی 1 | 0.27 | 0.49 |
| 411 | 8.1.2.3 | اجرای زیر اساس (مسیر زیر گذر باند شمالی) | 16d | 2026-07-30 | 2026-08-14 | 410 |  |  | 0d |  | زیراساس [17824 مترمربع] | 10,694,400 |  | 0% | 0% | 0% | 0% | 0% | 0% | 0% | 0% | No | زیراساس | اجرا | زیرگذر | باند شمالی | پیمانکار آسفالت 1 | 0.21 | 0.36 |
| 412 | 8.1.2.4 | اجرای جدول گذاری و احداث کانال (مسیر زیر گذر باند شمالی) | 40d | 2026-08-13 | 2026-09-21 | 411FS-2d |  |  | 0d |  | جدول و کانال بتنی [2830 مترطول] | 35,375,000 |  | 0% | 0% | 0% | 0% | 0% | 0% | 0% | 10% | No | جدول گذاری و کانال بتنی | اجرا | زیرگذر | باند شمالی | پیمانکار اجرای جدول و کانال بتنی 1 | 0.68 | 0.89 |
| 413 | 8.1.2.5 | اجرای اساس (مسیر زیر گذر باند شمالی) | 16d | 2026-09-22 | 2026-10-07 | 411, 412 |  |  | 0d |  | اساس [17760 مترمربع] | 15,984,000 |  | 0% | 0% | 0% | 0% | 0% | 0% | 0% | 0% | No | اساس | اجرا | زیرگذر | باند شمالی | پیمانکار آسفالت 1 | 0.31 | 0.36 |
| 414 | 8.1.2.6 | اجرای آسفالت (مسیر زیر گذر باند شمالی) | 8d | 2026-10-08 | 2026-10-15 | 413 |  |  | 0d |  | آسفالت [17031 مترمربع] | 51,093,000 |  | 0% | 0% | 0% | 0% | 0% | 0% | 0% | 0% | No | آسفالت | اجرا | زیرگذر | باند شمالی | پیمانکار آسفالت 1 | 0.98 | 0.18 |
| 415 | 8.1.3 | **تکمیل مسیر زیر گذر باند شمالی** | 280d | 2026-02-14 | 2026-11-30 |  |  |  | 0d |  |  | 37,640,500 |  | 0% | 0% | 0% | 0% | 0% | 0% | 0% | 0% | No |  |  |  |  |  |  |  |
| 416 | 8.1.3.1 | احداث پیاده رو (تکمیل مسیر زیر گذر باند شمالی) | 35d | 2026-10-16 | 2026-11-19 | 414 |  |  | 0d |  | پیاده رو [2146 مترمربع] | 11,803,000 |  | 0% | 0% | 0% | 0% | 0% | 0% | 0% | 6% | No | پیاده رو | اجرا | زیرگذر | باند شمالی | پیمانکار پیاده روسازی 1 | 0.23 | 0.78 |
| 417 | 8.1.3.2 | ساخت گارد ریل روی دیوارها (تکمیل مسیر زیر گذر باند شمالی) | 40d | 2026-02-14 | 2026-03-31 | 366 |  |  | 179d | 0d | ساخت گاردریل [1427 مترطول مسیر] | 14,983,500 |  | 0% | 0% | 0% | 0% | 0% | 0% | 0% | 0% | No | گاردریل | ساخت | زیرگذر | باند شمالی | پیمانکار ساخت و نصب گاردریل 1 | 0.29 | 0.89 |
| 418 | 8.1.3.3 | نصب گارد ریل روی دیوارها (تکمیل مسیر زیر گذر باند شمالی) | 20d | 2026-11-10 | 2026-11-29 | 417, 416FS-10d |  |  | 0d |  | نصب گاردریل [1442 مترطول مسیر] | 6,489,000 |  | 0% | 0% | 0% | 0% | 0% | 0% | 0% | 0% | No | گاردریل | نصب | زیرگذر | باند شمالی | پیمانکار ساخت و نصب گاردریل 1 | 0.12 | 0.45 |
| 419 | 8.1.3.4 | اجرای خط کشی مسیر و نصب علایم (تکمیل مسیر زیر گذر باند شمالی) | 10d | 2026-11-21 | 2026-11-30 | 414, 418FS-9d |  |  | 0d |  | رنگ آمیزی مسیر [1455 مترطول مسیر] | 4,365,000 |  | 0% | 0% | 0% | 0% | 0% | 0% | 0% | 0% | No | رنگ آمیزی مسیر | اجرا | زیرگذر | باند شمالی | پیمانکار نصب علائم و رنگ آمیزی 1 | 0.08 | 0.22 |
| 420 | 8.2 | **احداث مسیر زیر گذر باند جنوبی** | 301d | 2025-12-02 A | 2026-10-12 |  | 6% | 283.74d | 69d |  |  | 656,506,400 | 22,257,450 | 0% | 0% | 0% | 0% | 0% | 0% | 0% | 0% | No |  |  |  |  |  |  |  |
| 421 | 8.2.1 | **اجرای دیوار مسیر زیر گذر باند جنوبی** | 186d | 2025-12-02 A | 2026-06-19 |  | 13% | 161.78d | 184d |  |  | 123,849,600 | 22,257,450 | 0% | 0% | 0% | 0% | 0% | 0% | 0% | 0% | No |  |  |  |  |  |  |  |
| 422 | 8.2.1.1 | **اجرای دیوار W8 مسیر زیر گذر باند جنوبی** | 111d | 2025-12-02 A | 2026-04-03 |  | 22% | 86.58d | 259d |  |  | 32,188,300 | 8,746,400 | 0% | 0% | 0% | 0% | 0% | 0% | 0% | 0% | No |  |  |  |  |  |  |  |
| 423 | 8.2.1.1.1 | بغل تراشی خاک (دیوار W8 مسیر زیر گذر باند جنوبی) | 4d | 2025-12-02 A | 2025-12-05 A | 137 | 100% |  |  |  | بغل تراشی خاک [556 مترمکعب] | 1,946,000 | 1,946,000 | 0% | 0% | 0% | 0% | 0% | 0% | 0% | 0% | No | بغل تراشی خاک | اجرا | زیرگذر | باند جنوبی | پیمانکار بغل تراشی 1 | 0.04 | 0.09 |
| 424 | 8.2.1.1.2 | اجرای لایه زهكش (دیوار W8 مسیر زیر گذر باند جنوبی) | 3d | 2025-12-06 A | 2025-12-08 A | 423 | 100% |  |  |  | زهکش [541 مترمربع] | 3,651,750 | 3,651,750 | 0% | 0% | 0% | 0% | 0% | 0% | 0% | 0% | No | زهکش | اجرا | زیرگذر | باند جنوبی | پیمانکار اجرای زهکش 1 | 0.07 | 0.07 |
| 425 | 8.2.1.1.3 | اجرای آرماتوربندی دیوار (دیوار W8 مسیر زیر گذر باند جنوبی) | 4d | 2025-12-09 A | 2025-12-12 A | 424 | 100% |  |  |  | آرماتوربندی دیواره [6997 کیلوگرم] | 3,148,650 | 3,148,650 | 0% | 0% | 0% | 0% | 0% | 0% | 0% | 0% | No | آرماتوربندی | اجرا | زیرگذر | باند جنوبی | پیمانکار آرماتوربندی 1 | 0.06 | 0.09 |
| 426 | 8.2.1.1.4 | ساخت قطعات پیش ساخته (دیوار W8 مسیر زیر گذر باند جنوبی) | 14d | 2026-03-01 | 2026-03-15 | 385 |  |  | 49d | 0d | ساخت قطعات پیش ساخته نما [530 مترمربع] | 8,692,000 |  | 0% | 0% | 0% | 0% | 0% | 0% | 0% | 1% | No | قطعات پیش ساخته نما | ساخت | زیرگذر | باند جنوبی | پیمانکار ساخت و نصب قطعات پیش ساخته 1 | 0.17 | 0.33 |
| 427 | 8.2.1.1.5 | نصب قطعات پیش ساخته (دیوار W8 مسیر زیر گذر باند جنوبی) | 7d | 2026-03-16 | 2026-03-27 | 426, 425 |  |  | 259d | 0d | نصب قطعات پیش ساخته نما [555 مترمربع] | 1,998,000 |  | 0% | 0% | 0% | 0% | 0% | 0% | 0% | 0% | No | قطعات پیش ساخته نما | نصب | زیرگذر | باند جنوبی | پیمانکار ساخت و نصب قطعات پیش ساخته 1 | 0.04 | 0.16 |
| 428 | 8.2.1.1.6 | بتن ریزی دیوار (دیوار W8 مسیر زیر گذر باند جنوبی) | 1d | 2026-03-28 | 2026-03-28 | 427 |  |  | 259d | 0d | بتن ریزی [163 مترمکعب] | 3,586,000 |  | 0% | 0% | 0% | 0% | 0% | 0% | 0% | 0% | No | بتن ریزی | اجرا | زیرگذر | باند جنوبی | پیمانکار بتن ریزی 1 | 0.07 | 0.02 |
| 429 | 8.2.1.1.7 | ساخت قرنیز پیش ساخته (دیوار W8 مسیر زیر گذر باند جنوبی) | 13d | 2026-02-27 | 2026-03-12 | 388 |  |  | 0d |  | ساخت قرنیز [268 مترطول] | 241,200 |  | 0% | 0% | 0% | 0% | 0% | 0% | 0% | 0% | No | سرشمع و قرنیز | ساخت | زیرگذر | باند جنوبی | پیمانکار ساخت و نصب و اجرای سرشمع و قرنیز 1 | 0.00 | 0.29 |
| 430 | 8.2.1.1.8 | اجرای سرشمع ها و قرنیز (دیوار W8 مسیر زیر گذر باند جنوبی) | 4d | 2026-03-29 | 2026-04-03 | 429, 428 |  |  | 259d |  | سرشمع و قرنیز [142 مترطول] | 8,924,700 |  | 0% | 0% | 0% | 0% | 0% | 0% | 0% | 0% | No | سرشمع و قرنیز | اجرا | زیرگذر | باند جنوبی | پیمانکار ساخت و نصب و اجرای سرشمع و قرنیز 1 | 0.17 | 0.09 |

| ID | WBS | Task | Duration | Start | Finish | Predecessors | Complete | Remaining | Total slack | Free slack | Resources | Cost | Actual cost | 1404.07.07 | 1404.07.14 | 1404.07.21 | 1404.07.28 | 1404.08.05 | 1404.08.12 | 1404.08.19 | 1404.08.26 | معارض | Activity Category | Activity Type | Task Category | Task Sub Category | نام پیمانکار | Text7 | Text8 |
| --- | --- | --- | --- | --- | --- | --- | --- | --- | --- | --- | --- | --- | --- | --- | --- | --- | --- | --- | --- | --- | --- | --- | --- | --- | --- | --- | --- | --- | --- |
| 431 | 8.2.1.2 | **اجرای دیوار W6 مسیر زیر گذر باند جنوبی** | 103d | 2025-12-30 A | 2026-04-23 |  | 16% | 86.74d | 239d |  |  | 38,491,500 | 8,859,050 | 0% | 0% | 0% | 0% | 0% | 0% | 0% | 0% | No |  |  |  |  |  |  |  |
| 432 | 8.2.1.2.1 | بغل تراشی خاک (دیوار W6 مسیر زیر گذر باند جنوبی) | 4d | 2025-12-30 A | 2026-01-02 A | 147, 154, 423 | 100% |  |  |  | بغل تراشی خاک [685 مترمکعب] | 2,397,500 | 2,397,500 | 0% | 0% | 0% | 0% | 0% | 0% | 0% | 0% | No | بغل تراشی خاک | اجرا | زیرگذر | باند جنوبی | پیمانکار بغل تراشی 1 | 0.05 | 0.09 |
| 433 | 8.2.1.2.2 | اجرای لایه زهكش (دیوار W6 مسیر زیر گذر باند جنوبی) | 3d | 2026-01-04 A | 2026-01-06 A | 432 | 100% |  |  |  | زهکش [669 مترمربع] | 4,515,750 | 4,515,750 | 0% | 0% | 0% | 0% | 0% | 0% | 0% | 0% | No | زهکش | اجرا | زیرگذر | باند جنوبی | پیمانکار اجرای زهکش 1 | 0.09 | 0.07 |
| 434 | 8.2.1.2.3 | اجرای آرماتوربندی دیوار (دیوار W6 مسیر زیر گذر باند جنوبی) | 4d | 2026-01-07 A | 2026-01-10 | 433 | 50% | 2d | 317d | 78d | آرماتوربندی دیواره [8648 کیلوگرم] | 3,891,600 | 1,945,800 | 0% | 0% | 0% | 0% | 0% | 0% | 0% | 0% | No | آرماتوربندی | اجرا | زیرگذر | باند جنوبی | پیمانکار آرماتوربندی 2 | 0.07 | 0.09 |
| 435 | 8.2.1.2.4 | ساخت قطعات پیش ساخته (دیوار W6 مسیر زیر گذر باند جنوبی) | 18d | 2026-03-16 | 2026-04-09 | 426 |  |  | 49d | 0d | ساخت قطعات پیش ساخته نما [659 مترمربع] | 10,807,600 |  | 0% | 0% | 0% | 0% | 0% | 0% | 0% | 1% | No | قطعات پیش ساخته نما | ساخت | زیرگذر | باند جنوبی | پیمانکار ساخت و نصب قطعات پیش ساخته 1 | 0.21 | 0.42 |
| 436 | 8.2.1.2.5 | نصب قطعات پیش ساخته (دیوار W6 مسیر زیر گذر باند جنوبی) | 8d | 2026-04-10 | 2026-04-17 | 435, 434 |  |  | 239d | 0d | نصب قطعات پیش ساخته نما [684 مترمربع] | 2,462,400 |  | 0% | 0% | 0% | 0% | 0% | 0% | 0% | 0% | No | قطعات پیش ساخته نما | نصب | زیرگذر | باند جنوبی | پیمانکار ساخت و نصب قطعات پیش ساخته 1 | 0.05 | 0.18 |
| 437 | 8.2.1.2.6 | بتن ریزی دیوار (دیوار W6 مسیر زیر گذر باند جنوبی) | 2d | 2026-04-18 | 2026-04-19 | 436 |  |  | 239d | 0d | بتن ریزی [201 مترمکعب] | 4,422,000 |  | 0% | 0% | 0% | 0% | 0% | 0% | 0% | 0% | No | بتن ریزی | اجرا | زیرگذر | باند جنوبی | پیمانکار بتن ریزی 1 | 0.09 | 0.04 |
| 438 | 8.2.1.2.7 | ساخت قرنیز پیش ساخته (دیوار W6 مسیر زیر گذر باند جنوبی) | 14d | 2026-03-13 | 2026-03-31 | 429 |  |  | 0d |  | ساخت قرنیز [281 مترطول] | 252,900 |  | 0% | 0% | 0% | 0% | 0% | 0% | 0% | 0% | No | سرشمع و قرنیز | ساخت | زیرگذر | باند جنوبی | پیمانکار ساخت و نصب و اجرای سرشمع و قرنیز 1 | 0.00 | 0.31 |
| 439 | 8.2.1.2.8 | اجرای سرشمع ها و قرنیز (دیوار W6 مسیر زیر گذر باند جنوبی) | 4d | 2026-04-20 | 2026-04-23 | 438, 437 |  |  | 239d |  | سرشمع و قرنیز [155 مترطول] | 9,741,750 |  | 0% | 0% | 0% | 0% | 0% | 0% | 0% | 0% | No | سرشمع و قرنیز | اجرا | زیرگذر | باند جنوبی | پیمانکار ساخت و نصب و اجرای سرشمع و قرنیز 1 | 0.19 | 0.09 |
| 440 | 8.2.1.3 | **اجرای دیوار W4 مسیر زیر گذر باند جنوبی** | 140d | 2026-01-04 A | 2026-06-03 |  | 12% | 122.93d | 198d |  |  | 25,691,550 | 4,652,000 | 0% | 0% | 0% | 0% | 0% | 0% | 0% | 0% | No |  |  |  |  |  |  |  |
| 441 | 8.2.1.3.1 | بغل تراشی خاک (دیوار W4 مسیر زیر گذر باند جنوبی) | 3d | 2026-01-04 A | 2026-01-06 A | 147, 154, 432 | 100% |  |  |  | بغل تراشی خاک [469 مترمکعب] | 1,641,500 | 1,641,500 | 0% | 0% | 0% | 0% | 0% | 0% | 0% | 0% | No | بغل تراشی خاک | اجرا | زیرگذر | باند جنوبی | پیمانکار بغل تراشی 1 | 0.03 | 0.07 |
| 442 | 8.2.1.3.2 | اجرای لایه زهكش (دیوار W4 مسیر زیر گذر باند جنوبی) | 2d | 2026-01-07 A | 2026-01-08 A | 441 | 100% |  |  |  | زهکش [446 مترمربع] | 3,010,500 | 3,010,500 | 0% | 0% | 0% | 0% | 0% | 0% | 0% | 0% | No | زهکش | اجرا | زیرگذر | باند جنوبی | پیمانکار اجرای زهکش 1 | 0.06 | 0.04 |
| 443 | 8.2.1.3.3 | اجرای آرماتوربندی دیوار (دیوار W4 مسیر زیر گذر باند جنوبی) | 3d | 2026-01-09 | 2026-01-11 | 442 |  |  | 320d | 122d | آرماتوربندی دیواره [5780 کیلوگرم] | 2,601,000 |  | 0% | 0% | 0% | 0% | 0% | 0% | 0% | 0% | No | آرماتوربندی | اجرا | زیرگذر | باند جنوبی | پیمانکار آرماتوربندی 3 | 0.05 | 0.07 |
| 444 | 8.2.1.3.4 | ساخت قطعات پیش ساخته (دیوار W4 مسیر زیر گذر باند جنوبی) | 13d | 2026-05-12 | 2026-05-24 | 403 |  |  | 49d | 0d | ساخت قطعات پیش ساخته نما [436 مترمربع] | 7,150,400 |  | 0% | 0% | 0% | 0% | 0% | 0% | 0% | 1% | No | قطعات پیش ساخته نما | ساخت | زیرگذر | باند جنوبی | پیمانکار ساخت و نصب قطعات پیش ساخته 1 | 0.14 | 0.29 |
| 445 | 8.2.1.3.5 | نصب قطعات پیش ساخته (دیوار W4 مسیر زیر گذر باند جنوبی) | 6d | 2026-05-25 | 2026-05-30 | 444, 443 |  |  | 198d | 0d | نصب قطعات پیش ساخته نما [461 مترمربع] | 1,659,600 |  | 0% | 0% | 0% | 0% | 0% | 0% | 0% | 0% | No | قطعات پیش ساخته نما | نصب | زیرگذر | باند جنوبی | پیمانکار ساخت و نصب قطعات پیش ساخته 1 | 0.03 | 0.13 |
| 446 | 8.2.1.3.6 | بتن ریزی دیوار (دیوار W4 مسیر زیر گذر باند جنوبی) | 1d | 2026-05-31 | 2026-05-31 | 445 |  |  | 198d | 0d | بتن ریزی [134 مترمکعب] | 2,948,000 |  | 0% | 0% | 0% | 0% | 0% | 0% | 0% | 0% | No | بتن ریزی | اجرا | زیرگذر | باند جنوبی | پیمانکار بتن ریزی 1 | 0.06 | 0.02 |
| 447 | 8.2.1.3.7 | ساخت قرنیز پیش ساخته (دیوار W4 مسیر زیر گذر باند جنوبی) | 10d | 2026-05-01 | 2026-05-10 | 406 |  |  | 206d | 0d | ساخت قرنیز [230 مترطول] | 207,000 |  | 0% | 0% | 0% | 0% | 0% | 0% | 0% | 0% | No | سرشمع و قرنیز | ساخت | زیرگذر | باند جنوبی | پیمانکار ساخت و نصب و اجرای سرشمع و قرنیز 1 | 0.00 | 0.22 |
| 448 | 8.2.1.3.8 | اجرای سرشمع ها و قرنیز (دیوار W4 مسیر زیر گذر باند جنوبی) | 3d | 2026-06-01 | 2026-06-03 | 447, 446 |  |  | 198d |  | سرشمع و قرنیز [103 مترطول] | 6,473,550 |  | 0% | 0% | 0% | 0% | 0% | 0% | 0% | 0% | No | سرشمع و قرنیز | اجرا | زیرگذر | باند جنوبی | پیمانکار ساخت و نصب و اجرای سرشمع و قرنیز 1 | 0.12 | 0.07 |
| 449 | 8.2.1.4 | **اجرای دیوار W2 مسیر زیر گذر باند جنوبی** | 100d | 2026-03-02 | 2026-06-19 |  |  |  | 125d |  |  | 27,478,250 |  | 0% | 0% | 0% | 0% | 0% | 0% | 0% | 0% | No |  |  |  |  |  |  |  |
| 450 | 8.2.1.4.1 | بغل تراشی خاک (دیوار W2 مسیر زیر گذر باند جنوبی) | 3d | 2026-03-02 | 2026-03-04 | 285, 441 |  |  | 130d | 0d | بغل تراشی خاک [459 مترمکعب] | 1,606,500 |  | 0% | 0% | 0% | 0% | 0% | 0% | 0% | 0% | No | بغل تراشی خاک | اجرا | زیرگذر | باند جنوبی | پیمانکار بغل تراشی 1 | 0.03 | 0.07 |
| 451 | 8.2.1.4.2 | اجرای لایه زهكش (دیوار W2 مسیر زیر گذر باند جنوبی) | 2d | 2026-03-05 | 2026-03-06 | 450 |  |  | 130d | 0d | زهکش [444 مترمربع] | 2,997,000 |  | 0% | 0% | 0% | 0% | 0% | 0% | 0% | 0% | No | زهکش | اجرا | زیرگذر | باند جنوبی | پیمانکار اجرای زهکش 1 | 0.06 | 0.04 |
| 452 | 8.2.1.4.3 | اجرای آرماتوربندی دیوار (دیوار W2 مسیر زیر گذر باند جنوبی) | 3d | 2026-03-07 | 2026-03-09 | 451 |  |  | 130d | 81d | آرماتوربندی دیواره [5748 کیلوگرم] | 2,586,600 |  | 0% | 0% | 0% | 0% | 0% | 0% | 0% | 0% | No | آرماتوربندی | اجرا | زیرگذر | باند جنوبی | پیمانکار آرماتوربندی 4 | 0.05 | 0.07 |
| 453 | 8.2.1.4.4 | ساخت قطعات پیش ساخته (دیوار W2 مسیر زیر گذر باند جنوبی) | 13d | 2026-05-25 | 2026-06-08 | 444 |  |  | 49d | 0d | ساخت قطعات پیش ساخته نما [434 مترمربع] | 7,117,600 |  | 0% | 0% | 0% | 0% | 0% | 0% | 0% | 1% | No | قطعات پیش ساخته نما | ساخت | زیرگذر | باند جنوبی | پیمانکار ساخت و نصب قطعات پیش ساخته 1 | 0.14 | 0.29 |
| 454 | 8.2.1.4.5 | نصب قطعات پیش ساخته (دیوار W2 مسیر زیر گذر باند جنوبی) | 6d | 2026-06-09 | 2026-06-14 | 453, 452 |  |  | 49d | 0d | نصب قطعات پیش ساخته نما [459 مترمربع] | 1,652,400 |  | 0% | 0% | 0% | 0% | 0% | 0% | 0% | 0% | No | قطعات پیش ساخته نما | نصب | زیرگذر | باند جنوبی | پیمانکار ساخت و نصب قطعات پیش ساخته 1 | 0.03 | 0.13 |
| 455 | 8.2.1.4.6 | بتن ریزی دیوار (دیوار W2 مسیر زیر گذر باند جنوبی) | 1d | 2026-06-15 | 2026-06-15 | 454 |  |  | 49d | 0d | بتن ریزی [133 مترمکعب] | 2,926,000 |  | 0% | 0% | 0% | 0% | 0% | 0% | 0% | 0% | No | بتن ریزی | اجرا | زیرگذر | باند جنوبی | پیمانکار بتن ریزی 1 | 0.06 | 0.02 |
| 456 | 8.2.1.4.7 | ساخت قرنیز پیش ساخته (دیوار W2 مسیر زیر گذر باند جنوبی) | 12d | 2026-05-11 | 2026-05-22 | 447 |  |  | 206d | 22d | ساخت قرنیز [259 مترطول] | 233,100 |  | 0% | 0% | 0% | 0% | 0% | 0% | 0% | 0% | No | سرشمع و قرنیز | ساخت | زیرگذر | باند جنوبی | پیمانکار ساخت و نصب و اجرای سرشمع و قرنیز 1 | 0.00 | 0.27 |
| 457 | 8.2.1.4.8 | اجرای سرشمع ها و قرنیز (دیوار W2 مسیر زیر گذر باند جنوبی) | 4d | 2026-06-16 | 2026-06-19 | 456, 455 |  |  | 184d |  | سرشمع و قرنیز [133 مترطول] | 8,359,050 |  | 0% | 0% | 0% | 0% | 0% | 0% | 0% | 0% | No | سرشمع و قرنیز | اجرا | زیرگذر | باند جنوبی | پیمانکار ساخت و نصب و اجرای سرشمع و قرنیز 1 | 0.16 | 0.09 |

| ID | WBS | Task | Duration | Start | Finish | Predecessors | Total slack | Free slack | Resources | Cost | 1404.07.07 | 1404.07.14 | 1404.07.21 | 1404.07.28 | 1404.08.05 | 1404.08.12 | 1404.08.19 | 1404.08.26 | معارض | Activity Category | Activity Type | Task Category | Task Sub Category | نام پیمانکار | Text7 | Text8 |
| --- | --- | --- | --- | --- | --- | --- | --- | --- | --- | --- | --- | --- | --- | --- | --- | --- | --- | --- | --- | --- | --- | --- | --- | --- | --- | --- |
| 458 | 8.2.2 | **مسیر زیر گذر باند جنوبی** | 137d | 2026-04-15 | 2026-08-31 |  | 49d |  |  | 495,016,300 | 0% | 0% | 0% | 0% | 0% | 0% | 0% | 0% | No |  |  |  |  |  |  |  |
| 459 | 8.2.2.1 | اجرای خاک برداری (مسیر زیر گذر باند جنوبی) | 60d | 2026-04-15 | 2026-06-15 | 455FS-60d | 49d | 0d | خاکبرداری [127562 مترمکعب] | 191,343,000 | 70% | 70% | 80% | 83% | 88% | 90% | 90% | 95% | No | خاکبرداری | اجرا | زیرگذر | باند جنوبی | پیمانکار خاکبرداری و خاکریزی 3 | 3.68 | 1.45 |
| 460 | 8.2.2.2 | اجرای رگلاژ و بستر سازی (مسیر زیر گذر باند جنوبی) | 22d | 2026-06-16 | 2026-07-07 | 459 | 49d | 0d | رگلاژ و بسترسازی [28552 مترمربع] | 14,276,000 | 0% | 0% | 0% | 0% | 0% | 0% | 0% | 0% | No | رگلاژ و بسترسازی | اجرا | زیرگذر | باند جنوبی | پیمانکار رگلاژ و بسترسازی 1 | 0.27 | 0.49 |
| 461 | 8.2.2.3 | اجرای زیر اساس (مسیر زیر گذر باند جنوبی) | 3d | 2026-07-08 | 2026-07-10 | 460 | 49d | 0d | زیراساس [3013 مترمربع] | 1,807,800 | 0% | 0% | 0% | 0% | 0% | 0% | 0% | 0% | No | زیراساس | اجرا | زیرگذر | باند جنوبی | پیمانکار آسفالت 2 | 0.03 | 0.07 |
| 462 | 8.2.2.4 | اجرای جدول گذاری و احداث کانال (مسیر زیر گذر باند جنوبی) | 30d | 2026-07-09 | 2026-08-07 | 461FS-2d | 49d | 0d | جدول و کانال بتنی [17641 مترطول] | 220,512,500 | 0% | 0% | 0% | 0% | 0% | 0% | 0% | 0% | No | جدول گذاری و کانال بتنی | اجرا | زیرگذر | باند جنوبی | پیمانکار اجرای جدول و کانال بتنی 2 | 4.24 | 0.67 |
| 463 | 8.2.2.5 | اجرای اساس (مسیر زیر گذر باند جنوبی) | 16d | 2026-08-08 | 2026-08-23 | 461, 462 | 49d | 0d | اساس [17760 مترمربع] | 15,984,000 | 0% | 0% | 0% | 0% | 0% | 0% | 0% | 0% | No | اساس | اجرا | زیرگذر | باند جنوبی | پیمانکار آسفالت 2 | 0.31 | 0.36 |
| 464 | 8.2.2.6 | اجرای آسفالت (مسیر زیر گذر باند جنوبی) | 8d | 2026-08-24 | 2026-08-31 | 463 | 49d | 0d | آسفالت [17031 مترمربع] | 51,093,000 | 0% | 0% | 0% | 0% | 0% | 0% | 0% | 0% | No | آسفالت | اجرا | زیرگذر | باند جنوبی | پیمانکار آسفالت 2 | 0.98 | 0.18 |
| 465 | 8.2.3 | **تکمیل مسیر زیر گذر باند جنوبی** | 191d | 2026-04-03 | 2026-10-12 |  | 49d |  |  | 37,640,500 | 0% | 0% | 0% | 0% | 0% | 0% | 0% | 0% | No |  |  |  |  |  |  |  |
| 466 | 8.2.3.1 | احداث پیاده رو (تکمیل مسیر زیر گذر باند جنوبی) | 35d | 2026-08-28 | 2026-10-01 | 462, 464FS-4d | 49d | 0d | پیاده رو [2146 مترمربع] | 11,803,000 | 0% | 0% | 0% | 0% | 0% | 0% | 0% | 0% | No | پیاده رو | اجرا | زیرگذر | باند جنوبی | پیمانکار آرماتوربندی 2 | 0.23 | 0.78 |
| 467 | 8.2.3.2 | ساخت گارد ریل روی دیوارها (تکمیل مسیر زیر گذر باند جنوبی) | 40d | 2026-04-03 | 2026-05-12 | 417 | 179d | 0d | ساخت گاردریل [1427 مترطول مسیر] | 14,983,500 | 0% | 0% | 0% | 0% | 0% | 0% | 0% | 0% | No | گاردریل | ساخت | زیرگذر | باند جنوبی | پیمانکار ساخت و نصب گاردریل 1 | 0.29 | 0.89 |
| 468 | 8.2.3.3 | نصب گارد ریل روی دیوارها (تکمیل مسیر زیر گذر باند جنوبی) | 20d | 2026-09-22 | 2026-10-11 | 467, 466FS-10d | 49d | 0d | نصب گاردریل [1442 مترطول مسیر] | 6,489,000 | 0% | 0% | 0% | 0% | 0% | 0% | 0% | 0% | No | گاردریل | نصب | زیرگذر | باند جنوبی | پیمانکار ساخت و نصب گاردریل 1 | 0.12 | 0.45 |
| 469 | 8.2.3.4 | اجرای خط کشی مسیر و نصب علایم (تکمیل مسیر زیر گذر باند جنوبی) | 10d | 2026-10-03 | 2026-10-12 | 464, 468FS-9d | 49d |  | رنگ آمیزی مسیر [1455 مترطول مسیر] | 4,365,000 | 0% | 0% | 0% | 0% | 0% | 0% | 0% | 0% | No | رنگ آمیزی مسیر | اجرا | زیرگذر | باند جنوبی | پیمانکار نصب علائم و رنگ آمیزی 1 | 0.08 | 0.22 |
| 470 | 8.3 | **اجرای سپتیک جمع آوری آب های سطحی** | 83d | 2026-07-08 | 2026-09-28 |  | 82d |  |  | 65,149,223 | 0% | 0% | 0% | 0% | 0% | 0% | 0% | 0% | No |  |  |  |  |  |  |  |
| 471 | 8.3.1 | اجرای خاک برداری سپتیک جمع آوری آب های سطحی | 2d | 2026-07-08 | 2026-07-09 | 409, 459 | 82d | 0d | خاکبرداری [683 مترمکعب] | 1,024,500 | 0% | 0% | 0% | 0% | 0% | 0% | 0% | 0% | No | خاکبرداری | اجرا | زیرگذر | سپتیک جمع آوری آب های سطحی | پیمانکار خاکبرداری و خاکریزی 3 | 0.02 | 0.04 |
| 472 | 8.3.2 | **اجرای فونداسیون سپتیک جمع آوری آب های سطحی** | 7d | 2026-07-10 | 2026-07-16 |  | 82d |  |  | 2,508,900 | 0% | 0% | 0% | 0% | 0% | 0% | 0% | 0% | No |  |  |  |  |  |  |  |
| 473 | 8.3.2.1 | اجرای آرماتوربندی فونداسیون سپتیک جمع آوری آب های سطحی | 4d | 2026-07-10 | 2026-07-13 | 471 | 82d | 0d | آرماتوربندی [3562 کیلوگرم] | 1,602,900 | 0% | 0% | 0% | 0% | 0% | 0% | 0% | 0% | No | آرماتوربندی | اجرا | زیرگذر | سپتیک جمع آوری آب های سطحی | پیمانکار آرماتوربندی 5 | 0.03 | 0.09 |
| 474 | 8.3.2.2 | اجرای قالب بندی فونداسیون سپتیک جمع آوری آب های سطحی | 2d | 2026-07-14 | 2026-07-15 | 473 | 82d | 0d | قالب بندی [52 مترمربع] | 312,000 | 0% | 0% | 0% | 0% | 0% | 0% | 0% | 0% | No | قالب بندی | اجرا | زیرگذر | سپتیک جمع آوری آب های سطحی | پیمانکار قالب بندی 1 | 0.01 | 0.04 |
| 475 | 8.3.2.3 | بتن ریزی فونداسیون سپتیک جمع آوری آب های سطحی | 1d | 2026-07-16 | 2026-07-16 | 474 | 82d | 0d | بتن ریزی [27 مترمکعب] | 594,000 | 0% | 0% | 0% | 0% | 0% | 0% | 0% | 0% | No | بتن ریزی | اجرا | زیرگذر | سپتیک جمع آوری آب های سطحی | پیمانکار بتن ریزی 1 | 0.01 | 0.02 |
| 476 | 8.3.3 | **اجرای دیوار سپتیک جمع آوری آب های سطحی** | 13d | 2026-07-17 | 2026-07-29 |  | 82d |  |  | 9,144,350 | 0% | 0% | 0% | 0% | 0% | 0% | 0% | 0% | No |  |  |  |  |  |  |  |
| 477 | 8.3.3.1 | اجرای آرماتوربندی دیوار سپتیک جمع آوری آب های سطحی | 7d | 2026-07-17 | 2026-07-23 | 475 | 82d | 0d | آرماتوربندی دیواره [9623 کیلوگرم] | 4,330,350 | 0% | 0% | 0% | 0% | 0% | 0% | 0% | 0% | No | آرماتوربندی | اجرا | زیرگذر | سپتیک جمع آوری آب های سطحی | پیمانکار آرماتوربندی 5 | 0.08 | 0.16 |
| 478 | 8.3.3.2 | اجرای قالب بندی دیوار سپتیک جمع آوری آب های سطحی | 5d | 2026-07-24 | 2026-07-28 | 477 | 82d | 0d | قالب بندی [520 مترمربع] | 3,120,000 | 0% | 0% | 0% | 0% | 0% | 0% | 0% | 0% | No | قالب بندی | اجرا | زیرگذر | سپتیک جمع آوری آب های سطحی | پیمانکار قالب بندی 1 | 0.06 | 0.11 |
| 479 | 8.3.3.3 | بتن ریزی دیوار سپتیک جمع آوری آب های سطحی | 1d | 2026-07-29 | 2026-07-29 | 478 | 82d | 0d | بتن ریزی [77 مترمکعب] | 1,694,000 | 0% | 0% | 0% | 0% | 0% | 0% | 0% | 0% | No | بتن ریزی | اجرا | زیرگذر | سپتیک جمع آوری آب های سطحی | پیمانکار بتن ریزی 1 | 0.03 | 0.02 |
| 480 | 8.3.4 | **اجرای سقف سپتیک جمع آوری آب های سطحی** | 26d | 2026-07-30 | 2026-08-24 |  | 82d |  |  | 4,201,300 | 0% | 0% | 0% | 0% | 0% | 0% | 0% | 0% | No |  |  |  |  |  |  |  |
| 481 | 8.3.4.1 | اجرای کفراژ سقف سپتیک جمع آوری آب های سطحی | 5d | 2026-07-30 | 2026-08-03 | 479 | 82d | 0d | داربست بندی [799 مترمکعب] | 399,500 | 0% | 0% | 0% | 0% | 0% | 0% | 0% | 0% | No | داربست بندی | اجرا | زیرگذر | سپتیک جمع آوری آب های سطحی | پیمانکار داربست بندی 1 | 0.01 | 0.11 |
| 482 | 8.3.4.2 | اجرای قالب بندی سقف سپتیک جمع آوری آب های سطحی | 10d | 2026-08-04 | 2026-08-13 | 481 | 82d | 0d | قالب بندی [161 مترمربع] | 966,000 | 0% | 0% | 0% | 0% | 0% | 0% | 0% | 0% | No | قالب بندی | اجرا | زیرگذر | سپتیک جمع آوری آب های سطحی | پیمانکار قالب بندی 1 | 0.02 | 0.22 |
| 483 | 8.3.4.3 | اجرای آرماتوربندی سقف سپتیک جمع آوری آب های سطحی | 10d | 2026-08-14 | 2026-08-23 | 482 | 82d | 0d | آرماتوربندی [4444 کیلوگرم] | 1,999,800 | 0% | 0% | 0% | 0% | 0% | 0% | 0% | 0% | No | آرماتوربندی | اجرا | زیرگذر | سپتیک جمع آوری آب های سطحی | پیمانکار آرماتوربندی 5 | 0.04 | 0.22 |
| 484 | 8.3.4.4 | بتن ریزی سقف سپتیک جمع آوری آب های سطحی | 1d | 2026-08-24 | 2026-08-24 | 483 | 82d | 0d | بتن ریزی [38 مترمکعب] | 836,000 | 0% | 0% | 0% | 0% | 0% | 0% | 0% | 0% | No | بتن ریزی | اجرا | زیرگذر | سپتیک جمع آوری آب های سطحی | پیمانکار بتن ریزی 1 | 0.02 | 0.02 |

| ID | WBS | Task | Duration | Start | Finish | Predecessors | Complete | Remaining | Total slack | Free slack | Resources | Cost | Actual cost | 1404.07.07 | 1404.07.14 | 1404.07.21 | 1404.07.28 | 1404.08.05 | 1404.08.12 | 1404.08.19 | 1404.08.26 | معارض | Activity Category | Activity Type | Task Category | Task Sub Category | نام پیمانکار | Text7 | Text8 |
| --- | --- | --- | --- | --- | --- | --- | --- | --- | --- | --- | --- | --- | --- | --- | --- | --- | --- | --- | --- | --- | --- | --- | --- | --- | --- | --- | --- | --- | --- |
| 485 | 8.3.5 | **اجرای تاسیسات سپتیک جمع آوری آب های سطحی** | 35d | 2026-08-25 | 2026-09-28 |  |  |  | 82d |  |  | 48,270,173 |  | 0% | 0% | 0% | 0% | 0% | 0% | 0% | 0% | No |  |  |  |  |  |  |  |
| 486 | 8.3.5.1 | تهیه و ساخت تاسیسات برقی سپتیک جمع آوری آب های سطحی | 20d | 2026-08-25 | 2026-09-13 | 484 |  |  | 82d | 0d | تاسیسات برقی سپتیک [1 مقطوع] | 37,817,699.25 |  | 0% | 0% | 0% | 0% | 0% | 0% | 0% | 0% | No | تاسیسات برقی | تهیه و ساخت | زیرگذر | سپتیک جمع آوری آب های سطحی | پیمانکار تاسیسات 1 | 0.73 | 0.45 |
| 487 | 8.3.5.2 | تهیه و ساخت تاسیسات مکانیکی سپتیک جمع آوری آب های سطحی | 20d | 2026-08-30 | 2026-09-18 | 486FS-15d |  |  | 82d | 0d | تاسیسات مکانیکی سپتیک [1 مقطوع] | 3,940,033.75 |  | 0% | 0% | 0% | 0% | 0% | 0% | 0% | 0% | No | تاسیسات مکانیکی | تهیه و ساخت | زیرگذر | سپتیک جمع آوری آب های سطحی | پیمانکار تاسیسات 1 | 0.08 | 0.45 |
| 488 | 8.3.5.3 | لوله گذاری خروجی از سپتیک جمع آوری آب های سطحی | 20d | 2026-09-04 | 2026-09-23 | 487FS-15d |  |  | 82d | 0d | لوله گذاری خروجی سپتیک [120 مترطول] | 4,012,440 |  | 0% | 0% | 0% | 0% | 0% | 0% | 0% | 0% | No | لوله گذاری | اجرا | زیرگذر | سپتیک جمع آوری آب های سطحی | پیمانکار تاسیسات 1 | 0.08 | 0.45 |
| 489 | 8.3.5.4 | نصب تاسیسات برقی، نصب پمپ لجن کش و تاسیسات مکانیکی | 20d | 2026-09-09 | 2026-09-28 | 488FS-15d |  |  | 82d |  | نصب پمپ [1 دستگاه] | 2,500,000 |  | 0% | 0% | 0% | 0% | 0% | 0% | 0% | 0% | No | پمپ | نصب | زیرگذر | سپتیک جمع آوری آب های سطحی | پیمانکار تاسیسات 1 | 0.05 | 0.45 |
| 490 | 9 | **احداث پل های B و C و مسیر فخرایی** | 293d | 2025-09-26 A | 2026-07-30 |  | 27% | 214.31d | 143d |  |  | 596,908,217.5 | 124,467,115.83 | 0% | 0% | 0% | 0% | 0% | 0% | 0% | 0% | No |  |  |  |  |  |  |  |
| 491 | 9.1 | **احداث پل B** | 215d | 2025-09-26 A | 2026-05-11 |  | 51% | 105.5d | 220d |  |  | 236,130,429 | 87,908,650.83 | 0% | 0% | 0% | 0% | 0% | 0% | 0% | 0% | No |  |  |  |  |  |  |  |
| 492 | 9.1.1 | **اجرای شمع های بتنی پل B** | 97d | 2025-09-26 A | 2026-01-01 A |  | 100% |  |  |  |  | 80,605,942.5 | 80,605,942.5 | 0% | 0% | 0% | 0% | 0% | 0% | 0% | 0% | No |  |  |  |  |  |  |  |
| 493 | 9.1.1.1 | حفاری شمع ها (پل B) | 20d | 2025-09-26 A | 2025-10-15 A | 6FS-10d | 100% |  |  |  | حفر چاه ماشینی [639 مترطول] | 15,975,000 | 15,975,000 | 0% | 0% | 0% | 0% | 0% | 6% | 27% | 27% | Yes | حفر چاه ماشینی | اجرا | پل |  | پیمانکار حفر ماشینی 1 | 0.31 | 0.45 |
| 494 | 9.1.1.2 | پیش ساخت آرماتور شمع ها (پل B) | 66d | 2025-09-26 A | 2025-12-01 A | 6FS-10d | 100% |  |  |  | آرماتوربندی شمع [108215 کیلوگرم]; Ø12 [9437.04 کیلوگرم]; Ø20 [48656.9 کیلوگرم]; Ø25 [39916.8 کیلوگرم] | 31,652,887.5 | 31,652,887.5 | 0% | 0% | 0% | 0% | 0% | 24% | 24% | 24% | No | آرماتوربندی | پیش ساخت | پل |  | پیمانکار آرماتوربندی 5 | 0.61 | 1.47 |
| 495 | 9.1.1.3 | نصب آرماتور شمع ها (پل B) | 29d | 2025-11-30 A | 2025-12-28 A | 494FS-2d | 100% |  |  |  | نصب آرماتوربندی شمع [108394 کیلوگرم] | 17,072,055 | 17,072,055 | 0% | 0% | 0% | 0% | 0% | 0% | 0% | 0% | No | آرماتوربندی | نصب | پل |  | پیمانکار آرماتوربندی 5 | 0.33 | 0.65 |
| 496 | 9.1.1.4 | بتن ریزی شمع ها (پل B) | 5d | 2025-12-28 A | 2026-01-01 A | 495FS-1d | 100% |  |  |  | بتن ریزی [723 مترمکعب] | 15,906,000 | 15,906,000 | 0% | 0% | 0% | 0% | 0% | 0% | 0% | 0% | No | بتن ریزی | اجرا | پل |  | پیمانکار بتن ریزی 1 | 0.31 | 0.11 |
| 497 | 9.1.2 | **اجرای ستون های بتنی پل B** | 26d | 2026-01-02 A | 2026-01-29 |  | 23% | 20d | 218d |  |  | 11,524,000 | 1,374,000 | 0% | 0% | 0% | 0% | 0% | 0% | 0% | 0% | No |  |  |  |  |  |  |  |
| 498 | 9.1.2.1 | اجرای قالب بندی ستون ها (پل B) | 24d | 2026-01-02 A | 2026-01-27 | 496 | 25% | 18d | 218d | 0d | قالب بندی [916 مترمربع] | 5,496,000 | 1,374,000 | 0% | 0% | 0% | 0% | 0% | 0% | 0% | 0% | No | قالب بندی | اجرا | پل |  | پیمانکار قالب بندی 2 | 0.11 | 0.53 |
| 499 | 9.1.2.2 | بتن ریزی ستون ها (پل B) | 2d | 2026-01-28 | 2026-01-29 | 498 |  |  | 218d | 0d | بتن ریزی [274 مترمکعب] | 6,028,000 |  | 0% | 0% | 0% | 0% | 0% | 0% | 0% | 0% | No | بتن ریزی | اجرا | پل |  | پیمانکار بتن ریزی 1 | 0.12 | 0.04 |
| 500 | 9.1.3 | **اجرای کوله پل B** | 14d | 2026-01-30 | 2026-02-14 |  |  |  | 218d |  |  | 8,078,500 |  | 0% | 0% | 0% | 0% | 0% | 0% | 0% | 0% | No |  |  |  |  |  |  |  |
| 501 | 9.1.3.1 | اجرای آرماتوربندی دیوارهای کوله (پل B) | 4d | 2026-01-30 | 2026-02-02 | 499 |  |  | 218d | 0d | آرماتوربندی دیواره [8290 کیلوگرم] | 3,730,500 |  | 0% | 0% | 0% | 0% | 0% | 0% | 0% | 0% | No | آرماتوربندی | اجرا | پل |  | پیمانکار آرماتوربندی 5 | 0.07 | 0.09 |
| 502 | 9.1.3.2 | اجرای قالب بندی دیوارهای کوله (پل B) | 9d | 2026-02-03 | 2026-02-13 | 501 |  |  | 220d | 0d | قالب بندی [347 مترمربع] | 2,082,000 |  | 0% | 0% | 0% | 0% | 0% | 0% | 0% | 0% | No | قالب بندی | اجرا | پل |  | پیمانکار قالب بندی 2 | 0.04 | 0.20 |
| 503 | 9.1.3.3 | بتن ریزی دیوارهای کوله (پل B) | 1d | 2026-02-14 | 2026-02-14 | 502 |  |  | 220d | 0d | بتن ریزی [103 مترمکعب] | 2,266,000 |  | 0% | 0% | 0% | 0% | 0% | 0% | 0% | 0% | No | بتن ریزی | اجرا | پل |  | پیمانکار بتن ریزی 1 | 0.04 | 0.02 |
| 504 | 9.1.4 | **اجرای دیوارهای وزنی پل B** | 16d | 2026-01-02 A | 2026-01-19 |  | 38% | 10d | 143d |  |  | 21,731,000 | 4,311,708.33 | 0% | 0% | 0% | 0% | 0% | 0% | 0% | 0% | No |  |  |  |  |  |  |  |
| 505 | 9.1.4.1 | گود برداری دیوارهای وزنی (پل B) | 1d | 2026-01-02 A | 2026-01-02 A | 496 | 100% |  |  |  | خاکبرداری [1771 مترمکعب] | 2,656,500 | 2,656,500 | 0% | 0% | 0% | 0% | 0% | 0% | 0% | 0% | No | خاکبرداری | اجرا | پل |  | پیمانکار خاکبرداری و خاکریزی 3 | 0.05 | 0.02 |
| 506 | 9.1.4.2 | اجرای فونداسیون دیوارهای وزنی (پل B) | 12d | 2026-01-04 A | 2026-01-15 | 505 | 42% | 7d | 143d | 0d | اجرای فونداسیون [1135 مترمکعب] | 3,972,500 | 1,655,208.33 | 0% | 0% | 0% | 0% | 0% | 0% | 0% | 0% | No | فونداسیون | اجرا | پل |  | پیمانکار آرماتوربندی 5 | 0.08 | 0.27 |
| 507 | 9.1.4.3 | اجرای قالب بندی دیوارها دیوارهای وزنی (پل B) | 2d | 2026-01-16 | 2026-01-18 | 506 |  |  | 143d | 0d | قالب بندی [680 مترمربع] | 4,080,000 |  | 0% | 0% | 0% | 0% | 0% | 0% | 0% | 0% | No | قالب بندی | اجرا | پل |  | پیمانکار قالب بندی 2 | 0.08 | 0.04 |
| 508 | 9.1.4.4 | بتن ریزی دیوارهای وزنی دیوارهای وزنی (پل B) | 1d | 2026-01-19 | 2026-01-19 | 507 |  |  | 143d | 0d | بتن ریزی [501 مترمکعب] | 11,022,000 |  | 0% | 0% | 0% | 0% | 0% | 0% | 0% | 0% | No | بتن ریزی | اجرا | پل |  | پیمانکار بتن ریزی 1 | 0.21 | 0.02 |

| ID | WBS | Task | Duration | Start | Finish | Predecessors | Complete | Remaining | Total slack | Free slack | Resources | Cost | Actual cost | 1404.07.07 | 1404.07.14 | 1404.07.21 | 1404.07.28 | 1404.08.05 | 1404.08.12 | 1404.08.19 | 1404.08.26 | معارض | Activity Category | Activity Type | Task Category | نام پیمانکار | Text7 | Text8 |
| --- | --- | --- | --- | --- | --- | --- | --- | --- | --- | --- | --- | --- | --- | --- | --- | --- | --- | --- | --- | --- | --- | --- | --- | --- | --- | --- | --- | --- |
| 509 | 9.1.5 | **اجرای عرشه پل B** | 56d | 2026-02-15 | 2026-04-19 |  |  |  | 220d |  |  | 98,205,850 |  | 0% | 0% | 0% | 0% | 0% | 0% | 0% | 0% | No |  |  |  |  |  |  |
| 510 | 9.1.5.1 | اجرای کفراژ عرشه پل (پل B) | 3d | 2026-02-15 | 2026-02-17 | 499, 503 |  |  | 220d | 0d | داربست بندی [1223 مترمکعب] | 611,500 |  | 0% | 0% | 0% | 0% | 0% | 0% | 0% | 0% | No | داربست بندی | اجرا | پل | پیمانکار داربست بندی 1 | 0.01 | 0.07 |
| 511 | 9.1.5.2 | اجرای قالب بندی عرشه (پل B) | 26d | 2026-02-18 | 2026-03-16 | 510 |  |  | 220d | 0d | قالب بندی [1011 مترمربع] | 6,066,000 |  | 0% | 0% | 0% | 0% | 0% | 0% | 0% | 0% | No | قالب بندی | اجرا | پل | پیمانکار قالب بندی 2 | 0.12 | 0.58 |
| 512 | 9.1.5.3 | اجرای آرماتوربندی عرشه (پل B) | 27d | 2026-03-12 | 2026-04-14 | 511FS-5d |  |  | 220d | 0d | آرماتوربندی [169223 کیلوگرم] | 76,150,350 |  | 0% | 0% | 0% | 0% | 0% | 0% | 0% | 0% | No | آرماتوربندی | اجرا | پل | پیمانکار آرماتوربندی 5 | 1.46 | 0.60 |
| 513 | 9.1.5.4 | بتن ریزی عرشه (پل B) | 5d | 2026-04-15 | 2026-04-19 | 512 |  |  | 220d | 0d | بتن ریزی [699 مترمکعب] | 15,378,000 |  | 0% | 0% | 0% | 0% | 0% | 0% | 0% | 0% | No | بتن ریزی | اجرا | پل | پیمانکار بتن ریزی 1 | 0.30 | 0.11 |
| 514 | 9.1.6 | **اجرای پیش دال پل B** | 5d | 2026-04-20 | 2026-04-24 |  |  |  | 220d |  |  | 2,976,850 |  | 0% | 0% | 0% | 0% | 0% | 0% | 0% | 0% | No |  |  |  |  |  |  |
| 515 | 9.1.6.1 | اجرای قالب بندی پیش دال (پل B) | 2d | 2026-04-20 | 2026-04-21 | 513 |  |  | 220d | 0d | قالب بندی [74 مترمربع] | 444,000 |  | 0% | 0% | 0% | 0% | 0% | 0% | 0% | 0% | No | قالب بندی | اجرا | پل | پیمانکار قالب بندی 2 | 0.01 | 0.04 |
| 516 | 9.1.6.2 | اجرای آرماتوربندی پیش دال (پل B) | 2d | 2026-04-22 | 2026-04-23 | 515 |  |  | 220d | 0d | آرماتوربندی [4113 کیلوگرم] | 1,850,850 |  | 0% | 0% | 0% | 0% | 0% | 0% | 0% | 0% | No | آرماتوربندی | اجرا | پل | پیمانکار آرماتوربندی 5 | 0.04 | 0.04 |
| 517 | 9.1.6.3 | بتن ریزی پیش دال (پل B) | 1d | 2026-04-24 | 2026-04-24 | 516 |  |  | 220d | 0d | بتن ریزی [31 مترمکعب] | 682,000 |  | 0% | 0% | 0% | 0% | 0% | 0% | 0% | 0% | No | بتن ریزی | اجرا | پل | پیمانکار بتن ریزی 1 | 0.01 | 0.02 |
| 518 | 9.1.7 | **تکمیل پل B** | 130d | 2025-12-21 A | 2026-05-11 |  | 19% | 105.93d | 220d |  |  | 13,008,286.5 | 1,617,000 | 0% | 0% | 0% | 0% | 0% | 0% | 0% | 0% | No |  |  |  |  |  |  |
| 519 | 9.1.7.1 | ساخت قرنیز (پل B) | 3d | 2026-03-17 | 2026-03-19 | 511 |  |  | 249d | 0d | ساخت قرنیز [271 مترطول] | 243,900 |  | 0% | 0% | 0% | 0% | 0% | 0% | 0% | 0% | No | سرشمع و قرنیز | ساخت | پل | پیمانکار ساخت و نصب و اجرای سرشمع و قرنیز 1 | 0.00 | 0.07 |
| 520 | 9.1.7.2 | تکمیل آرماتوربندی (پل B) | 5d | 2026-04-25 | 2026-04-29 | 513, 517 |  |  | 220d | 0d | آرماتوربندی [776.97 کیلوگرم] | 349,636.5 |  | 0% | 0% | 0% | 0% | 0% | 0% | 0% | 0% | No | آرماتوربندی | اجرا | پل | پیمانکار آرماتوربندی 5 | 0.01 | 0.11 |
| 521 | 9.1.7.3 | نصب قرنیز (پل B) | 2d | 2026-03-25 | 2026-03-26 | 519 |  |  | 252d | 32d | سرشمع و قرنیز [145 مترطول] | 9,113,250 |  | 0% | 0% | 0% | 0% | 0% | 0% | 0% | 0% | No | سرشمع و قرنیز | نصب | پل | پیمانکار ساخت و نصب و اجرای سرشمع و قرنیز 1 | 0.18 | 0.04 |
| 522 | 9.1.7.4 | بتن ریزی (پل B) | 2d | 2026-04-30 | 2026-05-01 | 521, 520 |  |  | 220d | 0d | بتن ریزی [42 مترمکعب] | 924,000 |  | 0% | 0% | 0% | 0% | 0% | 0% | 0% | 0% | No | بتن ریزی | اجرا | پل | پیمانکار بتن ریزی 1 | 0.02 | 0.04 |
| 523 | 9.1.7.5 | ساخت گارد ریل دیوارها و پل (پل B) | 5d | 2025-12-21 A | 2025-12-25 A | 2FS+90d | 100% |  |  |  | ساخت گاردریل [154 مترطول مسیر] | 1,617,000 | 1,617,000 | 0% | 0% | 0% | 0% | 0% | 0% | 0% | 0% | No | گاردریل | ساخت | پل | پیمانکار ساخت و نصب گاردریل 1 | 0.03 | 0.11 |
| 524 | 9.1.7.6 | نصب گارد ریل دیوارها و پل (پل B) | 10d | 2026-05-02 | 2026-05-11 | 522, 523 |  |  | 220d |  | نصب گاردریل [169 مترطول مسیر] | 760,500 |  | 0% | 0% | 0% | 0% | 0% | 0% | 0% | 0% | No | گاردریل | نصب | پل | پیمانکار ساخت و نصب گاردریل 1 | 0.01 | 0.22 |
| 525 | 9.2 | **احداث پل C** | 258d | 2025-10-16 A | 2026-07-15 |  | 23% | 197.86d | 158d |  |  | 239,032,162.5 | 36,558,465 | 0% | 0% | 0% | 0% | 0% | 0% | 0% | 0% | No |  |  |  |  |  |  |
| 526 | 9.2.1 | **اجرای شمع های بتنی پل C** | 142d | 2025-10-16 A | 2026-03-12 |  | 48% | 73.98d | 157d |  |  | 82,821,062.5 | 34,941,465 | 0% | 0% | 0% | 0% | 0% | 0% | 0% | 0% | No |  |  |  |  |  |  |
| 527 | 9.2.1.1 | حفاری شمع ها (پل C) | 20d | 2025-10-16 A | 2025-11-04 A | 493 | 100% |  |  |  | حفر چاه ماشینی [657 مترطول] | 16,425,000 | 16,425,000 | 0% | 0% | 0% | 0% | 0% | 0% | 6% | 6% | Yes | حفر چاه ماشینی | اجرا | پل | پیمانکار حفر ماشینی 1 | 0.32 | 0.45 |
| 528 | 9.2.1.2 | پیش ساخت آرماتور شمع ها (پل C) | 65d | 2025-12-02 A | 2026-02-07 | 494 | 57% | 28d | 157d | 0d | آرماتوربندی شمع [111210 کیلوگرم]; Ø12 [9699.18 کیلوگرم]; Ø20 [50008.5 کیلوگرم]; Ø25 [41025.6 کیلوگرم] | 32,528,925 | 18,516,465 | 0% | 0% | 0% | 0% | 0% | 0% | 0% | 0% | No | آرماتوربندی | پیش ساخت | پل | پیمانکار آرماتوربندی 5 | 0.63 | 1.51 |
| 529 | 9.2.1.3 | نصب آرماتور شمع ها (پل C) | 29d | 2026-02-06 | 2026-03-07 | 528FS-2d |  |  | 157d | 0d | نصب آرماتوربندی شمع [111385 کیلوگرم] | 17,543,137.5 |  | 0% | 0% | 0% | 0% | 0% | 0% | 0% | 0% | No | آرماتوربندی | نصب | پل | پیمانکار آرماتوربندی 5 | 0.34 | 0.65 |
| 530 | 9.2.1.4 | بتن ریزی شمع ها (پل C) | 5d | 2026-03-07 | 2026-03-12 | 529FS-1d |  |  | 157d | 0d | بتن ریزی [742 مترمکعب] | 16,324,000 |  | 0% | 0% | 0% | 0% | 0% | 0% | 0% | 0% | No | بتن ریزی | اجرا | پل | پیمانکار بتن ریزی 1 | 0.31 | 0.11 |
| 531 | 9.2.2 | **اجرای ستون های بتنی پل C** | 26d | 2026-03-13 | 2026-04-14 |  |  |  | 157d |  |  | 11,844,000 |  | 0% | 0% | 0% | 0% | 0% | 0% | 0% | 0% | No |  |  |  |  |  |  |
| 532 | 9.2.2.1 | اجرای قالب بندی ستون ها (پل C) | 24d | 2026-03-13 | 2026-04-12 | 530 |  |  | 157d | 0d | قالب بندی [940 مترمربع] | 5,640,000 |  | 0% | 0% | 0% | 0% | 0% | 0% | 0% | 0% | No | قالب بندی | اجرا | پل | پیمانکار قالب بندی 2 | 0.11 | 0.53 |
| 533 | 9.2.2.2 | بتن ریزی ستون ها (پل C) | 2d | 2026-04-13 | 2026-04-14 | 532 |  |  | 157d | 0d | بتن ریزی [282 مترمکعب] | 6,204,000 |  | 0% | 0% | 0% | 0% | 0% | 0% | 0% | 0% | No | بتن ریزی | اجرا | پل | پیمانکار بتن ریزی 1 | 0.12 | 0.04 |

| ID | WBS | Task | Duration | Start | Finish | Predecessors | Complete | Remaining | Total slack | Free slack | Resources | Cost | Actual cost | 1404.07.07 | 1404.07.14 | 1404.07.21 | 1404.07.28 | 1404.08.05 | 1404.08.12 | 1404.08.19 | 1404.08.26 | معارض | Activity Category | Activity Type | Task Category | نام پیمانکار | Text7 | Text8 |
| --- | --- | --- | --- | --- | --- | --- | --- | --- | --- | --- | --- | --- | --- | --- | --- | --- | --- | --- | --- | --- | --- | --- | --- | --- | --- | --- | --- | --- |
| 534 | 9.2.3 | **اجرای کوله پل C** | 15d | 2026-04-15 | 2026-04-29 |  |  |  | 157d |  |  | 8,447,350 |  | 0% | 0% | 0% | 0% | 0% | 0% | 0% | 0% | No |  |  |  |  |  |  |
| 535 | 9.2.3.1 | اجرای آرماتوربندی دیوارهای کوله (پل C) | 5d | 2026-04-15 | 2026-04-19 | 501, 533 |  |  | 157d | 0d | آرماتوربندی دیواره [9083 کیلوگرم] | 4,087,350 |  | 0% | 0% | 0% | 0% | 0% | 0% | 0% | 0% | No | آرماتوربندی | اجرا | پل | پیمانکار آرماتوربندی 5 | 0.08 | 0.11 |
| 536 | 9.2.3.2 | اجرای قالب بندی دیوارهای کوله (پل C) | 9d | 2026-04-20 | 2026-04-28 | 535 |  |  | 157d | 0d | قالب بندی [349 مترمربع] | 2,094,000 |  | 0% | 0% | 0% | 0% | 0% | 0% | 0% | 0% | No | قالب بندی | اجرا | پل | پیمانکار قالب بندی 2 | 0.04 | 0.20 |
| 537 | 9.2.3.3 | بتن ریزی دیوارهای کوله (پل C) | 1d | 2026-04-29 | 2026-04-29 | 536 |  |  | 157d | 0d | بتن ریزی [103 مترمکعب] | 2,266,000 |  | 0% | 0% | 0% | 0% | 0% | 0% | 0% | 0% | No | بتن ریزی | اجرا | پل | پیمانکار بتن ریزی 1 | 0.04 | 0.02 |
| 538 | 9.2.4 | **اجرای دیوارهای وزنی پل C** | 16d | 2026-03-13 | 2026-04-04 |  |  |  | 258d |  |  | 21,731,000 |  | 0% | 0% | 0% | 0% | 0% | 0% | 0% | 0% | No |  |  |  |  |  |  |
| 539 | 9.2.4.1 | گود برداری دیوارهای وزنی (پل C) | 1d | 2026-03-13 | 2026-03-13 | 530, 505 |  |  | 258d | 0d | خاکبرداری [1771 مترمکعب] | 2,656,500 |  | 0% | 0% | 0% | 0% | 0% | 0% | 0% | 0% | No | خاکبرداری | اجرا | پل | پیمانکار خاکبرداری و خاکریزی 3 | 0.05 | 0.02 |
| 540 | 9.2.4.2 | اجرای فونداسیون دیوارهای وزنی (پل C) | 12d | 2026-03-14 | 2026-03-30 | 539 |  |  | 258d | 0d | اجرای فونداسیون [1135 مترمکعب] | 3,972,500 |  | 0% | 0% | 0% | 0% | 0% | 0% | 0% | 0% | No | فونداسیون | اجرا | پل | پیمانکار آرماتوربندی 5 | 0.08 | 0.27 |
| 541 | 9.2.4.3 | اجرای قالب بندی دیوارها دیوارهای وزنی (پل C) | 2d | 2026-03-31 | 2026-04-03 | 540 |  |  | 258d | 0d | قالب بندی [680 مترمربع] | 4,080,000 |  | 0% | 0% | 0% | 0% | 0% | 0% | 0% | 0% | No | قالب بندی | اجرا | پل | پیمانکار قالب بندی 2 | 0.08 | 0.04 |
| 542 | 9.2.4.4 | بتن ریزی دیوارهای وزنی دیوارهای وزنی (پل C) | 1d | 2026-04-04 | 2026-04-04 | 541 |  |  | 258d |  | بتن ریزی [501 مترمکعب] | 11,022,000 |  | 0% | 0% | 0% | 0% | 0% | 0% | 0% | 0% | No | بتن ریزی | اجرا | پل | پیمانکار بتن ریزی 1 | 0.21 | 0.02 |
| 543 | 9.2.5 | **اجرای عرشه پل C** | 53d | 2026-04-30 | 2026-06-23 |  |  |  | 157d |  |  | 98,205,850 |  | 0% | 0% | 0% | 0% | 0% | 0% | 0% | 0% | No |  |  |  |  |  |  |
| 544 | 9.2.5.1 | اجرای کفراژ عرشه پل (پل C) | 3d | 2026-04-30 | 2026-05-02 | 537, 533 |  |  | 157d | 0d | داربست بندی [1223 مترمکعب] | 611,500 |  | 0% | 0% | 0% | 0% | 0% | 0% | 0% | 0% | No | داربست بندی | اجرا | پل | پیمانکار داربست بندی 1 | 0.01 | 0.07 |
| 545 | 9.2.5.2 | اجرای قالب بندی عرشه (پل C) | 25d | 2026-05-03 | 2026-05-27 | 544 |  |  | 157d | 0d | قالب بندی [1011 مترمربع] | 6,066,000 |  | 0% | 0% | 0% | 0% | 0% | 0% | 0% | 0% | No | قالب بندی | اجرا | پل | پیمانکار قالب بندی 2 | 0.12 | 0.58 |
| 546 | 9.2.5.3 | اجرای آرماتوربندی عرشه (پل C) | 25d | 2026-05-23 | 2026-06-18 | 545FS-5d |  |  | 157d | 0d | آرماتوربندی [169223 کیلوگرم] | 76,150,350 |  | 0% | 0% | 0% | 0% | 0% | 0% | 0% | 0% | No | آرماتوربندی | اجرا | پل | پیمانکار آرماتوربندی 5 | 1.46 | 0.60 |
| 547 | 9.2.5.4 | بتن ریزی عرشه (پل C) | 5d | 2026-06-19 | 2026-06-23 | 546 |  |  | 157d | 0d | بتن ریزی [699 مترمکعب] | 15,378,000 |  | 0% | 0% | 0% | 0% | 0% | 0% | 0% | 0% | No | بتن ریزی | نصب | پل | پیمانکار بتن ریزی 1 | 0.30 | 0.11 |
| 548 | 9.2.6 | **اجرای پیش دال پل C** | 5d | 2026-06-24 | 2026-06-28 |  |  |  | 157d |  |  | 2,976,850 |  | 0% | 0% | 0% | 0% | 0% | 0% | 0% | 0% | No |  |  |  |  |  |  |
| 549 | 9.2.6.1 | اجرای قالب بندی پیش دال (پل C) | 2d | 2026-06-24 | 2026-06-25 | 547 |  |  | 157d | 0d | قالب بندی [74 مترمربع] | 444,000 |  | 0% | 0% | 0% | 0% | 0% | 0% | 0% | 0% | No | قالب بندی | اجرا | پل | پیمانکار قالب بندی 2 | 0.01 | 0.04 |
| 550 | 9.2.6.2 | اجرای آرماتوربندی پیش دال (پل C) | 2d | 2026-06-26 | 2026-06-27 | 549 |  |  | 157d | 0d | آرماتوربندی [4113 کیلوگرم] | 1,850,850 |  | 0% | 0% | 0% | 0% | 0% | 0% | 0% | 0% | No | آرماتوربندی | اجرا | پل | پیمانکار آرماتوربندی 5 | 0.04 | 0.04 |
| 551 | 9.2.6.3 | بتن ریزی پیش دال (پل C) | 1d | 2026-06-28 | 2026-06-28 | 550 |  |  | 157d | 0d | بتن ریزی [31 مترمکعب] | 682,000 |  | 0% | 0% | 0% | 0% | 0% | 0% | 0% | 0% | No | بتن ریزی | اجرا | پل | پیمانکار بتن ریزی 1 | 0.01 | 0.02 |
| 552 | 9.2.7 | **تکمیل پل C** | 188d | 2025-12-26 A | 2026-07-15 |  | 19% | 153.19d | 157d |  |  | 13,006,050 | 1,617,000 | 0% | 0% | 0% | 0% | 0% | 0% | 0% | 0% | No |  |  |  |  |  |  |
| 553 | 9.2.7.1 | ساخت قرنیز (پل C) | 3d | 2026-03-25 | 2026-03-27 | 519 |  |  | 249d | 0d | ساخت قرنیز [271 مترطول] | 243,900 |  | 0% | 0% | 0% | 0% | 0% | 0% | 0% | 0% | No | سرشمع و قرنیز | ساخت | پل | پیمانکار ساخت و نصب و اجرای سرشمع و قرنیز 1 | 0.00 | 0.07 |
| 554 | 9.2.7.2 | تکمیل آرماتوربندی (پل C) | 5d | 2026-06-29 | 2026-07-03 | 547, 551 |  |  | 157d | 0d | آرماتوربندی [772 کیلوگرم] | 347,400 |  | 0% | 0% | 0% | 0% | 0% | 0% | 0% | 0% | No | آرماتوربندی | اجرا | پل | پیمانکار آرماتوربندی 5 | 0.01 | 0.11 |
| 555 | 9.2.7.3 | نصب قرنیز (پل C) | 2d | 2026-03-28 | 2026-03-29 | 553 |  |  | 249d | 92d | سرشمع و قرنیز [145 مترطول] | 9,113,250 |  | 0% | 0% | 0% | 0% | 0% | 0% | 0% | 0% | No | سرشمع و قرنیز | نصب | پل | پیمانکار ساخت و نصب و اجرای سرشمع و قرنیز 1 | 0.18 | 0.04 |
| 556 | 9.2.7.4 | بتن ریزی (پل C) | 2d | 2026-07-04 | 2026-07-05 | 555, 554 |  |  | 157d | 0d | بتن ریزی [42 مترمکعب] | 924,000 |  | 0% | 0% | 0% | 0% | 0% | 0% | 0% | 0% | No | بتن ریزی | اجرا | پل | پیمانکار بتن ریزی 1 | 0.02 | 0.04 |
| 557 | 9.2.7.5 | ساخت گارد ریل دیوارها و پل (پل C) | 5d | 2025-12-26 A | 2025-12-30 A | 523 | 100% |  |  |  | ساخت گاردریل [154 مترطول مسیر] | 1,617,000 | 1,617,000 | 0% | 0% | 0% | 0% | 0% | 0% | 0% | 0% | No | گاردریل | ساخت | پل | پیمانکار ساخت و نصب گاردریل 1 | 0.03 | 0.11 |
| 558 | 9.2.7.6 | نصب گارد ریل دیوارها و پل (پل C) | 10d | 2026-07-06 | 2026-07-15 | 557, 556 |  |  | 157d |  | نصب گاردریل [169 مترطول مسیر] | 760,500 |  | 0% | 0% | 0% | 0% | 0% | 0% | 0% | 0% | No | گاردریل | نصب | پل | پیمانکار ساخت و نصب گاردریل 1 | 0.01 | 0.22 |

| ID | WBS | Task | Duration | Start | Finish | Predecessors | Complete | Remaining | Total slack | Free slack | Resources | Cost | Actual cost | 1404.07.07 | 1404.07.14 | 1404.07.21 | 1404.07.28 | 1404.08.05 | 1404.08.12 | 1404.08.19 | 1404.08.26 | معارض | Activity Category | Activity Type | Task Category | Task Sub Category | نام پیمانکار | Text7 | Text8 |
| --- | --- | --- | --- | --- | --- | --- | --- | --- | --- | --- | --- | --- | --- | --- | --- | --- | --- | --- | --- | --- | --- | --- | --- | --- | --- | --- | --- | --- | --- |
| 559 | 9.3 | **مسیر فخرایی** | 180d | 2026-01-20 | 2026-07-30 |  |  |  | 143d |  |  | 121,745,626 |  | 0% | 0% | 0% | 0% | 0% | 0% | 0% | 0% | No |  |  |  |  |  |  |  |
| 560 | 9.3.1 | **احداث مسیر به فخرایی** | 159d | 2026-01-20 | 2026-07-09 |  |  |  | 143d |  |  | 85,049,900 |  | 0% | 0% | 0% | 0% | 0% | 0% | 0% | 0% | No |  |  |  |  |  |  |  |
| 561 | 9.3.1.1 | اجرای خاک برداری (مسیر فخرایی) | 10d | 2026-01-20 | 2026-01-29 | 508 |  |  | 143d | 0d | خاکبرداری [19160 مترمکعب] | 28,740,000 |  | 0% | 0% | 0% | 0% | 0% | 0% | 0% | 0% | Yes | خاکبرداری | اجرا | مسیر | فخرایی | پیمانکار خاکبرداری و خاکریزی 3 | 0.55 | 0.22 |
| 562 | 9.3.1.2 | اجرای رگلاژ و بستر سازی (مسیر فخرایی) | 8d | 2026-01-30 | 2026-02-07 | 561 |  |  | 143d | 0d | رگلاژ و بسترسازی [10149 مترمربع] | 5,074,500 |  | 0% | 0% | 0% | 0% | 0% | 0% | 0% | 0% | No | رگلاژ و بسترسازی | اجرا | مسیر | فخرایی | پیمانکار خاکبرداری و خاکریزی 3 | 0.10 | 0.18 |
| 563 | 9.3.1.3 | اجرای زیر اساس (مسیر فخرایی) | 7d | 2026-02-05 | 2026-02-12 | 562FS-3d |  |  | 143d | 0d | زیراساس [7300 مترمربع] | 4,380,000 |  | 0% | 0% | 0% | 0% | 0% | 0% | 0% | 0% | No | زیراساس | اجرا | مسیر | فخرایی | پیمانکار آسفالت 3 | 0.08 | 0.16 |
| 564 | 9.3.1.4 | اجرای جدول گذاری و احداث کانال بتنی (مسیر فخرایی) | 55d | 2026-02-10 | 2026-04-14 | 563FS-2d |  |  | 143d | 0d | جدول و کانال بتنی [1552 مترطول] | 19,400,000 |  | 0% | 0% | 0% | 0% | 0% | 0% | 0% | 0% | No | جدول گذاری و کانال بتنی | اجرا | مسیر | فخرایی | پیمانکار اجرای جدول و کانال بتنی 1 | 0.37 | 1.25 |
| 565 | 9.3.1.5 | اجرای اساس (مسیر فخرایی) | 7d | 2026-04-13 | 2026-04-19 | 563, 564FS-2d |  |  | 234d | 77d | اساس [7236 مترمربع] | 6,512,400 |  | 0% | 0% | 0% | 0% | 0% | 0% | 0% | 0% | No | اساس | اجرا | مسیر | فخرایی | پیمانکار آسفالت 3 | 0.13 | 0.16 |
| 566 | 9.3.1.6 | اجرای آسفالت مسیر فخرایی و پل ها (مسیر فخرایی) | 4d | 2026-07-06 | 2026-07-09 | 565FS-2d, 556, 522 |  |  | 157d | 0d | آسفالت [6981 مترمربع] | 20,943,000 |  | 0% | 0% | 0% | 0% | 0% | 0% | 0% | 0% | No | آسفالت | اجرا | مسیر | فخرایی | پیمانکار آسفالت 3 | 0.40 | 0.09 |
| 567 | 9.3.2 | **تکمیل مسیر به فخرایی** | 105d | 2026-04-15 | 2026-07-30 |  |  |  | 143d |  |  | 36,695,726 |  | 0% | 0% | 0% | 0% | 0% | 0% | 0% | 0% | No |  |  |  |  |  |  |  |
| 568 | 9.3.2.1 | اجرای جداول جدا کننده پیاده رو و دوچرخه (مسیر فخرایی) | 28d | 2026-04-15 | 2026-05-12 | 564 |  |  | 143d | 0d | پیاده رو [792 مترمربع] | 4,356,000 |  | 0% | 0% | 0% | 0% | 0% | 0% | 0% | 0% | No | جدول گذاری و کانال بتنی | اجرا | مسیر | فخرایی | پیمانکار اجرای جدول و کانال بتنی 1 | 0.08 | 0.62 |
| 569 | 9.3.2.2 | اجرای زیرساز مسیر دوچرخه و پیاده رو (مسیر فخرایی) | 40d | 2026-05-10 | 2026-06-20 | 568FS-3d |  |  | 143d | 0d | پیاده رو [2952 مترمربع] | 16,236,000 |  | 0% | 0% | 0% | 0% | 0% | 0% | 0% | 0% | No | پیاده رو | اجرا | مسیر | فخرایی | پیمانکار پیاده روسازی 1 | 0.31 | 0.89 |
| 570 | 9.3.2.3 | اجرای غلاف تاسیساتی (مسیر فخرایی) | 5d | 2026-06-20 | 2026-06-24 | 569FS-1d |  |  | 143d | 0d | غلاف تاسیساتی [85 مترطول] | 327,726 |  | 0% | 0% | 0% | 0% | 0% | 0% | 0% | 0% | No | غلاف تاسیساتی | اجرا | مسیر | فخرایی | پیمانکار اجرای غلاف تاسیساتی 1 | 0.01 | 0.11 |
| 571 | 9.3.2.4 | تکمیل روسازی (مسیر فخرایی) | 35d | 2026-06-25 | 2026-07-29 | 569, 570 |  |  | 143d | 0d | پیاده رو [1564 مترمربع] | 8,602,000 |  | 0% | 0% | 0% | 0% | 0% | 0% | 0% | 0% | No | پیاده رو | اجرا | مسیر | فخرایی | پیمانکار پیاده روسازی 1 | 0.17 | 0.80 |
| 572 | 9.3.2.5 | رنگ آمیزی مسیر دوچرخه (مسیر فخرایی) | 1d | 2026-07-30 | 2026-07-30 | 571 |  |  | 143d |  | رنگ آمیزی مسیر دوچرخه [1186 مترمربع] | 4,744,000 |  | 0% | 0% | 0% | 0% | 0% | 0% | 0% | 0% | No | رنگ آمیزی مسیر | اجرا | مسیر | فخرایی | پیمانکار نصب علائم و رنگ آمیزی 1 | 0.09 | 0.02 |
| 573 | 9.3.2.6 | اجرای خط کشی مسیر و نصب علایم (مسیر فخرایی) | 6d | 2026-07-10 | 2026-07-15 | 566 |  |  | 157d |  | رنگ آمیزی مسیر [810 مترطول مسیر] | 2,430,000 |  | 0% | 0% | 0% | 0% | 0% | 0% | 0% | 0% | No | رنگ آمیزی مسیر | اجرا | مسیر | فخرایی | پیمانکار نصب علائم و رنگ آمیزی 1 | 0.05 | 0.13 |
| 574 | 10 | **میدان در تراز همسطح** | 210d | 2025-10-22 A | 2026-06-01 |  | 82% | 37.14d | 200d |  |  | 180,136,050 | 164,795,550 | 0% | 0% | 0% | 0% | 0% | 0% | 0% | 0% | No |  |  |  |  |  |  |  |
| 575 | 10.1 | **ضلع شمالی میدان در تراز همسطح** | 201d | 2025-10-31 A | 2026-06-01 |  | 82% | 35.31d | 200d |  |  | 99,170,850 | 90,673,350 | 0% | 0% | 0% | 0% | 0% | 0% | 0% | 0% | No |  |  |  |  |  |  |  |
| 576 | 10.1.1 | عملیات روتبال و قطاعی ضلع شمالی میدان در تراز همسطح | 10d | 2025-10-31 A | 2025-11-09 A | 593 | 100% |  |  |  | روتبال و قطاعی [650 اصله] | 10,725,000 | 10,725,000 | 15% | 12% | 12% | 15% | 25% | 70% | 85% | 85% | No | روتبال و قطاعی | اجرا | میدان در تراز همسطح | ضلع شمالی | پیمانکار روتبال 1 | 0.21 | 0.22 |
| 577 | 10.1.2 | جمع آوری کانال و گارد ریل موجود ضلع شمالی میدان در تراز همسطح | 3d | 2025-11-03 A | 2025-11-05 A | 594 | 100% |  |  |  | تخریب [570 مترطول مسیر] | 3,420,000 | 3,420,000 | 0% | 0% | 0% | 0% | 0% | 0% | 0% | 0% | No | تخریب | اجرا | میدان در تراز همسطح | ضلع شمالی | پیمانکار تخزیب و جمع آوری 1 | 0.07 | 0.07 |
| 578 | 10.1.3 | **اجرای شناژ بتنی ضلع شمالی دور میدان در تراز همسطح** | 5d | 2025-11-08 A | 2025-11-12 A |  | 100% |  |  |  |  | 20,491,450 | 20,491,450 | 0% | 0% | 0% | 0% | 0% | 0% | 0% | 0% | No |  |  |  |  |  |  |  |
| 579 | 10.1.3.1 | آرماتوربندی اجرای شناژ بتنی دور ضلع شمالی میدان در تراز همسطح | 5d | 2025-11-08 A | 2025-11-12 A | 596 | 100% |  |  |  | آرماتوربندی [19541 کیلوگرم] | 8,793,450 | 8,793,450 | 0% | 0% | 0% | 0% | 0% | 0% | 0% | 0% | No | آرماتوربندی | اجرا | میدان در تراز همسطح | ضلع شمالی | پیمانکار آرماتوربندی 5 | 0.17 | 0.11 |
| 580 | 10.1.3.2 | قالب بندی اجرای شناژ بتنی دور ضلع شمالی میدان در تراز همسطح | 2d | 2025-11-10 A | 2025-11-11 A | 597 | 100% |  |  |  | قالب بندی [1121 مترمربع] | 6,726,000 | 6,726,000 | 0% | 0% | 0% | 0% | 0% | 0% | 0% | 0% | No | قالب بندی | اجرا | میدان در تراز همسطح | ضلع شمالی | پیمانکار قالب بندی 2 | 0.13 | 0.04 |
| 581 | 10.1.3.3 | بتن ریزی اجرای شناژ بتنی دور ضلع شمالی میدان در تراز همسطح | 1d | 2025-11-11 A | 2025-11-11 A | 598 | 100% |  |  |  | بتن ریزی [226 مترمکعب] | 4,972,000 | 4,972,000 | 0% | 0% | 0% | 0% | 0% | 0% | 0% | 0% | No | بتن ریزی | اجرا | میدان در تراز همسطح | ضلع شمالی | پیمانکار بتن ریزی 1 | 0.10 | 0.02 |
| 582 | 10.1.4 | ساخت گارد ریل ضلع شمالی میدان در تراز همسطح | 10d | 2026-05-23 | 2026-06-01 | 599 |  |  | 200d |  | ساخت گاردریل [562 مترطول مسیر] | 5,901,000 |  | 0% | 0% | 0% | 0% | 0% | 0% | 0% | 0% | No | گاردریل | ساخت | میدان در تراز همسطح | ضلع شمالی | پیمانکار ساخت و نصب گاردریل 1 | 0.11 | 0.22 |
| 583 | 10.1.5 | نصب گارد ریل ضلع شمالی میدان در تراز همسطح | 3d | 2026-05-24 | 2026-05-26 | 600 |  |  | 206d |  | نصب گاردریل [577 مترطول مسیر] | 2,596,500 |  | 0% | 0% | 0% | 0% | 0% | 0% | 0% | 0% | No | گاردریل | نصب | میدان در تراز همسطح | ضلع شمالی | پیمانکار ساخت و نصب گاردریل 1 | 0.05 | 0.07 |
| 584 | 10.1.6 | اجرای کانال ضلع شمالی میدان در تراز همسطح | 7d | 2025-11-18 A | 2025-11-25 A | 601 | 100% |  |  |  | جدول و کانال بتنی [560 مترطول] | 7,000,000 | 7,000,000 | 0% | 0% | 0% | 0% | 0% | 0% | 0% | 0% | No | جدول گذاری و کانال بتنی | اجرا | میدان در تراز همسطح | ضلع شمالی | پیمانکار اجرای جدول و کانال بتنی 2 | 0.13 | 0.16 |
| 585 | 10.1.7 | احداث پیاده رو ضلع شمالی میدان در تراز همسطح | 7d | 2025-11-30 A | 2025-12-06 A | 603 | 100% |  |  |  | پیاده رو [296 مترمربع] | 1,628,000 | 1,628,000 | 0% | 0% | 0% | 0% | 0% | 0% | 0% | 0% | No | پیاده رو | اجرا | میدان در تراز همسطح | ضلع شمالی | پیمانکار آرماتوربندی 2 | 0.03 | 0.16 |

| ID | WBS | Task | Type | Duration | Start | Finish | Predecessors | Complete | Remaining | Total slack | Free slack | Resources | Cost | Actual cost | 1404.07.07 | 1404.07.14 | 1404.07.21 | 1404.07.28 | 1404.08.05 | 1404.08.12 | 1404.08.19 | 1404.08.26 | معارض | Activity Category | Activity Type | Task Category | Task Sub Category | نام پیمانکار | Text7 | Text8 |
| --- | --- | --- | --- | --- | --- | --- | --- | --- | --- | --- | --- | --- | --- | --- | --- | --- | --- | --- | --- | --- | --- | --- | --- | --- | --- | --- | --- | --- | --- | --- |
| 586 | 10.1.8 | **عملیات تکمیلی ضلع شمالی میدان در تراز همسطح** |  | 26d | 2025-11-06 A | 2025-12-02 A |  | 100% |  |  |  |  | 47,408,900 | 47,408,900 | 0% | 0% | 0% | 0% | 0% | 0% | 0% | 0% | No |  |  |  |  |  |  |  |
| 587 | 10.1.8.1 | عملیات خاکی و بسترسازی ضلع شمالی میدان در تراز همسطح |  | 7d | 2025-11-06 A | 2025-11-12 A | 577 | 100% |  |  |  | رگلاژ و بسترسازی [7945 مترمربع] | 3,972,500 | 3,972,500 | 0% | 0% | 0% | 0% | 0% | 0% | 0% | 0% | No | رگلاژ و بسترسازی | اجرا | میدان در تراز همسطح | ضلع شمالی | پیمانکار خاکبرداری و خاکریزی 3 | 0.08 | 0.16 |
| 588 | 10.1.8.2 | اجرای زیر اساس ضلع شمالی میدان در تراز همسطح |  | 7d | 2025-11-13 A | 2025-11-19 A | 587 | 100% |  |  |  | زیراساس [7906 مترمربع] | 4,743,600 | 4,743,600 | 0% | 0% | 0% | 0% | 0% | 0% | 0% | 0% | No | زیراساس | اجرا | میدان در تراز همسطح | ضلع شمالی | پیمانکار آسفالت 3 | 0.09 | 0.16 |
| 589 | 10.1.8.3 | اجرای اساس ضلع شمالی میدان در تراز همسطح |  | 5d | 2025-11-20 A | 2025-11-25 A | 588 | 100% |  |  |  | اساس [7842 مترمربع] | 7,057,800 | 7,057,800 | 0% | 0% | 0% | 0% | 0% | 0% | 0% | 0% | No | اساس | اجرا | میدان در تراز همسطح | ضلع شمالی | پیمانکار آسفالت 3 | 0.14 | 0.11 |
| 590 | 10.1.8.4 | اجرای آسفالت ضلع شمالی میدان در تراز همسطح |  | 5d | 2025-11-26 A | 2025-11-30 A | 589 | 100% |  |  |  | آسفالت [7752 مترمربع] | 23,256,000 | 23,256,000 | 0% | 0% | 0% | 0% | 0% | 0% | 0% | 0% | No | آسفالت | اجرا | میدان در تراز همسطح | ضلع شمالی | پیمانکار آسفالت 3 | 0.45 | 0.11 |
| 591 | 10.1.8.5 | اجرای خط کشی مسیر و نصب علایم ضلع شمالی میدان در تراز همسطح |  | 2d | 2025-12-01 A | 2025-12-02 A | 590 | 100% |  |  |  | رنگ آمیزی مسیر [2793 مترطول مسیر] | 8,379,000 | 8,379,000 | 0% | 0% | 0% | 0% | 0% | 0% | 0% | 0% | No | رنگ آمیزی مسیر | اجرا | میدان در تراز همسطح | ضلع شمالی | پیمانکار نصب علائم و رنگ آمیزی 1 | 0.16 | 0.04 |
| 592 | 10.2 | **ضلع جنوبی میدان در تراز همسطح** |  | 201d | 2025-10-22 A | 2026-05-23 |  | 82% | 35.79d | 206d |  |  | 80,965,200 | 74,122,200 | 0% | 0% | 0% | 0% | 0% | 0% | 0% | 0% | No |  |  |  |  |  |  |  |
| 593 | 10.2.1 | عملیات روتبال و قطاعی ضلع جنوبی میدان در تراز همسطح |  | 9d | 2025-10-22 A | 2025-10-30 A | 231 | 100% |  |  |  | روتبال و قطاعی [600 اصله] | 9,900,000 | 9,900,000 | 15% | 12% | 12% | 15% | 25% | 70% | 85% | 85% | No | روتبال و قطاعی | اجرا | میدان در تراز همسطح | ضلع جنوبی | پیمانکار روتبال 2 | 0.19 | 0.20 |
| 594 | 10.2.2 | جمع آوری کانال و گارد ریل موجود ضلع جنوبی میدان در تراز همسطح |  | 3d | 2025-10-31 A | 2025-11-02 A | 593 | 100% |  |  |  | تخریب [460 مترطول مسیر] | 2,760,000 | 2,760,000 | 0% | 0% | 0% | 0% | 0% | 0% | 0% | 0% | No | تخریب | اجرا | میدان در تراز همسطح | ضلع جنوبی | پیمانکار تخزیب و جمع آوری 1 | 0.05 | 0.07 |
| 595 | 10.2.3 | **اجرای شناژ بتنی ضلع جنوبی دور میدان در تراز همسطح** |  | 8d | 2025-11-03 A | 2025-11-10 A |  | 100% |  |  |  |  | 16,467,800 | 16,467,800 | 0% | 0% | 0% | 0% | 0% | 0% | 0% | 0% | No |  |  |  |  |  |  |  |
| 596 | 10.2.3.1 | آرماتوربندی اجرای شناژ بتنی دور ضلع جنوبی میدان در تراز همسطح |  | 5d | 2025-11-03 A | 2025-11-07 A | 594 | 100% |  |  |  | آرماتوربندی [15684 کیلوگرم] | 7,057,800 | 7,057,800 | 0% | 0% | 0% | 0% | 0% | 0% | 0% | 0% | No | آرماتوربندی | اجرا | میدان در تراز همسطح | ضلع جنوبی | پیمانکار آرماتوربندی 5 | 0.14 | 0.11 |
| 597 | 10.2.3.2 | قالب بندی اجرای شناژ بتنی دور ضلع جنوبی میدان در تراز همسطح |  | 2d | 2025-11-08 A | 2025-11-09 A | 596 | 100% |  |  |  | قالب بندی [901 مترمربع] | 5,406,000 | 5,406,000 | 0% | 0% | 0% | 0% | 0% | 0% | 0% | 0% | No | قالب بندی | اجرا | میدان در تراز همسطح | ضلع جنوبی | پیمانکار قالب بندی 2 | 0.10 | 0.04 |
| 598 | 10.2.3.3 | بتن ریزی اجرای شناژ بتنی دور ضلع جنوبی میدان در تراز همسطح |  | 1d | 2025-11-10 A | 2025-11-10 A | 597 | 100% |  |  |  | بتن ریزی [182 مترمکعب] | 4,004,000 | 4,004,000 | 0% | 0% | 0% | 0% | 0% | 0% | 0% | 0% | No | بتن ریزی | اجرا | میدان در تراز همسطح | ضلع جنوبی | پیمانکار بتن ریزی 1 | 0.08 | 0.02 |
| 599 | 10.2.4 | ساخت گارد ریل ضلع جنوبی میدان در تراز همسطح |  | 10d | 2026-05-13 | 2026-05-22 | 467 |  |  | 200d | 0d | ساخت گاردریل [452 مترطول مسیر] | 4,746,000 |  | 0% | 0% | 0% | 0% | 0% | 0% | 0% | 0% | No | گاردریل | ساخت | میدان در تراز همسطح | ضلع جنوبی | پیمانکار ساخت و نصب گاردریل 1 | 0.09 | 0.22 |
| 600 | 10.2.5 | نصب گارد ری ضلع جنوبی میدان در تراز همسطح |  | 3d | 2026-05-21 | 2026-05-23 | 599FS-2d |  |  | 206d | 0d | نصب گاردریل [466 مترطول مسیر] | 2,097,000 |  | 0% | 0% | 0% | 0% | 0% | 0% | 0% | 0% | No | گاردریل | نصب | میدان در تراز همسطح | ضلع جنوبی | پیمانکار ساخت و نصب گاردریل 1 | 0.04 | 0.07 |
| 601 | 10.2.6 | اجرای کانال ضلع جنوبی میدان در تراز همسطح |  | 7d | 2025-11-11 A | 2025-11-17 A | 598 | 100% |  |  |  | جدول و کانال بتنی [450 مترطول] | 5,625,000 | 5,625,000 | 0% | 0% | 0% | 0% | 0% | 0% | 0% | 0% | No | جدول گذاری و کانال بتنی | اجرا | میدان در تراز همسطح | ضلع جنوبی | پیمانکار اجرای جدول و کانال بتنی 2 | 0.11 | 0.16 |
| 602 | 10.2.7 | احداث پیاده رو ضلع جنوبی میدان در تراز همسطح |  | 7d | 2025-11-18 A | 2025-11-25 A | 601 | 100% |  |  |  | پیاده رو [241 مترمربع] | 1,325,500 | 1,325,500 | 0% | 0% | 0% | 0% | 0% | 0% | 0% | 0% | No | پیاده رو | اجرا | میدان در تراز همسطح | ضلع جنوبی | پیمانکار آرماتوربندی 2 | 0.03 | 0.16 |
| 603 | 10.2.8 | **عملیات تکمیلی ضلع جنوبی میدان در تراز همسطح** |  | 26d | 2025-11-03 A | 2025-11-29 A |  | 100% |  |  |  |  | 38,043,900 | 38,043,900 | 0% | 0% | 0% | 0% | 0% | 0% | 0% | 0% | No |  |  |  |  |  |  |  |
| 604 | 10.2.8.1 | عملیات خاکی و بسترسازی ضلع جنوبی میدان در تراز همسطح |  | 7d | 2025-11-03 A | 2025-11-09 A | 594 | 100% |  |  |  | رگلاژ و بسترسازی [6402 مترمربع] | 3,201,000 | 3,201,000 | 0% | 0% | 0% | 0% | 0% | 0% | 0% | 0% | No | رگلاژ و بسترسازی | اجرا | میدان در تراز همسطح | ضلع جنوبی | پیمانکار خاکبرداری و خاکریزی 3 | 0.06 | 0.16 |
| 605 | 10.2.8.2 | اجرای زیر اساس ضلع جنوبی میدان در تراز همسطح |  | 7d | 2025-11-10 A | 2025-11-16 A | 604 | 100% |  |  |  | زیراساس [6363 مترمربع] | 3,817,800 | 3,817,800 | 0% | 0% | 0% | 0% | 0% | 0% | 0% | 0% | No | زیراساس | اجرا | میدان در تراز همسطح | ضلع جنوبی | پیمانکار آسفالت 3 | 0.07 | 0.16 |
| 606 | 10.2.8.3 | اجرای اساس ضلع جنوبی میدان در تراز همسطح |  | 5d | 2025-11-17 A | 2025-11-21 A | 605 | 100% |  |  |  | اساس [6299 مترمربع] | 5,669,100 | 5,669,100 | 0% | 0% | 0% | 0% | 0% | 0% | 0% | 0% | No | اساس | اجرا | میدان در تراز همسطح | ضلع جنوبی | پیمانکار آسفالت 3 | 0.11 | 0.11 |
| 607 | 10.2.8.4 | اجرای آسفالت ضلع جنوبی میدان در تراز همسطح |  | 5d | 2025-11-22 A | 2025-11-27 A | 606 | 100% |  |  |  | آسفالت [6210 مترمربع] | 18,630,000 | 18,630,000 | 0% | 0% | 0% | 0% | 0% | 0% | 0% | 0% | No | آسفالت | اجرا | میدان در تراز همسطح | ضلع جنوبی | پیمانکار آسفالت 3 | 0.36 | 0.11 |
| 608 | 10.2.8.5 | اجرای خط کشی مسیر و نصب علایم ضلع جنوبی میدان در تراز همسطح |  | 2d | 2025-11-28 A | 2025-11-29 A | 607 | 100% |  |  |  | رنگ آمیزی مسیر [2242 مترطول مسیر] | 6,726,000 | 6,726,000 | 0% | 0% | 0% | 0% | 0% | 0% | 0% | 0% | No | رنگ آمیزی مسیر | اجرا | میدان در تراز همسطح | ضلع جنوبی | پیمانکار نصب علائم و رنگ آمیزی 1 | 0.13 | 0.04 |
| 609 | 11 | برچیدن کارگاه |  | 20d | 2026-12-01 | 2026-12-20 | 38FS-19d, 55FS-19d, 72FS-19d, 89FS-19d, 196FS-19d, 221FS-19d, 343FS-19d, 368FS-19d, 419FS-19d, 469FS-19d, 489FS-19d, 488FS-19d, 487FS-19d, 486FS-19d, 524FS-19d, 558FS-19d, 573FS-19d, 591FS-19d, 608FS-19d |  |  | 0d |  | برچیدن [1 مقطوع] | 77,000,000 |  | 0% | 0% | 0% | 0% | 0% | 0% | 0% | 0% | No | تجهیز و برچیدن |  | تجهیز و برچیدن کارگاه | برچیدن |  | 1.48 | 0.45 |
| 610 | 12 | پایان | milestone | 0d | 2026-12-20 | 2026-12-20 | 609 |  |  | 0d |  |  |  |  | 0% | 0% | 0% | 0% | 0% | 0% | 0% | 0% | No |  |  |  |  |  | 0.00 | 0.00 |
